# EPDP-P2_Project_Plan_20190815

How a schedule from MS Project changed from version to version. A marks actual dates.

## Version 1 (saved 2019-08-18, file EPDP-P2_Project_Plan_20190815.mpp)

| ID | WBS | Task | Duration | Start | Finish | Predecessors | Complete | Total float | Constraint |
| --- | --- | --- | --- | --- | --- | --- | --- | --- | --- |
| 1 | 1 | **EPDP - Phase 2 Policy Development** | 419d | 2019-03-04 A | 2020-10-06 |  | 19% | 0d |  |
| 2 | 1.1 | **PROJECT MANAGEMENT** | 419d | 2019-03-04 A | 2020-10-06 |  | 53% | 0d |  |
| 3 |  | Project start confirmed | 1d | 2019-03-04 A | 2019-03-04 A |  | 100% |  |  |
| 4 |  | Adopt/Confirm charter | 1d | 2019-03-05 A | 2019-03-05 A | 3 | 100% |  |  |
| 5 |  | Confirmation of EPDP Team | 20d | 2019-03-05 A | 2019-04-01 A | 3 | 100% |  |  |
| 6 |  | Appointment of EPDP Team Chair | 30d | 2019-03-05 A | 2019-04-15 A | 3 | 100% |  |  |
| 7 |  | Appointment of EPDP Liaison to GNSO Council | 5d | 2019-04-16 A | 2019-04-22 A | 6 | 100% |  |  |
| 8 |  | Chair / Staff preparations | 12d | 2019-04-16 A | 2019-05-01 A | 6 | 100% |  |  |
| 9 | 1.1.7 | **Project Management** | 417d | 2019-03-06 A | 2020-10-06 |  | 50% | 0d |  |
| 10 |  | Develop and confirm Project Plan | 90d | 2019-04-16 A | 2019-08-19 A | 6 | 100% |  |  |
| 11 |  | Adopt iterative work plan(s) | 90d | 2019-04-16 A | 2019-08-19 A | 6 | 100% |  |  |
| 12 |  | Develop Project status work products and communications | 90d | 2019-04-16 A | 2019-08-19 A | 6 | 100% |  |  |
| 13 |  | Obtain project plan approval from GNSO Council | 1d | 2019-08-22 | 2019-08-22 | 12 |  | 19d | start no earlier than 2019-08-22 |
| 14 | 1.1.7.5 | **Leadership Sub team** | 275d | 2019-04-16 A | 2020-04-30 |  | 25% | 93d |  |
| 15 |  | On-going preparation and planning of EPDP-P2 activities | 275d | 2019-04-16 A | 2020-04-30 | 6 | 25% | 93d |  |
| 16 | 1.1.7.6 | **Project Cost Support Team Sub team** | 360d | 2019-03-06 A | 2020-07-17 |  | 37% | 57d |  |
| 17 |  | Develop EPDP Fact Sheet | 30d | 2019-04-16 A | 2019-05-27 A | 6 | 100% |  |  |
| 18 |  | Request and acquire preliminary dedicated funds for additional project resources | 20d | 2019-03-06 A | 2019-04-02 A | 4 | 100% |  |  |
| 19 |  | Request and acquire funds for dedicated F2F sessions & facilitation services | 20d | 2019-05-02 A | 2019-05-29 A | 8 | 100% |  |  |
| 20 |  | Request and acquire final dedicated funds for additional project resources | 20d | 2019-08-27 A | 2019-10-08 | 13 | 30% | 262d |  |
| 21 |  | On-going financial and resource approvals of EPDP-P2 activities | 360d | 2019-03-06 A | 2020-07-17 | 4 | 25% | 37d |  |
| 22 |  | Close project plan, Factsheet, and transition project to IPT | 20d | 2020-09-09 | 2020-10-06 | 21, 15, 320 |  | 0d |  |
| 23 | 1.2 | **EPDP DELIBERATIONS** | 310d | 2019-04-03 A | 2020-06-05 |  | 13% | 87d |  |
| 24 |  | First meeting of EPDP Team | 1d | 2019-05-02 A | 2019-05-02 A | 8 | 100% |  |  |
| 25 |  | Understand Charter, organize materials and develop initial approach | 15d | 2019-05-02 A | 2019-05-22 A | 8 | 100% |  |  |
| 26 |  | Develop Worksheets for Phase 2 due diligence and organize work by Priority 1 & 2 Topics | 21d | 2019-05-02 A | 2019-05-30 A | 8 | 100% |  |  |
| 27 |  | Review prior legal advice memos and formulate potential topics that may require advice | 21d | 2019-05-02 A | 2019-05-30 A | 8 | 100% |  |  |
| 28 |  | Develop definitions and terminology | 21d | 2019-05-02 A | 2019-05-30 A | 8 | 100% |  |  |
| 29 | 1.2.6 | **Input from other SO/ACs & GNSO SG/Cs** | 74d | 2019-05-23 A | 2019-09-03 |  | 51% | 287d |  |
| 30 |  | Develop template for input | 5d | 2019-05-23 A | 2019-05-29 A | 25 | 100% |  |  |
| 31 |  | Announce input opportunity | 1d | 2019-05-30 A | 2019-05-30 A | 30 | 100% |  |  |
| 32 |  | Collect and collate input in to Review Tool | 28d | 2019-05-31 A | 2019-07-09 A | 31 | 100% |  |  |
| 33 |  | Group to review input and determine relevance to policy deliberations on issues within scope | 20d | 2019-07-10 A | 2019-08-06 | 32 | 20% | 287d |  |
| 34 |  | Review and assign early input for inclusion in SSAD and other worksheets | 20d | 2019-08-07 | 2019-09-03 | 33 |  | 287d |  |
| 35 | 1.2.7 | **Priority 1 Deliberations** | 125d | 2019-05-31 A | 2019-11-19 |  | 8% | 230d |  |
| 36 | 1.2.7.1 | **Requirements, incl. defining user groups, use cases and other criteria to determine similarities and differences** | 70d | 2019-05-31 A | 2019-09-05 |  | 36% | 0d |  |
| 37 |  | Deliberate Groups to Use Case approach | 10d | 2019-06-14 A | 2019-06-27 A | 26 | 100% |  |  |
| 38 |  | Deliberate Single Use Case to establish Template | 10d | 2019-06-14 A | 2019-06-27 A | 26 | 100% |  |  |
| 39 | 1.2.7.1.3 | **Generate potential Use Cases (refer to 20+ on wiki)** | 70d | 2019-05-31 A | 2019-09-05 | 38 | 31% | 0d |  |
| 40 |  | Confirm Use Case order and groups to consolidate | 50d | 2019-06-28 A | 2019-09-05 |  | 90% | 0d |  |
| 41 |  | Understand Purposes and Legitimate Interest for third party disclosure | 10d | 2019-05-31 A | 2019-07-02 |  | 75% | 47.5d |  |
| 42 |  | First reading + response | 50d | 2019-06-28 A | 2019-09-05 |  | 20% | 0d |  |
| 43 |  | Deliberate other policy topics as necessary to better inform dedicated time to that topic | 30d | 2019-06-28 A | 2019-08-08 |  | 20% | 20d |  |
| 44 |  | Develop subsequent draft + response | 50d | 2019-06-28 A | 2019-09-05 |  | 10% | 0d |  |
| 45 |  | Second reading + adoption or discard | 50d | 2019-06-28 | 2019-09-05 |  |  | 0d |  |
| 46 | 1.2.7.2 | **SSAD Model & Worksheets & Preliminary Recommendations** | 75d | 2019-08-09 A | 2019-11-19 |  | 1% | 230d |  |
| 47 | 1.2.7.2.1 | **Safeguards** | 74.5d | 2019-08-09 A | 2019-11-19 |  | 2% | 230.5d |  |
| 48 |  | Review inputs from Requirements and Use Cases | 5d | 2019-08-09 A | 2019-09-12 | 39 | 45% | 1.25d |  |
| 49 | 1.2.7.2.1.2 | **Understand sub-topics and determine need to deliberate** | 10d | 2019-09-12 | 2019-09-26 |  |  | 0d |  |
| 50 |  | Query volume limitations | 10d | 2019-09-12 | 2019-09-26 | 48 |  |  |  |
| 51 |  | Code of conduct | 10d | 2019-09-12 | 2019-09-26 | 48 |  |  |  |
| 52 |  | Terms of use / disclosure agreements | 10d | 2019-09-12 | 2019-09-26 | 48 |  |  |  |
| 53 |  | Privacy policies | 10d | 2019-09-12 | 2019-09-26 | 48 |  |  |  |
| 54 |  | Retention and destruction of data | 10d | 2019-09-12 | 2019-09-26 | 48 |  |  |  |
| 55 |  | Service level agreements | 10d | 2019-09-12 | 2019-09-26 | 48 |  |  |  |
| 56 |  | Transfer of the Data | 10d | 2019-09-12 | 2019-09-26 | 48 |  |  |  |
| 57 |  | Disclosure of the Data | 10d | 2019-09-12 | 2019-09-26 | 48 |  |  |  |
| 58 |  | Monitoring | 10d | 2019-09-12 | 2019-09-26 | 48 |  |  |  |
| 59 |  | Audit trail | 10d | 2019-09-12 | 2019-09-26 | 48 |  |  |  |
| 60 |  | Retention | 10d | 2019-09-12 | 2019-09-26 | 48 |  |  |  |
| 61 |  | Destruction of data | 10d | 2019-09-12 | 2019-09-26 | 48 |  |  |  |
| 62 |  | Deliberate policy considerations and determine approach | 5d | 2019-09-26 A | 2019-10-03 | 49 | 25% | 0.5d |  |
| 63 |  | Deliberate policy issues | 20d | 2019-10-03 | 2019-10-31 | 62 |  | 0.5d |  |
| 64 |  | Develop draft work product | 30d | 2019-10-03 | 2019-11-12 | 62 |  | 230.5d |  |
| 65 |  | Conduct First Reading + verbal and email response | 10d | 2019-10-03 | 2019-10-17 | 62 |  | 250.5d |  |
| 66 |  | Conduct Second Reading + verbal response + adoption or discard | 5d | 2019-11-12 | 2019-11-19 | 64, 65 |  | 230.5d |  |
| 67 | 1.2.7.2.2 | **Accreditation and Authentication (Credentialing)** | 55d | 2019-09-06 A | 2019-11-19 |  | 1% | 230d |  |
| 68 |  | Understand topic and determine need to deliberate | 5d | 2019-09-06 A | 2019-09-12 | 39 | 25% | 280d |  |
| 69 |  | Deliberate policy considerations and determine approach | 5d | 2019-09-06 | 2019-09-12 | 39 |  | 0d |  |
| 70 |  | Deliberate policy issues | 35d | 2019-09-13 | 2019-10-31 | 69 |  | 0d |  |

| ID | WBS | Task | Duration | Start | Finish | Predecessors | Complete | Total float |
| --- | --- | --- | --- | --- | --- | --- | --- | --- |
| 71 |  | Develop draft work product | 45d | 2019-09-13 | 2019-11-12 | 69 |  | 230d |
| 72 |  | Conduct First Reading + verbal and email response | 10d | 2019-09-13 | 2019-09-26 | 69 |  | 265d |
| 73 |  | Conduct Second Reading + verbal response + adoption or discard | 5d | 2019-11-13 | 2019-11-19 | 71, 72 |  | 230d |
| 74 | 1.2.7.2.3 | **Lawful Basis & Balancing Test** | 55d | 2019-09-06 A | 2019-11-19 |  | 1% | 230d |
| 75 |  | Understand topic and determine need to deliberate | 5d | 2019-09-06 A | 2019-09-12 | 39 | 25% | 280d |
| 76 |  | Deliberate policy considerations and determine approach | 5d | 2019-09-06 | 2019-09-12 | 39 |  | 0d |
| 77 |  | Deliberate policy issues | 35d | 2019-09-13 | 2019-10-31 | 76 |  | 0d |
| 78 |  | Develop draft work product | 45d | 2019-09-13 | 2019-11-12 | 76 |  | 230d |
| 79 |  | Conduct First Reading + verbal and email response | 10d | 2019-09-13 | 2019-09-26 | 76 |  | 265d |
| 80 |  | Conduct Second Reading + verbal response + adoption or discard | 5d | 2019-11-13 | 2019-11-19 | 78, 79 |  | 230d |
| 81 | 1.2.7.2.4 | **Determine Process publication, format and content request requirements** | 55d | 2019-09-06 | 2019-11-19 |  |  | 0d |
| 82 |  | Understand topic and determine need to deliberate | 5d | 2019-09-06 | 2019-09-12 | 39 |  | 280d |
| 83 |  | Deliberate policy considerations and determine approach | 5d | 2019-09-06 | 2019-09-12 | 39 |  | 0d |
| 84 |  | Deliberate policy issues | 35d | 2019-09-13 | 2019-10-31 | 83 |  | 0d |
| 85 |  | Develop draft work product | 45d | 2019-09-13 | 2019-11-12 | 83 |  | 230d |
| 86 |  | Conduct First Reading + verbal and email response | 10d | 2019-09-13 | 2019-09-26 | 83 |  | 265d |
| 87 |  | Conduct Second Reading + verbal response + adoption or discard | 5d | 2019-11-13 | 2019-11-19 | 85, 86 |  | 230d |
| 88 | 1.2.7.2.5 | **Timeline of process** | 55d | 2019-09-06 | 2019-11-19 |  |  | 0d |
| 89 |  | Understand topic and determine need to deliberate | 5d | 2019-09-06 | 2019-09-12 | 39 |  | 280d |
| 90 |  | Deliberate policy considerations and determine approach | 5d | 2019-09-06 | 2019-09-12 | 39 |  | 0d |
| 91 |  | Deliberate policy issues | 35d | 2019-09-13 | 2019-10-31 | 90 |  | 0d |
| 92 |  | Develop draft work product | 45d | 2019-09-13 | 2019-11-12 | 90 |  | 230d |
| 93 |  | Conduct First Reading + verbal and email response | 10d | 2019-09-13 | 2019-09-26 | 90 |  | 265d |
| 94 |  | Conduct Second Reading + verbal response + adoption or discard | 5d | 2019-11-13 | 2019-11-19 | 92, 93 |  | 230d |
| 95 | 1.2.7.2.6 | **Automation Analysis + Centralized vs. De-Centralized Models** | 55d | 2019-09-06 | 2019-11-19 |  |  | 0d |
| 96 |  | Understand topic and determine need to deliberate | 5d | 2019-09-06 | 2019-09-12 | 39 |  | 280d |
| 97 |  | Deliberate policy considerations and determine approach | 5d | 2019-09-06 | 2019-09-12 | 39 |  | 0d |
| 98 |  | Deliberate policy issues | 35d | 2019-09-13 | 2019-10-31 | 97 |  | 0d |
| 99 |  | Determine if automation is consistent with legal requirements/legal basis | 45d | 2019-09-13 | 2019-11-12 | 97 |  | 235d |
| 100 |  | Develop draft work product | 45d | 2019-09-13 | 2019-11-12 | 97 |  | 230d |
| 101 |  | Conduct First Reading + verbal and email response | 10d | 2019-09-13 | 2019-09-26 | 97 |  | 265d |
| 102 |  | Conduct Second Reading + verbal response + adoption or discard | 5d | 2019-11-13 | 2019-11-19 | 100, 101 |  | 230d |
| 103 | 1.2.7.2.7 | **Review possible comprehensive model and options** | 55d | 2019-09-06 | 2019-11-19 |  |  | 0d |
| 104 |  | Understand topic and determine need to deliberate | 5d | 2019-09-06 | 2019-09-12 | 39 |  | 280d |
| 105 |  | Deliberate policy considerations and determine approach | 5d | 2019-09-06 | 2019-09-12 | 39 |  | 0d |
| 106 |  | Deliberate policy issues | 35d | 2019-09-13 | 2019-10-31 | 105 |  | 0d |
| 107 |  | Develop draft work product | 45d | 2019-09-13 | 2019-11-12 | 105 |  | 230d |
| 108 |  | Conduct First Reading + verbal and email response | 10d | 2019-09-13 | 2019-09-26 | 105 |  | 265d |
| 109 |  | Conduct Second Reading + verbal response + adoption or discard | 5d | 2019-11-13 | 2019-11-19 | 107, 108 |  | 230d |
| 110 | 1.2.7.2.8 | **Financial sustainability** | 55d | 2019-09-06 | 2019-11-19 |  |  | 0d |
| 111 |  | Understand topic and determine need to deliberate | 5d | 2019-09-06 | 2019-09-12 | 39 |  | 280d |
| 112 |  | Deliberate policy considerations and determine approach | 5d | 2019-09-06 | 2019-09-12 | 39 |  | 0d |
| 113 |  | Deliberate policy issues | 35d | 2019-09-13 | 2019-10-31 | 112 |  | 0d |
| 114 |  | Develop draft work product | 45d | 2019-09-13 | 2019-11-12 | 112 |  | 230d |
| 115 |  | Conduct First Reading + verbal and email response | 10d | 2019-09-13 | 2019-09-26 | 112 |  | 265d |
| 116 |  | Conduct Second Reading + verbal response + adoption or discard | 5d | 2019-11-13 | 2019-11-19 | 114, 115 |  | 230d |
| 117 |  | Priority 1 Day Zero documents for LA1 F2F2 | 0d | 2019-09-05 | 2019-09-05 | 36 |  | 285d |
| 118 |  | Priority 1 Day Zero documents for ICANN66 Montreal | 0d | 2019-10-31 | 2019-10-31 | 63, 70, 77, 84, 91, 98, 106, 113 |  | 0d |
| 119 | 1.2.8 | **Priority 2 Deliberations (Issues carried from Phase 1)** | 227d | 2019-05-31 A | 2020-04-09 |  | 2% | 128d |
| 120 |  | Organize Priority 2 topics | 1d | 2019-05-31 | 2019-05-31 | 26 |  | 354d |
| 121 | 1.2.8.2 | **Display of information of affiliated vs. accredited privacy / proxy providers** | 200d | 2019-06-03 A | 2020-03-04 |  | 1% | 154d |
| 122 |  | Initial Scoping of topic | 5d | 2019-06-03 A | 2019-06-07 A | 120 | 100% |  |
| 123 | 1.2.8.2.2 | **Understand topic and determine need to deliberate** | 80d | 2019-06-10 | 2019-09-27 |  |  | 154d |
| 124 |  | PPSAI IRT briefing to determine how their work compliments or depends on EPDP | 80d | 2019-06-10 | 2019-09-27 | 122 |  | 154d |
| 125 |  | Determine if briefing regarding a data privacy impact assessment on the PPSAI program is required | 80d | 2019-06-10 | 2019-09-27 | 122 |  | 154d |
| 126 |  | Determine if answers to legal questions are required | 80d | 2019-06-10 | 2019-09-27 | 122 |  | 154d |
| 127 |  | Deliberate policy considerations and determine approach | 5d | 2019-09-30 | 2019-10-04 | 123 |  | 154d |
| 128 |  | Deliberate policy issues | 90d | 2019-10-07 | 2020-02-05 | 127 |  | 154d |
| 129 |  | Develop draft work product | 10d | 2020-02-06 | 2020-02-19 | 128 |  | 154d |
| 130 |  | Conduct First Reading + verbal and email response | 5d | 2020-02-20 | 2020-02-26 | 129 |  | 154d |
| 131 |  | Conduct Second Reading + verbal response + adoption or discard | 5d | 2020-02-27 | 2020-03-04 | 130 |  | 154d |
| 132 | 1.2.8.3 | **Legal vs. Natural** | 200d | 2019-06-03 A | 2020-03-04 |  | 1% | 154d |
| 133 |  | Initial Scoping of topic | 5d | 2019-06-03 A | 2019-06-07 A | 120 | 100% |  |
| 134 | 1.2.8.3.2 | **Understand topic and determine need to deliberate** | 80d | 2019-06-10 | 2019-09-27 |  |  | 154d |
| 135 |  | Receive briefing from Bird & Bird on legal vs. natural memo | 80d | 2019-06-10 | 2019-09-27 | 133 |  | 154d |
| 136 |  | Determine if answers to legal questions are required | 80d | 2019-06-10 | 2019-09-27 | 133 |  | 154d |
| 137 |  | EPDP Team to confirm with ICANN Org expected next steps and timing to conduct and publish the study results. | 80d | 2019-06-10 | 2019-09-27 | 133 |  | 154d |
| 138 |  | EPDP Team or Sub-team to work with ICANN org on this study, including providing questions and/or relevant background to assist in informing the study by 1 July 2019. | 80d | 2019-06-10 | 2019-09-27 | 133 |  | 154d |
| 139 |  | Deliberate policy considerations and determine approach | 5d | 2019-09-30 | 2019-10-04 | 134 |  | 154d |
| 140 |  | Deliberate policy issues | 90d | 2019-10-07 | 2020-02-05 | 139 |  | 154d |

| ID | WBS | Task | Duration | Start | Finish | Predecessors | Complete | Total float | Constraint |
| --- | --- | --- | --- | --- | --- | --- | --- | --- | --- |
| 141 |  | Develop draft work product | 10d | 2020-02-06 | 2020-02-19 | 140 |  | 154d |  |
| 142 |  | Conduct First Reading + verbal and email response | 5d | 2020-02-20 | 2020-02-26 | 141 |  | 154d |  |
| 143 |  | Conduct Second Reading + verbal response + adoption or discard | 5d | 2020-02-27 | 2020-03-04 | 142 |  | 154d |  |
| 144 | 1.2.8.4 | **City Field** | 200d | 2019-06-11 A | 2020-03-12 |  | 2% | 148d |  |
| 145 |  | Initial Scoping of topic | 5d | 2019-06-11 A | 2019-06-17 A | 120 | 100% |  | start no earlier than 2019-06-11 |
| 146 | 1.2.8.4.2 | **Understand topic and determine need to deliberate** | 80d | 2019-06-18 | 2019-10-07 |  |  | 148d |  |
| 147 |  | Receive briefing from Bird & Bird on city field memo | 80d | 2019-06-18 | 2019-10-07 | 145 |  | 148d |  |
| 148 |  | Determine if answers to legal questions are required | 80d | 2019-06-18 | 2019-10-07 | 145 |  | 148d |  |
| 149 |  | Deliberate policy considerations and determine approach | 5d | 2019-10-08 | 2019-10-14 | 146 |  | 148d | start no earlier than 2019-06-11 |
| 150 |  | Deliberate policy issues | 90d | 2019-10-15 | 2020-02-13 | 149 |  | 148d |  |
| 151 |  | Develop draft work product | 10d | 2020-02-14 | 2020-02-27 | 150 |  | 148d |  |
| 152 |  | Conduct First Reading + verbal and email response | 5d | 2020-02-28 | 2020-03-05 | 151 |  | 148d |  |
| 153 |  | Conduct Second Reading + verbal response + adoption or discard | 5d | 2020-03-06 | 2020-03-12 | 152 |  | 148d |  |
| 154 | 1.2.8.5 | **Data Retention** | 200d | 2019-06-11 A | 2020-03-12 |  | 3% | 148d |  |
| 155 |  | Initial Scoping of topic | 5d | 2019-06-11 A | 2019-06-17 A | 120 | 100% |  | start no earlier than 2019-06-11 |
| 156 | 1.2.8.5.2 | **Understand topic and determine need to deliberate** | 80d | 2019-06-18 | 2019-10-07 |  |  | 148d |  |
| 157 |  | Confirm with ICANN org when the review of all of ICANN org's processes and procedures to identify and document the instances in which personal data is requested beyond the life of domain name registration is expected to be completed. | 80d | 2019-06-18 | 2019-10-07 | 155 |  | 148d |  |
| 158 |  | Deliberate policy considerations and determine approach | 5d | 2019-10-08 | 2019-10-14 | 156 |  | 148d | start no earlier than 2019-06-11 |
| 159 | 1.2.8.5.4 | **Deliberate policy issues** | 90d | 2019-10-15 | 2020-02-13 |  |  | 148d |  |
| 160 |  | Confirm whether the data retention requirements recommended in phase 1 are to be confirmed or whether updates are needed | 90d | 2019-10-15 | 2020-02-13 | 158 |  | 148d |  |
| 161 |  | Develop draft work product | 10d | 2020-02-14 | 2020-02-27 | 159 |  | 148d |  |
| 162 |  | Conduct First Reading + verbal and email response | 5d | 2020-02-28 | 2020-03-05 | 161 |  | 148d |  |
| 163 |  | Conduct Second Reading + verbal response + adoption or discard | 5d | 2020-03-06 | 2020-03-12 | 162 |  | 148d |  |
| 164 | 1.2.8.6 | **Additional purpose for ICANN’s OCTO** | 200d | 2019-06-17 A | 2020-03-18 |  | 2% | 144d |  |
| 165 |  | Initial Scoping of topic | 5d | 2019-06-17 A | 2019-06-21 A | 120 | 100% |  | start no earlier than 2019-06-17 |
| 166 | 1.2.8.6.2 | **Understand topic and determine need to deliberate** | 80d | 2019-06-24 | 2019-10-11 |  |  | 144d |  |
| 167 |  | Further to EPDP-P1 Rec#2, EPDP Team to draft question to ICANN org, to inform next steps. | 80d | 2019-06-24 | 2019-10-11 | 165 |  | 144d |  |
| 168 |  | Determine if answers to legal questions are required | 80d | 2019-06-24 | 2019-10-11 | 165 |  | 144d |  |
| 169 |  | Deliberate policy considerations and determine approach | 5d | 2019-10-14 | 2019-10-18 | 166 |  | 144d | start no earlier than 2019-06-17 |
| 170 |  | Deliberate policy issues | 90d | 2019-10-21 | 2020-02-19 | 169 |  | 144d |  |
| 171 |  | Develop draft work product | 10d | 2020-02-20 | 2020-03-04 | 170 |  | 144d |  |
| 172 |  | Conduct First Reading + verbal and email response | 5d | 2020-03-05 | 2020-03-11 | 171 |  | 144d |  |
| 173 |  | Conduct Second Reading + verbal response + adoption or discard | 5d | 2020-03-12 | 2020-03-18 | 172 |  | 144d |  |
| 174 | 1.2.8.7 | **Feasibility of unique contacts to have uniform anonymized email address** | 200d | 2019-06-17 A | 2020-03-18 |  | 3% | 144d |  |
| 175 |  | Initial Scoping of topic | 5d | 2019-06-17 A | 2019-06-21 A | 120 | 100% |  | start no earlier than 2019-06-17 |
| 176 | 1.2.8.7.2 | **Understand topic and determine need to deliberate** | 80d | 2019-06-24 | 2019-10-11 |  |  | 144d |  |
| 177 |  | Determine if answers to legal questions are required | 80d | 2019-06-24 | 2019-10-11 | 175 |  | 144d |  |
| 178 |  | Deliberate policy considerations and determine approach | 5d | 2019-10-14 | 2019-10-18 | 176 |  | 144d | start no earlier than 2019-06-17 |
| 179 |  | Deliberate policy issues | 90d | 2019-10-21 | 2020-02-19 | 178 |  | 144d |  |
| 180 |  | Develop draft work product | 10d | 2020-02-20 | 2020-03-04 | 179 |  | 144d |  |
| 181 |  | Conduct First Reading + verbal and email response | 5d | 2020-03-05 | 2020-03-11 | 180 |  | 144d |  |
| 182 |  | Conduct Second Reading + verbal response + adoption or discard | 5d | 2020-03-12 | 2020-03-18 | 181 |  | 144d |  |
| 183 | 1.2.8.8 | **Data Accuracy and the WHOIS Accuracy Reporting System** | 200d | 2019-07-09 A | 2020-04-09 |  | 2% | 128d |  |
| 184 |  | Initial Scoping of topic | 5d | 2019-07-09 A | 2019-07-15 A | 120 | 100% |  | start no earlier than 2019-07-09 |
| 185 | 1.2.8.8.2 | **Understand topic and determine need to deliberate** | 80d | 2019-07-16 | 2019-11-02 |  |  | 128d |  |
| 186 |  | Receive briefing from Bird & Bird on city field memo | 80d | 2019-07-16 | 2019-11-02 | 184 |  | 128d |  |
| 187 |  | Determine if answers to legal questions are required | 80d | 2019-07-16 | 2019-11-02 | 184 |  | 128d |  |
| 188 |  | Deliberate policy considerations and determine approach | 5d | 2019-11-03 | 2019-11-07 | 185 |  | 128d | start no earlier than 2019-07-09 |
| 189 |  | Deliberate policy issues | 90d | 2019-11-08 | 2020-03-12 | 188 |  | 128d |  |
| 190 |  | Develop draft work product | 10d | 2020-03-13 | 2020-03-26 | 189 |  | 128d |  |
| 191 |  | Conduct First Reading + verbal and email response | 5d | 2020-03-27 | 2020-04-02 | 190 |  | 128d |  |
| 192 |  | Conduct Second Reading + verbal response + adoption or discard | 5d | 2020-04-03 | 2020-04-09 | 191 |  | 128d |  |
| 193 | 1.2.9 | **Unplanned Issues & Tasks** | 80d | 2019-12-04 | 2020-03-24 |  |  | 140d |  |
| 194 | 1.2.9.1 | **Phase 2 discussion on Geographic Basis** | 80d | 2019-12-04 | 2020-03-24 |  |  | 140d |  |
| 195 |  | Understand topic and determine need to deliberate | 5d | 2019-12-04 | 2019-12-10 | 303 |  | 140d | start no earlier than 2019-08-22 |
| 196 |  | Deliberate policy considerations and determine approach | 5d | 2019-12-11 | 2019-12-17 | 195 |  | 140d | start no earlier than 2019-08-22 |
| 197 |  | Deliberate policy issues | 60d | 2019-12-18 | 2020-03-10 | 196 |  | 150d |  |
| 198 |  | Develop draft work product | 60d | 2019-12-18 | 2020-03-10 | 196 |  | 140d |  |
| 199 |  | Conduct First Reading + verbal and email response | 5d | 2020-03-11 | 2020-03-17 | 198 |  | 140d |  |
| 200 |  | Conduct Second Reading + verbal response + adoption or discard | 5d | 2020-03-18 | 2020-03-24 | 199 |  | 140d |  |
| 201 | 1.2.9.2 | **Phase 2 discussion on Thick Whois coming from IRT>Board>Council>EPDP2>Council>Board** | 80d | 2019-12-04 | 2020-03-24 |  |  | 140d |  |
| 202 |  | Understand topic and determine need to deliberate | 5d | 2019-12-04 | 2019-12-10 | 303 |  | 140d | start no earlier than 2019-08-22 |
| 203 |  | Deliberate policy considerations and determine approach | 5d | 2019-12-11 | 2019-12-17 | 202 |  | 140d | start no earlier than 2019-08-22 |
| 204 |  | Deliberate policy issues | 60d | 2019-12-18 | 2020-03-10 | 203 |  | 150d |  |
| 205 |  | Develop draft work product | 60d | 2019-12-18 | 2020-03-10 | 203 |  | 140d |  |
| 206 |  | Conduct First Reading + verbal and email response | 5d | 2020-03-11 | 2020-03-17 | 205 |  | 140d |  |
| 207 |  | Conduct Second Reading + verbal response + adoption or discard | 5d | 2020-03-18 | 2020-03-24 | 206 |  | 140d |  |
| 208 | 1.2.10 | **Legal Sub team** | 133d | 2019-05-30 A | 2019-11-28 |  | 46% | 123d |  |
| 209 |  | Establish operating framework for handling legal advice requirements | 33d | 2019-05-30 A | 2019-07-15 A |  | 100% |  | start no earlier than 2019-05-30 |
| 210 |  | Select members and establish chair | 33d | 2019-05-30 A | 2019-07-15 A |  | 100% |  | start no earlier than 2019-05-30 |

| ID | WBS | Task | Duration | Start | Finish | Predecessors | Complete | Total float | Constraint |
| --- | --- | --- | --- | --- | --- | --- | --- | --- | --- |
| 211 |  | On-going review of legal questions / advice and interaction with counsel for Initial Report | 100d | 2019-07-16 A | 2019-11-28 | 209 | 10% | 123d |  |
| 212 | 1.2.11 | **Key Events** | 310d | 2019-04-03 A | 2020-06-05 |  | 22% | 87d |  |
| 213 | 1.2.11.1 | **EPDP Team F2F Meeting - Marrakech (24-27 Jun 2019)** | 111d | 2019-04-03 A | 2019-09-04 |  | 91% | 286d |  |
| 214 |  | Determine requirements and scope | 1d | 2019-04-03 A | 2019-04-03 A | 18 | 100% |  |  |
| 215 |  | Obtain PCST approval | 10d | 2019-04-04 A | 2019-04-17 A | 214 | 100% |  |  |
| 216 |  | Interact with Meetings Team | 75d | 2019-04-18 A | 2019-07-31 A | 215 | 100% |  |  |
| 217 |  | Engage EPDP team to confirm RSVPs and manage applications for travel support | 30d | 2019-04-18 A | 2019-05-29 A | 215 | 100% |  |  |
| 218 |  | Engage facilitators - not required | 0d | 2019-04-17 A | 2019-04-17 A | 215 | 100% |  |  |
| 219 |  | Plan agenda | 45d | 2019-04-18 A | 2019-06-19 A | 215 | 100% |  |  |
| 220 |  | Confirm Day 0 work products (see tasks above) | 0d | 2019-06-13 A | 2019-06-13 A | 215, 39 | 100% |  |  |
| 221 |  | Day 0 preparations | 1d | 2019-06-21 A | 2019-06-21 A | 219 | 100% |  | start no earlier than 2019-06-21 |
| 222 |  | Day 1 sessions | 1d | 2019-06-25 A | 2019-06-25 A | 221 | 100% |  | start no earlier than 2019-06-25 |
| 223 |  | Day 2 sessions | 1d | 2019-06-27 A | 2019-06-27 A | 222 | 100% |  | start no earlier than 2019-06-27 |
| 224 |  | F2F Recon and Sitrep | 0d | 2019-06-27 A | 2019-06-27 A | 223 | 100% |  |  |
| 225 |  | Communicate outcomes | 10d | 2019-06-28 A | 2019-07-11 A | 224 | 100% |  |  |
| 226 |  | Manage financial invoice, payment confirmation, and tracking (report to PCST) | 100d | 2019-04-18 A | 2019-09-04 | 215 | 75% | 286d |  |
| 227 |  | Close F2F | 0d | 2019-09-04 | 2019-09-04 | 226 |  | 286d |  |
| 228 | 1.2.11.2 | **EPDP Team F2F Meeting - Los Angeles (08-11 Sept 2019)** | 131d | 2019-05-30 A | 2019-11-26 |  | 36% | 225d |  |
| 229 |  | Determine requirements and scope | 1d | 2019-05-30 A | 2019-05-30 A | 19 | 100% |  |  |
| 230 |  | Obtain PCST approval | 20d | 2019-05-31 A | 2019-06-27 A | 229 | 100% |  |  |
| 231 |  | Interact with Meetings Team | 100d | 2019-06-07 A | 2019-10-24 | 230 | 35% | 250d |  |
| 232 |  | Evaluate locations and reserve hotel and facilities | 25d | 2019-06-07 A | 2019-07-11 A | 230 | 100% |  |  |
| 233 |  | Engage EPDP team to confirm RSVPs and manage applications for travel support | 30d | 2019-07-12 A | 2019-08-22 | 232 | 35% | 295d |  |
| 234 |  | Engage hotel and facilities support teams | 70d | 2019-07-12 A | 2019-10-17 | 232 | 75% | 255d |  |
| 235 |  | Research and schedule events as necessary | 45d | 2019-07-12 A | 2019-09-12 | 232 | 50% | 280d |  |
| 236 |  | Engage facilitators | 75d | 2019-06-07 A | 2019-09-19 | 230 | 35% | 275d |  |
| 237 |  | Plan agenda | 60d | 2019-06-07 A | 2019-09-11 | 230 | 10% | 267d |  |
| 238 |  | Confirm Day 0 work products (see tasks above) | 0d | 2019-09-05 | 2019-09-05 | 230, 117 |  | 285d |  |
| 239 |  | Day 0 preparations | 1d | 2019-09-08 | 2019-09-08 | 237 |  |  |  |
| 240 |  | Day 1 sessions | 1d | 2019-09-09 | 2019-09-09 | 239 |  | 271d |  |
| 241 |  | Day 2 sessions | 1d | 2019-09-10 | 2019-09-10 | 240 |  | 271d |  |
| 242 |  | Day 3 sessions | 1d | 2019-09-11 | 2019-09-11 | 241 |  | 271d |  |
| 243 |  | F2F Recon and Sitrep | 0d | 2019-09-11 | 2019-09-11 | 242 |  | 271d |  |
| 244 |  | Communicate outcomes | 10d | 2019-09-12 | 2019-09-25 | 243 |  | 271d |  |
| 245 |  | Manage financial invoice, payment confirmation, and tracking (report to PCST) | 110d | 2019-06-28 | 2019-11-26 | 230 |  | 225d |  |
| 246 |  | Close F2F | 0d | 2019-11-26 | 2019-11-26 | 245 |  | 225d |  |
| 247 | 1.2.11.3 | **EPDP Team F2F Meeting - Montreal (02-07 Nov 2019)** | 106d | 2019-08-23 | 2020-01-15 |  |  | 91d |  |
| 248 |  | Determine requirements and scope | 1d | 2019-08-23 | 2019-08-23 | 13 |  | 91d |  |
| 249 |  | Obtain PCST approval | 5d | 2019-08-26 | 2019-08-30 | 248 |  | 91d |  |
| 250 |  | Interact with Meetings Team | 75d | 2019-09-02 | 2019-12-11 | 249 |  | 214d |  |
| 251 |  | Engage EPDP team to confirm RSVPs and manage applications for travel support | 30d | 2019-09-02 | 2019-10-11 | 249 |  | 259d |  |
| 252 |  | Engage facilitators | 0d | 2019-08-30 | 2019-08-30 | 249 |  | 289d |  |
| 253 |  | Plan agenda | 40d | 2019-09-02 | 2019-10-25 | 249 |  | 91d |  |
| 254 |  | Confirm Day 0 work products (see tasks above) | 0d | 2019-10-31 | 2019-10-31 | 249, 118 |  | 245d |  |
| 255 |  | Day 0 preparations | 1d | 2019-11-01 | 2019-11-01 | 253 |  | 87d | start no earlier than 2019-11-01 |
| 256 |  | Day 1 sessions | 1d | 2019-11-02 | 2019-11-02 | 255 |  | 87d | start no earlier than 2019-11-02 |
| 257 |  | Day 2 sessions | 1d | 2019-11-03 | 2019-11-03 | 256 |  | 87d | start no earlier than 2019-11-03 |
| 258 |  | F2F Recon and Sitrep | 0d | 2019-11-03 | 2019-11-03 | 257 |  | 87d |  |
| 259 |  | Communicate outcomes | 10d | 2019-11-04 | 2019-11-15 | 258 |  | 232d |  |
| 260 |  | Manage financial invoice, payment confirmation, and tracking (report to PCST) | 100d | 2019-09-02 | 2020-01-15 | 249 |  | 189d |  |
| 261 |  | Close F2F | 0d | 2020-01-15 | 2020-01-15 | 260 |  | 189d |  |
| 262 | 1.2.11.4 | **EPDP Team F2F Meeting - TBD [Los Angeles] (End of Jan 2020)** | 135d | 2019-09-24 A | 2020-03-26 |  | 1% | 138d |  |
| 263 |  | Determine requirements and scope | 1d | 2019-09-24 A | 2019-09-24 A | 20 | 100% |  |  |
| 264 |  | Obtain PCST approval | 5d | 2019-09-24 A | 2019-09-30 A | 20 | 100% |  |  |
| 265 |  | Interact with Meetings Team | 100d | 2019-10-01 | 2020-02-13 | 264 |  | 168d |  |
| 266 |  | Evaluate locations and reserve hotel and facilities | 30d | 2019-10-01 | 2019-11-07 | 264 |  | 148d |  |
| 267 |  | Engage EPDP team to confirm RSVPs and manage applications for travel support | 30d | 2019-11-08 | 2019-12-19 | 266 |  | 208d |  |
| 268 |  | Engage hotel and facilities support teams | 90d | 2019-11-08 | 2020-03-12 | 266 |  | 148d |  |
| 269 |  | Research and schedule events as necessary | 50d | 2019-11-08 | 2020-01-16 | 266 |  | 188d |  |
| 270 |  | Engage facilitators | 90d | 2019-10-01 | 2020-01-30 | 264 |  | 178d |  |
| 271 |  | Plan agenda | 80d | 2019-10-01 | 2020-01-16 | 264 |  | 174d |  |
| 272 |  | Confirm Day 0 work products (see tasks above) | 0d | 2020-01-21 | 2020-01-21 | 264, 304 |  | 185d |  |
| 273 |  | Day 0 preparations | 1d | 2020-01-27 | 2020-01-27 | 271 |  | 168d | start no earlier than 2020-01-27 |
| 274 |  | Day 1 sessions | 1d | 2020-01-28 | 2020-01-28 | 273 |  | 168d |  |
| 275 |  | Day 2 sessions | 1d | 2020-01-29 | 2020-01-29 | 274 |  | 168d |  |
| 276 |  | Day 3 sessions | 1d | 2020-01-30 | 2020-01-30 | 275 |  | 168d |  |
| 277 |  | F2F Recon and Sitrep | 0d | 2020-01-30 | 2020-01-30 | 276 |  | 168d |  |
| 278 |  | Communicate outcomes | 10d | 2020-01-31 | 2020-02-13 | 277 |  | 168d |  |
| 279 |  | Manage financial invoice, payment confirmation, and tracking (report to PCST) | 130d | 2019-10-01 | 2020-03-26 | 264 |  | 138d |  |
| 280 |  | Close F2F | 0d | 2020-03-26 | 2020-03-26 | 279 |  | 138d |  |

| ID | WBS | Task | Duration | Start | Finish | Predecessors | Complete | Total float | Constraint |
| --- | --- | --- | --- | --- | --- | --- | --- | --- | --- |
| 281 | 1.2.11.5 | **EPDP Team F2F Meeting - Cancun (07-12 Mar 2020)** | 155d | 2019-11-04 | 2020-06-05 |  |  | 87d |  |
| 282 |  | Determine requirements and scope | 1d | 2019-11-04 | 2019-11-04 | 258 |  | 241d |  |
| 283 |  | Obtain PCST approval | 5d | 2019-11-04 | 2019-11-08 | 258 |  | 87d |  |
| 284 |  | Interact with Meetings Team | 75d | 2019-11-11 | 2020-02-21 | 283 |  | 162d |  |
| 285 |  | Engage EPDP team to confirm RSVPs and manage applications for travel support | 30d | 2019-11-11 | 2019-12-20 | 283 |  | 207d |  |
| 286 |  | Engage facilitators | 0d | 2019-11-08 | 2019-11-08 | 283 |  | 237d |  |
| 287 |  | Plan agenda | 40d | 2019-11-11 | 2020-01-03 | 283 |  | 184d |  |
| 288 |  | Confirm Day 0 work products (see tasks above) | 0d | 2019-11-08 | 2019-11-08 | 283, 118 |  | 237d |  |
| 289 |  | Day 0 preparations | 1d | 2020-03-06 | 2020-03-06 | 287 |  | 140d | start no earlier than 2020-03-06 |
| 290 |  | Day 1 sessions | 1d | 2020-03-09 | 2020-03-09 | 289 |  | 140d | start no earlier than 2019-11-02 |
| 291 |  | Day 2 sessions | 1d | 2020-03-10 | 2020-03-10 | 290 |  | 140d | start no earlier than 2019-11-03 |
| 292 |  | F2F Recon and Sitrep | 0d | 2020-03-10 | 2020-03-10 | 291 |  | 140d |  |
| 293 |  | Communicate outcomes | 10d | 2020-03-11 | 2020-03-24 | 292 |  | 140d |  |
| 294 |  | Manage financial invoice, payment confirmation, and tracking (report to PCST) | 150d | 2019-11-11 | 2020-06-05 | 283 |  | 87d |  |
| 295 |  | Close F2F | 0d | 2020-06-05 | 2020-06-05 | 294 |  | 87d |  |
| 296 | 1.3 | **INITIAL REPORT** | 150d | 2019-06-28 A | 2020-01-21 |  | 24% | 185d |  |
| 297 |  | Assemble initial conclusions | 90d | 2019-06-28 A | 2019-10-31 | 38 | 35% | 245d |  |
| 298 |  | Populate discussion papers with findings and potential recommendations | 90d | 2019-06-28 A | 2019-10-31 | 38 | 35% | 0d |  |
| 299 |  | Discuss/approve findings and interim recommendations | 10d | 2019-11-01 | 2019-11-12 | 118, 298 |  | 5d |  |
| 300 |  | Consolidate interim recommendations and findings | 15d | 2019-11-01 | 2019-11-19 | 118, 298 |  | 0d |  |
| 301 |  | Build Draft Report for public comment | 15d | 2019-11-01 | 2019-11-19 | 118, 298 |  | 0d |  |
| 302 |  | Approve Draft Report for public comment | 10d | 2019-11-20 | 2019-12-03 | 299, 300, 301 |  | 0d |  |
| 303 |  | Publish Initial Report | 0d | 2019-12-03 | 2019-12-03 | 302, 211 |  | 140d |  |
| 304 |  | Public comment forum on the Initial Report (49 days) | 35d | 2019-12-04 | 2020-01-21 | 302 |  | 0d |  |
| 305 | 1.4 | **FINAL REPORT** | 103d | 2019-11-29 | 2020-04-21 |  |  | 38d |  |
| 306 |  | Review of public comments | 25d | 2020-01-22 | 2020-02-25 | 304 |  | 0d |  |
| 307 |  | Continue deliberations of Priority 1 topics towards a Final Report | 40d | 2020-01-22 | 2020-03-17 | 304 |  | 145d |  |
| 308 |  | Continue deliberations of Priority 2 topics towards a Final Report | 40d | 2020-01-22 | 2020-03-17 | 304 |  | 145d |  |
| 309 |  | On-going review of legal questions / advice and interaction with counsel for Final Report | 100d | 2019-11-29 | 2020-04-16 | 211 |  | 123d |  |
| 310 |  | Build Final Report | 25d | 2020-02-26 | 2020-03-31 | 306 |  | 0d |  |
| 311 |  | Determine consensus levels on interim recommendations | 10d | 2020-04-01 | 2020-04-14 | 310 |  | 0d |  |
| 312 |  | Adopt final recommendations and report | 5d | 2020-04-15 | 2020-04-21 | 311 |  | 0d |  |
| 313 |  | Submission of Final Report to the GNSO Council | 0d | 2020-04-21 | 2020-04-21 | 312 |  | 0d |  |
| 314 | 1.5 | **POST EPDP ACTIVITIES** | 100d | 2020-04-22 | 2020-09-08 |  |  | 0d |  |
| 315 |  | Approval of Final Report and Recommendations by the GNSO Council | 40d | 2020-04-22 | 2020-06-16 | 313 |  | 0d |  |
| 316 |  | Report to the Board | 20d | 2020-06-17 | 2020-07-14 | 315 |  | 60d |  |
| 317 |  | Publish Recommendations for Public Comment | 35d | 2020-06-17 | 2020-08-04 | 315 |  | 0d |  |
| 318 |  | Inform GAC if Recommendations affect public policy | 35d | 2020-06-17 | 2020-08-04 | 315 |  | 45d |  |
| 319 |  | Board Paper | 20d | 2020-08-05 | 2020-09-01 | 317 |  | 0d |  |
| 320 |  | Board consideration / approval | 5d | 2020-09-02 | 2020-09-08 | 319 |  | 0d |  |

## Version 2 (saved 2019-09-01, file EPDP-P2_Project_Plan_20190831.mpp)

Last finish stays 2020-10-06. Complete tasks 48 → 59.

Added:

| ID | Task | Duration | Start | Finish | Predecessors |
| --- | --- | --- | --- | --- | --- |
| 116 | **Purpose 2 Rework per Phase 1 and Board Instruction to GNSO Council** | 55d | 2019-09-06 | 2019-11-19 | 35 |
| 117 | Understand topic and determine need to deliberate | 5d | 2019-09-06 | 2019-09-12 | 38 |
| 118 | Deliberate policy considerations and determine approach | 5d | 2019-09-06 | 2019-09-12 | 38 |
| 119 | Deliberate policy issues | 35d | 2019-09-13 | 2019-10-31 | 118 |
| 120 | Develop draft work product | 45d | 2019-09-13 | 2019-11-12 | 118 |
| 121 | Conduct First Reading + verbal and email response | 10d | 2019-09-13 | 2019-09-26 | 118 |
| 122 | Conduct Second Reading + verbal response + adoption or discard | 5d | 2019-11-13 | 2019-11-19 | 120, 121 |

Removed: 34 Review and assign early input for inclusion in SSAD and other worksheets

Changed:

| ID | Task | Start | Finish | Duration | Complete | Total float | Predecessors |
| --- | --- | --- | --- | --- | --- | --- | --- |
| 1 | **EPDP - Phase 2 Policy Development** |  |  |  | 19% → 23% |  |  |
| 2 | **PROJECT MANAGEMENT** |  |  |  | 53% → 56% |  |  |
| 9 | **Project Management** |  |  |  | 50% → 53% |  |  |
| 13 | Obtain project plan approval from GNSO Council | 2019-08-22 A | 2019-08-22 A |  | 0% → 100% | 19d → none |  |
| 14 | **Leadership Sub team** |  |  |  | 25% → 33% |  |  |
| 15 | On-going preparation and planning of EPDP-P2 activities |  |  |  | 25% → 33% |  |  |
| 16 | **Project Cost Support Team Sub team** |  |  |  | 37% → 39% |  |  |
| 20 | Request and acquire final dedicated funds for additional project resources |  |  |  | 30% → 75% |  |  |
| 23 | **EPDP DELIBERATIONS** |  |  |  | 13% → 18% |  |  |
| 29 | **Input from other SO/ACs & GNSO SG/Cs** |  | 2019-09-03 → 2019-11-22 (+80d) | 74d → 134d | 51% → 44% | 287d → 227d |  |
| 33 | Group to review input and determine relevance to policy deliberations on issues within scope |  | 2019-08-06 → 2019-11-22 (+108d) | 20d → 100d | 20% → 25% | 287d → 227d |  |
| 34 | **Priority 1 Deliberations** |  |  |  | 8% → 18% |  |  |
| 35 | **Requirements, incl. defining user groups, use cases and other criteria to determine similarities and differences** |  |  |  | 36% → 90% |  |  |
| 38 | **Generate potential Use Cases (refer to 20+ on wiki)** |  |  |  | 31% → 89% |  |  |
| 39 | Confirm Use Case order and groups to consolidate |  | 2019-09-05 A |  | 90% → 100% | 0d → none |  |
| 40 | Understand Purposes and Legitimate Interest for third party disclosure |  | 2019-07-02 A |  | 75% → 100% | 47.5d → none |  |
| 41 | First reading + response |  |  |  | 20% → 85% |  |  |
| 42 | Deliberate other policy topics as necessary to better inform dedicated time to that topic |  |  |  | 20% → 85% |  |  |
| 43 | Develop subsequent draft + response |  |  |  | 10% → 85% |  |  |
| 44 | Second reading + adoption or discard | 2019-06-28 A |  |  | 0% → 85% |  |  |
| 47 | Review inputs from Requirements and Use Cases |  |  |  | 45% → 70% |  |  |
| 123 | Priority 1 Day Zero documents for LA1 F2F2 | 2019-09-05 A | 2019-09-05 A |  | 0% → 100% | 285d → none |  |
| 124 | Priority 1 Day Zero documents for ICANN66 Montreal |  |  |  |  |  | 62, 69, 76, 83, 90, 97, 105, 112 → 62, 69, 76, 83, 90, 97, 105, 112, 119 |
| 126 | Organize Priority 2 topics | 2019-05-31 A | 2019-05-31 A |  | 0% → 100% | 354d → none |  |
| 214 | **Legal Sub team** |  |  |  | 46% → 55% |  |  |
| 217 | On-going review of legal questions / advice and interaction with counsel for Initial Report |  |  |  | 10% → 25% |  |  |
| 218 | **Key Events** |  |  |  | 22% → 28% |  |  |
| 219 | **EPDP Team F2F Meeting - Marrakech (24-27 Jun 2019)** |  | 2019-09-04 A |  | 91% → 100% | 286d → none |  |
| 232 | Manage financial invoice, payment confirmation, and tracking (report to PCST) |  | 2019-09-04 A |  | 75% → 100% | 286d → none |  |
| 233 | Close F2F | 2019-09-04 A | 2019-09-04 A |  | 0% → 100% | 286d → none |  |
| 234 | **EPDP Team F2F Meeting - Los Angeles (08-11 Sept 2019)** |  |  |  | 36% → 47% |  |  |
| 237 | Interact with Meetings Team |  |  |  | 35% → 50% |  |  |
| 239 | Engage EPDP team to confirm RSVPs and manage applications for travel support |  | 2019-08-22 A |  | 35% → 100% | 295d → none |  |
| 240 | Engage hotel and facilities support teams |  |  |  | 75% → 60% |  |  |
| 241 | Research and schedule events as necessary |  |  |  | 50% → 80% |  |  |
| 242 | Engage facilitators |  |  |  | 35% → 60% |  |  |
| 243 | Plan agenda |  |  |  | 10% → 15% |  |  |
| 244 | Confirm Day 0 work products (see tasks above) | 2019-09-05 A | 2019-09-05 A |  | 0% → 100% | 285d → none |  |
| 253 | **EPDP Team F2F Meeting - Montreal (02-07 Nov 2019)** | 2019-08-23 A |  |  | 0% → 14% | 91d → 189d |  |
| 254 | Determine requirements and scope | 2019-08-23 A | 2019-08-23 A |  | 0% → 100% | 91d → none |  |
| 255 | Obtain PCST approval | 2019-08-26 A | 2019-08-30 A |  | 0% → 100% | 91d → none |  |
| 256 | Interact with Meetings Team | 2019-09-02 A |  |  | 0% → 10% |  |  |
| 257 | Engage EPDP team to confirm RSVPs and manage applications for travel support | 2019-09-02 A |  |  | 0% → 75% |  |  |
| 258 | Engage facilitators | 2019-08-30 A |  |  | 0% → 10% |  |  |
| 302 | **INITIAL REPORT** |  |  |  | 24% → 32% |  |  |
| 303 | Assemble initial conclusions |  |  |  | 35% → 50% |  |  |
| 304 | Populate discussion papers with findings and potential recommendations |  |  |  | 35% → 45% |  |  |

## Version 3 (saved 2019-09-30, file EPDP-P2_Project_Plan_20190930.mpp)

Last finish stays 2020-10-06. Complete tasks 59 → 91.

Changed:

| ID | Task | Start | Finish | Complete | Total float |
| --- | --- | --- | --- | --- | --- |
| 1 | **EPDP - Phase 2 Policy Development** |  |  | 23% → 31% |  |
| 2 | **PROJECT MANAGEMENT** |  |  | 56% → 64% |  |
| 9 | **Project Management** |  |  | 53% → 61% |  |
| 14 | **Leadership Sub team** |  |  | 33% → 43% |  |
| 15 | On-going preparation and planning of EPDP-P2 activities |  |  | 33% → 43% |  |
| 16 | **Project Cost Support Team Sub team** |  |  | 39% → 52% | 57d → 37d |
| 20 | Request and acquire final dedicated funds for additional project resources |  | 2019-10-08 A | 75% → 100% | 262d → none |
| 21 | On-going financial and resource approvals of EPDP-P2 activities |  |  | 25% → 40% |  |
| 23 | **EPDP DELIBERATIONS** |  |  | 18% → 26% |  |
| 34 | **Priority 1 Deliberations** |  |  | 18% → 39% |  |
| 35 | **Requirements, incl. defining user groups, use cases and other criteria to determine similarities and differences** |  | 2019-09-05 A | 90% → 100% | 0d → none |
| 38 | **Generate potential Use Cases (refer to 20+ on wiki)** |  | 2019-09-05 A | 89% → 100% | 0d → none |
| 41 | First reading + response |  | 2019-09-05 A | 85% → 100% | 0d → none |
| 42 | Deliberate other policy topics as necessary to better inform dedicated time to that topic |  | 2019-08-08 A | 85% → 100% | 20d → none |
| 43 | Develop subsequent draft + response |  | 2019-09-05 A | 85% → 100% | 0d → none |
| 44 | Second reading + adoption or discard |  | 2019-09-05 A | 85% → 100% | 0d → none |
| 45 | **SSAD Model & Worksheets & Preliminary Recommendations** |  |  | 1% → 25% |  |
| 46 | **Safeguards** |  |  | 2% → 8% |  |
| 47 | Review inputs from Requirements and Use Cases |  | 2019-09-12 A | 70% → 100% | 1.25d → none |
| 48 | **Understand sub-topics and determine need to deliberate** | 2019-09-12 A |  | 0% → 8% |  |
| 49 | Query volume limitations | 2019-09-12 A |  | 0% → 10% |  |
| 50 | Code of conduct | 2019-09-12 A |  | 0% → 10% |  |
| 51 | Terms of use / disclosure agreements | 2019-09-12 A |  | 0% → 10% |  |
| 52 | Privacy policies | 2019-09-12 A |  | 0% → 10% |  |
| 53 | Retention and destruction of data | 2019-09-12 A |  | 0% → 10% |  |
| 56 | Disclosure of the Data | 2019-09-12 A |  | 0% → 10% |  |
| 57 | Monitoring | 2019-09-12 A |  | 0% → 10% |  |
| 58 | Audit trail | 2019-09-12 A |  | 0% → 10% |  |
| 59 | Retention | 2019-09-12 A |  | 0% → 10% |  |
| 60 | Destruction of data | 2019-09-12 A |  | 0% → 10% |  |
| 66 | **Accreditation and Authentication (Credentialing)** |  |  | 1% → 27% |  |
| 67 | Understand topic and determine need to deliberate |  | 2019-09-12 A | 25% → 100% | 280d → none |
| 68 | Deliberate policy considerations and determine approach | 2019-09-06 A | 2019-09-12 A | 0% → 100% | 0d → none |
| 69 | Deliberate policy issues | 2019-09-13 A |  | 0% → 25% |  |
| 70 | Develop draft work product | 2019-09-13 A |  | 0% → 10% |  |
| 71 | Conduct First Reading + verbal and email response | 2019-09-13 A |  | 0% → 50% |  |
| 73 | **Lawful Basis & Balancing Test** |  |  | 1% → 27% |  |
| 74 | Understand topic and determine need to deliberate |  | 2019-09-12 A | 25% → 100% | 280d → none |
| 75 | Deliberate policy considerations and determine approach | 2019-09-06 A | 2019-09-12 A | 0% → 100% | 0d → none |
| 76 | Deliberate policy issues | 2019-09-13 A |  | 0% → 25% |  |
| 77 | Develop draft work product | 2019-09-13 A |  | 0% → 10% |  |
| 78 | Conduct First Reading + verbal and email response | 2019-09-13 A |  | 0% → 50% |  |
| 80 | **Determine Process publication, format and content request requirements** | 2019-09-06 A |  | 0% → 23% | 0d → 230d |
| 81 | Understand topic and determine need to deliberate | 2019-09-06 A | 2019-09-12 A | 0% → 100% | 280d → none |
| 82 | Deliberate policy considerations and determine approach | 2019-09-06 A | 2019-09-12 A | 0% → 100% | 0d → none |
| 83 | Deliberate policy issues | 2019-09-13 A |  | 0% → 25% |  |
| 85 | Conduct First Reading + verbal and email response | 2019-09-13 A |  | 0% → 50% |  |
| 87 | **Timeline of process** | 2019-09-06 A |  | 0% → 23% | 0d → 230d |
| 88 | Understand topic and determine need to deliberate | 2019-09-06 A | 2019-09-12 A | 0% → 100% | 280d → none |
| 89 | Deliberate policy considerations and determine approach | 2019-09-06 A | 2019-09-12 A | 0% → 100% | 0d → none |
| 90 | Deliberate policy issues | 2019-09-13 A |  | 0% → 25% |  |
| 92 | Conduct First Reading + verbal and email response | 2019-09-13 A |  | 0% → 50% |  |
| 94 | **Automation Analysis + Centralized vs. De-Centralized Models** | 2019-09-06 A |  | 0% → 32% | 0d → 230d |
| 95 | Understand topic and determine need to deliberate | 2019-09-06 A | 2019-09-12 A | 0% → 100% | 280d → none |
| 96 | Deliberate policy considerations and determine approach | 2019-09-06 A | 2019-09-12 A | 0% → 100% | 0d → none |
| 97 | Deliberate policy issues | 2019-09-13 A |  | 0% → 50% |  |
| 98 | Determine if automation is consistent with legal requirements/legal basis | 2019-09-13 A |  | 0% → 25% |  |
| 99 | Develop draft work product | 2019-09-13 A |  | 0% → 10% |  |
| 100 | Conduct First Reading + verbal and email response | 2019-09-13 A |  | 0% → 50% |  |
| 102 | **Review possible comprehensive model and options** | 2019-09-06 A |  | 0% → 35% | 0d → 230d |
| 103 | Understand topic and determine need to deliberate | 2019-09-06 A | 2019-09-12 A | 0% → 100% | 280d → none |
| 104 | Deliberate policy considerations and determine approach | 2019-09-06 A | 2019-09-12 A | 0% → 100% | 0d → none |
| 105 | Deliberate policy issues | 2019-09-13 A |  | 0% → 50% |  |
| 106 | Develop draft work product | 2019-09-13 A |  | 0% → 10% |  |
| 107 | Conduct First Reading + verbal and email response | 2019-09-13 A |  | 0% → 50% |  |
| 109 | **Financial sustainability** | 2019-09-06 A |  | 0% → 35% | 0d → 230d |
| 110 | Understand topic and determine need to deliberate | 2019-09-06 A | 2019-09-12 A | 0% → 100% | 280d → none |
| 111 | Deliberate policy considerations and determine approach | 2019-09-06 A | 2019-09-12 A | 0% → 100% | 0d → none |
| 112 | Deliberate policy issues | 2019-09-13 A |  | 0% → 50% |  |
| 113 | Develop draft work product | 2019-09-13 A |  | 0% → 10% |  |

| ID | Task | Start | Finish | Duration | Complete | Total float | Other |
| --- | --- | --- | --- | --- | --- | --- | --- |
| 114 | Conduct First Reading + verbal and email response | 2019-09-13 A |  |  | 0% → 50% |  |  |
| 116 | **Purpose 2 Rework per Phase 1 and Board Instruction to GNSO Council** | 2019-09-06 A |  |  | 0% → 23% | 0d → 230d |  |
| 117 | Understand topic and determine need to deliberate | 2019-09-06 A | 2019-09-12 A |  | 0% → 100% | 280d → none |  |
| 118 | Deliberate policy considerations and determine approach | 2019-09-06 A | 2019-09-12 A |  | 0% → 100% | 0d → none |  |
| 119 | Deliberate policy issues | 2019-09-13 A |  |  | 0% → 25% |  |  |
| 121 | Conduct First Reading + verbal and email response | 2019-09-13 A |  |  | 0% → 50% |  |  |
| 123 | Priority 1 draft zero documents for LA1 F2F2 |  |  |  |  |  | was named Priority 1 Day Zero documents for LA1 F2F2 |
| 124 | Priority 1 draft 1.0 documents for ICANN66 Montreal |  |  |  |  |  | was named Priority 1 Day Zero documents for ICANN66 Montreal |
| 125 | **Priority 2 Deliberations (Issues carried from Phase 1)** |  | 2020-04-09 → 2020-04-23 (+14d) | 227d → 237d |  | 128d → 118d |  |
| 127 | **Display of information of affiliated vs. accredited privacy / proxy providers** |  | 2020-03-04 → 2020-04-15 (+42d) | 200d → 230d |  | 154d → 124d |  |
| 129 | **Understand topic and determine need to deliberate** |  | 2019-09-27 → 2019-11-06 (+40d) | 80d → 110d |  | 154d → 124d |  |
| 130 | PPSAI IRT briefing to determine how their work compliments or depends on EPDP |  | 2019-09-27 → 2019-11-06 (+40d) | 80d → 110d |  | 154d → 124d |  |
| 131 | Determine if briefing regarding a data privacy impact assessment on the PPSAI program is required |  | 2019-09-27 → 2019-11-06 (+40d) | 80d → 110d |  | 154d → 124d |  |
| 132 | Determine if answers to legal questions are required |  | 2019-09-27 → 2019-11-06 (+40d) | 80d → 110d |  | 154d → 124d |  |
| 133 | Deliberate policy considerations and determine approach | 2019-09-30 → 2019-11-07 (+38d) | 2019-10-04 → 2019-11-13 (+40d) |  |  | 154d → 124d |  |
| 134 | Deliberate policy issues | 2019-10-07 → 2019-11-14 (+38d) | 2020-02-05 → 2020-03-18 (+42d) |  |  | 154d → 124d |  |
| 135 | Develop draft work product | 2020-02-06 → 2020-03-19 (+42d) | 2020-02-19 → 2020-04-01 (+42d) |  |  | 154d → 124d |  |
| 136 | Conduct First Reading + verbal and email response | 2020-02-20 → 2020-04-02 (+42d) | 2020-02-26 → 2020-04-08 (+42d) |  |  | 154d → 124d |  |
| 137 | Conduct Second Reading + verbal response + adoption or discard | 2020-02-27 → 2020-04-09 (+42d) | 2020-03-04 → 2020-04-15 (+42d) |  |  | 154d → 124d |  |
| 138 | **Legal vs. Natural** |  | 2020-03-04 → 2020-04-15 (+42d) | 200d → 230d |  | 154d → 124d |  |
| 140 | **Understand topic and determine need to deliberate** |  | 2019-09-27 → 2019-11-06 (+40d) | 80d → 110d |  | 154d → 124d |  |
| 141 | Receive briefing from Bird & Bird on legal vs. natural memo |  | 2019-09-27 → 2019-11-06 (+40d) | 80d → 110d |  | 154d → 124d |  |
| 142 | Determine if answers to legal questions are required |  | 2019-09-27 → 2019-11-06 (+40d) | 80d → 110d |  | 154d → 124d |  |
| 143 | EPDP Team to confirm with ICANN Org expected next steps and timing to conduct and publish the study results. |  | 2019-09-27 → 2019-11-06 (+40d) | 80d → 110d |  | 154d → 124d |  |
| 144 | EPDP Team or Sub-team to work with ICANN org on this study, including providing questions and/or relevant background to assist in informing the study by 1 July 2019. |  | 2019-09-27 → 2019-11-06 (+40d) | 80d → 110d |  | 154d → 124d |  |
| 145 | Deliberate policy considerations and determine approach | 2019-09-30 → 2019-11-07 (+38d) | 2019-10-04 → 2019-11-13 (+40d) |  |  | 154d → 124d |  |
| 146 | Deliberate policy issues | 2019-10-07 → 2019-11-14 (+38d) | 2020-02-05 → 2020-03-18 (+42d) |  |  | 154d → 124d |  |
| 147 | Develop draft work product | 2020-02-06 → 2020-03-19 (+42d) | 2020-02-19 → 2020-04-01 (+42d) |  |  | 154d → 124d |  |
| 148 | Conduct First Reading + verbal and email response | 2020-02-20 → 2020-04-02 (+42d) | 2020-02-26 → 2020-04-08 (+42d) |  |  | 154d → 124d |  |
| 149 | Conduct Second Reading + verbal response + adoption or discard | 2020-02-27 → 2020-04-09 (+42d) | 2020-03-04 → 2020-04-15 (+42d) |  |  | 154d → 124d |  |
| 150 | **City Field** |  | 2020-03-12 → 2020-04-23 (+42d) | 200d → 230d |  | 148d → 118d |  |
| 152 | **Understand topic and determine need to deliberate** |  | 2019-10-07 → 2019-11-14 (+38d) | 80d → 110d |  | 148d → 118d |  |
| 153 | Receive briefing from Bird & Bird on city field memo |  | 2019-10-07 → 2019-11-14 (+38d) | 80d → 110d |  | 148d → 118d |  |
| 155 | Deliberate policy considerations and determine approach | 2019-10-08 → 2019-11-15 (+38d) | 2019-10-14 → 2019-11-21 (+38d) |  |  | 148d → 118d |  |
| 156 | Deliberate policy issues | 2019-10-15 → 2019-11-22 (+38d) | 2020-02-13 → 2020-03-26 (+42d) |  |  | 148d → 118d |  |
| 157 | Develop draft work product | 2020-02-14 → 2020-03-27 (+42d) | 2020-02-27 → 2020-04-09 (+42d) |  |  | 148d → 118d |  |
| 158 | Conduct First Reading + verbal and email response | 2020-02-28 → 2020-04-10 (+42d) | 2020-03-05 → 2020-04-16 (+42d) |  |  | 148d → 118d |  |
| 159 | Conduct Second Reading + verbal response + adoption or discard | 2020-03-06 → 2020-04-17 (+42d) | 2020-03-12 → 2020-04-23 (+42d) |  |  | 148d → 118d |  |
| 160 | **Data Retention** |  | 2020-03-12 → 2020-04-23 (+42d) | 200d → 230d | 3% → 2% | 148d → 118d |  |
| 162 | **Understand topic and determine need to deliberate** |  | 2019-10-07 → 2019-11-14 (+38d) | 80d → 110d |  | 148d → 118d |  |
| 163 | Confirm with ICANN org when the review of all of ICANN org's processes and procedures to identify and document the instances in which personal data is requested beyond the life of domain name registration is expected to be completed. |  | 2019-10-07 → 2019-11-14 (+38d) | 80d → 110d |  | 148d → 118d |  |
| 164 | Deliberate policy considerations and determine approach | 2019-10-08 → 2019-11-15 (+38d) | 2019-10-14 → 2019-11-21 (+38d) |  |  | 148d → 118d |  |
| 165 | **Deliberate policy issues** | 2019-10-15 → 2019-11-22 (+38d) | 2020-02-13 → 2020-03-26 (+42d) |  |  | 148d → 118d |  |
| 166 | Confirm whether the data retention requirements recommended in phase 1 are to be confirmed or whether updates are needed | 2019-10-15 → 2019-11-22 (+38d) | 2020-02-13 → 2020-03-26 (+42d) |  |  | 148d → 118d |  |
| 167 | Develop draft work product | 2020-02-14 → 2020-03-27 (+42d) | 2020-02-27 → 2020-04-09 (+42d) |  |  | 148d → 118d |  |
| 168 | Conduct First Reading + verbal and email response | 2020-02-28 → 2020-04-10 (+42d) | 2020-03-05 → 2020-04-16 (+42d) |  |  | 148d → 118d |  |
| 169 | Conduct Second Reading + verbal response + adoption or discard | 2020-03-06 → 2020-04-17 (+42d) | 2020-03-12 → 2020-04-23 (+42d) |  |  | 148d → 118d |  |
| 170 | **Additional purpose for ICANN’s OCTO** |  | 2020-03-18 → 2020-04-15 (+28d) | 200d → 220d |  | 144d → 124d |  |
| 172 | **Understand topic and determine need to deliberate** |  | 2019-10-11 → 2019-11-06 (+26d) | 80d → 100d |  | 144d → 124d |  |
| 173 | Further to EPDP-P1 Rec#2, EPDP Team to draft question to ICANN org, to inform next steps. |  | 2019-10-11 → 2019-11-06 (+26d) | 80d → 100d |  | 144d → 124d |  |
| 174 | Determine if answers to legal questions are required |  | 2019-10-11 → 2019-11-06 (+26d) | 80d → 100d |  | 144d → 124d |  |
| 175 | Deliberate policy considerations and determine approach | 2019-10-14 → 2019-11-07 (+24d) | 2019-10-18 → 2019-11-13 (+26d) |  |  | 144d → 124d |  |
| 176 | Deliberate policy issues | 2019-10-21 → 2019-11-14 (+24d) | 2020-02-19 → 2020-03-18 (+28d) |  |  | 144d → 124d |  |
| 177 | Develop draft work product | 2020-02-20 → 2020-03-19 (+28d) | 2020-03-04 → 2020-04-01 (+28d) |  |  | 144d → 124d |  |
| 178 | Conduct First Reading + verbal and email response | 2020-03-05 → 2020-04-02 (+28d) | 2020-03-11 → 2020-04-08 (+28d) |  |  | 144d → 124d |  |
| 179 | Conduct Second Reading + verbal response + adoption or discard | 2020-03-12 → 2020-04-09 (+28d) | 2020-03-18 → 2020-04-15 (+28d) |  |  | 144d → 124d |  |
| 180 | **Feasibility of unique contacts to have uniform anonymized email address** |  | 2020-03-18 → 2020-04-01 (+14d) | 200d → 210d | 3% → 2% | 144d → 134d |  |
| 182 | **Understand topic and determine need to deliberate** |  | 2019-10-11 → 2019-10-25 (+14d) | 80d → 90d |  | 144d → 134d |  |
| 183 | Determine if answers to legal questions are required |  | 2019-10-11 → 2019-10-25 (+14d) | 80d → 90d |  | 144d → 134d |  |
| 184 | Deliberate policy considerations and determine approach | 2019-10-14 → 2019-10-28 (+14d) | 2019-10-18 → 2019-11-01 (+14d) |  |  | 144d → 134d |  |
| 185 | Deliberate policy issues | 2019-10-21 → 2019-11-02 (+12d) | 2020-02-19 → 2020-03-04 (+14d) |  |  | 144d → 134d |  |
| 186 | Develop draft work product | 2020-02-20 → 2020-03-05 (+14d) | 2020-03-04 → 2020-03-18 (+14d) |  |  | 144d → 134d |  |
| 187 | Conduct First Reading + verbal and email response | 2020-03-05 → 2020-03-19 (+14d) | 2020-03-11 → 2020-03-25 (+14d) |  |  | 144d → 134d |  |
| 188 | Conduct Second Reading + verbal response + adoption or discard | 2020-03-12 → 2020-03-26 (+14d) | 2020-03-18 → 2020-04-01 (+14d) |  |  | 144d → 134d |  |
| 189 | **Data Accuracy and the WHOIS Accuracy Reporting System** |  | 2020-04-09 → 2020-04-23 (+14d) | 200d → 210d |  | 128d → 118d |  |
| 191 | **Understand topic and determine need to deliberate** |  | 2019-11-02 → 2019-11-14 (+12d) | 80d → 90d |  | 128d → 118d |  |
| 192 | Receive briefing from Bird & Bird on city field memo |  | 2019-11-02 → 2019-11-14 (+12d) | 80d → 90d |  | 128d → 118d |  |
| 193 | Determine if answers to legal questions are required |  | 2019-11-02 → 2019-11-14 (+12d) | 80d → 90d |  | 128d → 118d |  |
| 194 | Deliberate policy considerations and determine approach | 2019-11-03 → 2019-11-15 (+12d) | 2019-11-07 → 2019-11-21 (+14d) |  |  | 128d → 118d |  |
| 195 | Deliberate policy issues | 2019-11-08 → 2019-11-22 (+14d) | 2020-03-12 → 2020-03-26 (+14d) |  |  | 128d → 118d |  |

| ID | Task | Start | Finish | Complete | Total float | Other |
| --- | --- | --- | --- | --- | --- | --- |
| 196 | Develop draft work product | 2020-03-13 → 2020-03-27 (+14d) | 2020-03-26 → 2020-04-09 (+14d) |  | 128d → 118d |  |
| 197 | Conduct First Reading + verbal and email response | 2020-03-27 → 2020-04-10 (+14d) | 2020-04-02 → 2020-04-16 (+14d) |  | 128d → 118d |  |
| 198 | Conduct Second Reading + verbal response + adoption or discard | 2020-04-03 → 2020-04-17 (+14d) | 2020-04-09 → 2020-04-23 (+14d) |  | 128d → 118d |  |
| 214 | **Legal Sub team** |  |  | 55% → 70% |  |  |
| 217 | On-going review of legal questions / advice and interaction with counsel for Initial Report |  |  | 25% → 50% |  |  |
| 218 | **Key Events** |  |  | 28% → 42% |  |  |
| 234 | **EPDP Team F2F Meeting - Los Angeles (08-11 Sept 2019)** |  |  | 47% → 86% |  |  |
| 237 | Interact with Meetings Team |  |  | 50% → 75% |  |  |
| 240 | Engage hotel and facilities support teams |  |  | 60% → 85% |  |  |
| 241 | Research and schedule events as necessary |  | 2019-09-12 A | 80% → 100% | 280d → none |  |
| 242 | Engage facilitators |  | 2019-09-19 A | 60% → 100% | 275d → none |  |
| 243 | Plan agenda |  | 2019-09-11 A | 15% → 100% | 267d → none |  |
| 244 | Confirm draft zero work products (see tasks above) |  |  |  |  | was named Confirm Day 0 work products (see tasks above) |
| 245 | Day 0 preparations | 2019-09-08 A | 2019-09-08 A | 0% → 100% |  |  |
| 246 | Day 1 sessions | 2019-09-09 A | 2019-09-09 A | 0% → 100% | 271d → none |  |
| 247 | Day 2 sessions | 2019-09-10 A | 2019-09-10 A | 0% → 100% | 271d → none |  |
| 248 | Day 3 sessions | 2019-09-11 A | 2019-09-11 A | 0% → 100% | 271d → none |  |
| 249 | F2F Recon and Sitrep | 2019-09-11 A | 2019-09-11 A | 0% → 100% | 271d → none |  |
| 250 | Communicate outcomes | 2019-09-12 A | 2019-09-25 A | 0% → 100% | 271d → none |  |
| 251 | Manage financial invoice, payment confirmation, and tracking (report to PCST) | 2019-06-28 A |  | 0% → 60% |  |  |
| 253 | **EPDP Team F2F Meeting - Montreal (02-07 Nov 2019)** |  |  | 14% → 23% |  |  |
| 256 | Interact with Meetings Team |  |  | 10% → 15% |  |  |
| 259 | Plan agenda | 2019-09-02 A |  | 0% → 50% |  |  |
| 260 | Confirm 1.0 draft work products (see tasks above) |  |  |  |  | was named Confirm Day 0 work products (see tasks above) |
| 268 | **EPDP Team F2F Meeting - TBD [Los Angeles] (End of Jan 2020)** |  |  | 1% → 7% |  |  |
| 271 | Interact with Meetings Team | 2019-10-01 A |  | 0% → 5% |  |  |
| 272 | Evaluate locations and reserve hotel and facilities | 2019-10-01 A | 2019-11-07 A | 0% → 100% | 148d → none |  |
| 273 | Engage EPDP team to confirm RSVPs and manage applications for travel support | 2019-11-08 A |  | 0% → 10% |  |  |
| 302 | **INITIAL REPORT** |  |  | 32% → 51% |  |  |
| 303 | Assemble initial conclusions |  |  | 50% → 75% |  |  |
| 304 | Populate discussion papers with findings and potential recommendations |  |  | 45% → 75% |  |  |

## Version 4 (saved 2019-10-30, file EPDP-P2_Project_Plan_20191031.mpp)

Last finish stays 2020-10-06. Complete tasks 91 → 97.

Changed:

| ID | Task | Start | Finish | Complete | Total float | Other |
| --- | --- | --- | --- | --- | --- | --- |
| 1 | **EPDP - Phase 2 Policy Development** |  |  | 31% → 35% |  |  |
| 2 | **PROJECT MANAGEMENT** |  |  | 64% → 67% |  |  |
| 9 | **Project Management** |  |  | 61% → 65% |  |  |
| 14 | **Leadership Sub team** |  |  | 43% → 50% |  |  |
| 15 | On-going preparation and planning of EPDP-P2 activities |  |  | 43% → 50% |  |  |
| 16 | **Project Cost Support Team Sub team** |  |  | 52% → 55% |  |  |
| 21 | On-going financial and resource approvals of EPDP-P2 activities |  |  | 40% → 44% |  |  |
| 23 | **EPDP DELIBERATIONS** |  |  | 26% → 30% |  |  |
| 34 | **Priority 1 Deliberations** |  |  | 39% → 49% |  |  |
| 45 | **SSAD Model & Worksheets & Preliminary Recommendations** |  |  | 25% → 37% |  |  |
| 46 | **Safeguards** |  |  | 8% → 23% |  |  |
| 61 | Deliberate policy considerations and determine approach |  | 2019-10-03 A | 25% → 100% | 0.5d → none |  |
| 62 | Deliberate policy issues | 2019-10-03 A |  | 0% → 60% | 0.5d → 245.5d |  |
| 63 | Develop draft work product | 2019-10-03 A |  | 0% → 20% |  |  |
| 64 | Conduct First Reading + verbal and email response | 2019-10-03 A |  | 0% → 60% |  |  |
| 66 | **Accreditation and Authentication (Credentialing)** |  |  | 27% → 44% |  |  |
| 69 | Deliberate policy issues |  |  | 25% → 60% | 0d → 245d |  |
| 70 | Develop draft work product |  |  | 10% → 20% |  |  |
| 71 | Conduct First Reading + verbal and email response |  |  | 50% → 60% |  |  |
| 73 | **Lawful Basis & Balancing Test** |  |  | 27% → 44% |  |  |
| 76 | Deliberate policy issues |  |  | 25% → 60% | 0d → 245d |  |
| 77 | Develop draft work product |  |  | 10% → 20% |  |  |
| 78 | Conduct First Reading + verbal and email response |  |  | 50% → 60% |  |  |
| 80 | **Determine Process publication, format and content request requirements** |  |  | 23% → 44% |  |  |
| 83 | Deliberate policy issues |  |  | 25% → 60% | 0d → 245d |  |
| 84 | Develop draft work product | 2019-09-13 A |  | 0% → 20% |  |  |
| 85 | Conduct First Reading + verbal and email response |  |  | 50% → 60% |  |  |
| 87 | **Timeline of process** |  |  | 23% → 44% |  |  |
| 90 | Deliberate policy issues |  |  | 25% → 60% | 0d → 245d |  |
| 91 | Develop draft work product | 2019-09-13 A |  | 0% → 20% |  |  |
| 92 | Conduct First Reading + verbal and email response |  |  | 50% → 60% |  |  |
| 94 | **Automation Analysis + Centralized vs. De-Centralized Models** |  |  | 32% → 40% |  |  |
| 97 | Deliberate policy issues |  |  | 50% → 60% | 0d → 245d |  |
| 98 | Determine if automation is consistent with legal requirements/legal basis |  |  | 25% → 30% |  |  |
| 99 | Develop draft work product |  |  | 10% → 20% |  |  |
| 100 | Conduct First Reading + verbal and email response |  |  | 50% → 60% |  |  |
| 102 | **Review possible comprehensive model and options** |  |  | 35% → 44% |  |  |
| 105 | Deliberate policy issues |  |  | 50% → 60% | 0d → 245d |  |
| 106 | Develop draft work product |  |  | 10% → 20% |  |  |
| 107 | Conduct First Reading + verbal and email response |  |  | 50% → 60% |  |  |
| 109 | **Financial sustainability** |  |  | 35% → 44% |  |  |
| 112 | Deliberate policy issues |  |  | 50% → 60% | 0d → 245d |  |
| 113 | Develop draft work product |  |  | 10% → 20% |  |  |
| 114 | Conduct First Reading + verbal and email response |  |  | 50% → 60% |  |  |
| 124 | Priority 1 draft 1.0 documents for ICANN66 Montreal | 2019-10-31 A | 2019-10-31 A | 0% → 100% | 0d → none |  |
| 200 | **Phase 2 - Legal/Natural Study** |  |  |  |  | was named Phase 2 discussion on Geographic Basis |
| 207 | **Phase 2 - Placeholder** |  |  |  |  | was named Phase 2 discussion on Thick Whois coming from IRT>Board>Council>EPDP2>Council>Board |
| 214 | **Legal Sub team** |  |  | 70% → 85% |  |  |
| 217 | On-going review of legal questions / advice and interaction with counsel for Initial Report |  |  | 50% → 75% |  |  |
| 218 | **Key Events** |  |  | 42% → 47% |  |  |
| 234 | **EPDP Team F2F Meeting - Los Angeles (08-11 Sept 2019)** |  |  | 86% → 89% |  |  |
| 251 | Manage financial invoice, payment confirmation, and tracking (report to PCST) |  |  | 60% → 75% |  |  |
| 253 | **EPDP Team F2F Meeting - Montreal (02-07 Nov 2019)** |  |  | 23% → 39% |  |  |
| 256 | Interact with Meetings Team |  |  | 15% → 50% |  |  |
| 257 | Engage EPDP team to confirm RSVPs and manage applications for travel support |  | 2019-10-11 A | 75% → 100% | 259d → none |  |
| 258 | Engage facilitators |  | 2019-08-30 A | 10% → 100% | 289d → none |  |
| 259 | Plan agenda |  |  | 50% → 75% |  |  |
| 260 | Confirm 1.0 draft work products (see tasks above) | 2019-10-31 A |  | 0% → 20% |  |  |
| 268 | **EPDP Team F2F Meeting - Los Angeles (27-30 Jan 2020)** |  |  | 7% → 13% |  | was named EPDP Team F2F Meeting - TBD [Los Angeles] (End of Jan 2020) |
| 271 | Interact with Meetings Team |  |  | 5% → 20% |  |  |
| 273 | Engage EPDP team to confirm RSVPs and manage applications for travel support |  |  | 10% → 75% |  |  |
| 302 | **INITIAL REPORT** |  |  | 51% → 68% | 185d → 105d |  |
| 303 | Assemble initial conclusions |  | 2019-10-31 A | 75% → 100% | 245d → none |  |
| 304 | Populate discussion papers with findings and potential recommendations |  | 2019-10-31 A | 75% → 100% | 0d → none |  |

## Version 5 (saved 2019-12-05, file EPDP-P2_Project_Plan_20191130.mpp)

Last finish stays 2020-10-06. Complete tasks 97 → 137.

Added:

| ID | Task | Duration | Start | Finish |
| --- | --- | --- | --- | --- |
| 207 | **Phase 2 - Placeholder (Strawberry Paper / EDPB Input?)** | 80d | 2019-12-04 | 2020-03-24 |

Removed: 200 Phase 2 - Legal/Natural Study

Changed:

| ID | Task | Start | Finish | Complete | Total float |
| --- | --- | --- | --- | --- | --- |
| 1 | **EPDP - Phase 2 Policy Development** |  |  | 35% → 50% |  |
| 2 | **PROJECT MANAGEMENT** |  |  | 67% → 71% |  |
| 9 | **Project Management** |  |  | 65% → 69% |  |
| 14 | **Leadership Sub team** |  |  | 50% → 60% |  |
| 15 | On-going preparation and planning of EPDP-P2 activities |  |  | 50% → 60% |  |
| 16 | **Project Cost Support Team Sub team** |  |  | 55% → 60% |  |
| 21 | On-going financial and resource approvals of EPDP-P2 activities |  |  | 44% → 50% |  |
| 23 | **EPDP DELIBERATIONS** |  |  | 30% → 49% |  |
| 34 | **Priority 1 Deliberations** |  |  | 49% → 87% |  |
| 45 | **SSAD Model & Worksheets & Preliminary Recommendations** |  |  | 37% → 84% |  |
| 46 | **Safeguards** |  |  | 23% → 80% |  |
| 48 | **Understand sub-topics and determine need to deliberate** |  |  | 8% → 78% |  |
| 49 | Query volume limitations |  | 2019-09-26 A | 10% → 100% |  |
| 50 | Code of conduct |  |  | 10% → 25% |  |
| 51 | Terms of use / disclosure agreements |  | 2019-09-26 A | 10% → 100% |  |
| 53 | Retention and destruction of data |  | 2019-09-26 A | 10% → 100% |  |
| 55 | Transfer of the Data | 2019-09-12 A | 2019-09-26 A | 0% → 100% |  |
| 56 | Disclosure of the Data |  | 2019-09-26 A | 10% → 100% |  |
| 57 | Monitoring |  | 2019-09-26 A | 10% → 100% |  |
| 58 | Audit trail |  | 2019-09-26 A | 10% → 100% |  |
| 59 | Retention |  | 2019-09-26 A | 10% → 100% |  |
| 60 | Destruction of data |  | 2019-09-26 A | 10% → 100% |  |
| 62 | Deliberate policy issues |  |  | 60% → 80% |  |
| 63 | Develop draft work product |  |  | 20% → 80% | 230.5d → 4d |
| 64 | Conduct First Reading + verbal and email response |  |  | 60% → 80% | 250.5d → 24d |
| 65 | Conduct Second Reading + verbal response + adoption or discard | 2019-11-12 A |  | 0% → 80% |  |
| 66 | **Accreditation and Authentication (Credentialing)** |  | 2019-11-19 A | 44% → 100% | 230d → none |
| 69 | Deliberate policy issues |  | 2019-10-31 A | 60% → 100% | 245d → none |
| 70 | Develop draft work product |  | 2019-11-12 A | 20% → 100% | 230d → none |
| 71 | Conduct First Reading + verbal and email response |  | 2019-09-26 A | 60% → 100% | 265d → none |
| 72 | Conduct Second Reading + verbal response + adoption or discard | 2019-11-13 A | 2019-11-19 A | 0% → 100% | 230d → none |
| 73 | **Lawful Basis & Balancing Test** |  |  | 44% → 89% |  |
| 76 | Deliberate policy issues |  |  | 60% → 90% |  |
| 77 | Develop draft work product |  |  | 20% → 90% | 230d → 2.5d |
| 78 | Conduct First Reading + verbal and email response |  |  | 60% → 90% | 265d → 37.5d |
| 79 | Conduct Second Reading + verbal response + adoption or discard | 2019-11-13 A |  | 0% → 50% |  |
| 80 | **Determine Process publication, format and content request requirements** |  | 2019-11-19 A | 44% → 100% | 230d → none |
| 83 | Deliberate policy issues |  | 2019-10-31 A | 60% → 100% | 245d → none |
| 84 | Develop draft work product |  | 2019-11-12 A | 20% → 100% | 230d → none |
| 85 | Conduct First Reading + verbal and email response |  | 2019-09-26 A | 60% → 100% | 265d → none |
| 86 | Conduct Second Reading + verbal response + adoption or discard | 2019-11-13 A | 2019-11-19 A | 0% → 100% | 230d → none |
| 87 | **Timeline of process** |  |  | 44% → 77% |  |
| 90 | Deliberate policy issues |  |  | 60% → 75% |  |
| 91 | Develop draft work product |  |  | 20% → 75% | 230d → 3.75d |
| 92 | Conduct First Reading + verbal and email response |  |  | 60% → 75% | 265d → 38.75d |
| 93 | Conduct Second Reading + verbal response + adoption or discard | 2019-11-13 A |  | 0% → 75% |  |
| 94 | **Automation Analysis + Centralized vs. De-Centralized Models** |  |  | 40% → 85% |  |
| 97 | Deliberate policy issues |  | 2019-10-31 A | 60% → 100% | 245d → none |
| 98 | Determine if automation is consistent with legal requirements/legal basis |  |  | 30% → 50% |  |
| 99 | Develop draft work product |  | 2019-11-12 A | 20% → 100% | 230d → none |
| 100 | Conduct First Reading + verbal and email response |  | 2019-09-26 A | 60% → 100% | 265d → none |
| 101 | Conduct Second Reading + verbal response + adoption or discard | 2019-11-13 A | 2019-11-19 A | 0% → 100% | 230d → none |
| 102 | **Review possible comprehensive model and options** |  | 2019-11-19 A | 44% → 100% | 230d → none |
| 105 | Deliberate policy issues |  | 2019-10-31 A | 60% → 100% | 245d → none |
| 106 | Develop draft work product |  | 2019-11-12 A | 20% → 100% | 230d → none |
| 107 | Conduct First Reading + verbal and email response |  | 2019-09-26 A | 60% → 100% | 265d → none |
| 108 | Conduct Second Reading + verbal response + adoption or discard | 2019-11-13 A | 2019-11-19 A | 0% → 100% | 230d → none |
| 109 | **Financial sustainability** |  |  | 44% → 80% |  |
| 112 | Deliberate policy issues |  |  | 60% → 80% |  |
| 113 | Develop draft work product |  |  | 20% → 80% |  |
| 114 | Conduct First Reading + verbal and email response |  | 2019-09-26 A | 60% → 100% | 265d → none |
| 116 | **Purpose 2 Rework per Phase 1 and Board Instruction to GNSO Council** |  |  | 23% → 52% |  |
| 119 | Deliberate policy issues |  |  | 25% → 50% |  |
| 120 | Develop draft work product | 2019-09-13 A |  | 0% → 50% |  |
| 125 | **Priority 2 Deliberations (Issues carried from Phase 1)** |  |  | 2% → 16% |  |
| 138 | **Legal vs. Natural** |  |  | 1% → 40% |  |
| 140 | **Understand topic and determine need to deliberate** | 2019-06-10 A |  | 0% → 50% |  |
| 142 | Determine if answers to legal questions are required | 2019-06-10 A | 2019-11-06 A | 0% → 100% | 124d → none |
| 143 | EPDP Team to confirm with ICANN Org expected next steps and timing to conduct and publish the study results. | 2019-06-10 A | 2019-11-06 A | 0% → 100% | 124d → none |
| 150 | **City Field** |  |  | 2% → 5% |  |

| ID | Task | Start | Finish | Complete | Total float |
| --- | --- | --- | --- | --- | --- |
| 152 | **Understand topic and determine need to deliberate** | 2019-06-18 A |  | 0% → 6% |  |
| 153 | Receive briefing from Bird & Bird on city field memo | 2019-06-18 A |  | 0% → 10% |  |
| 160 | **Data Retention** |  |  | 2% → 12% |  |
| 162 | **Understand topic and determine need to deliberate** | 2019-06-18 A |  | 0% → 20% |  |
| 163 | Confirm with ICANN org when the review of all of ICANN org's processes and procedures to identify and document the instances in which personal data is requested beyond the life of domain name registration is expected to be completed. | 2019-06-18 A |  | 0% → 20% |  |
| 180 | **Feasibility of unique contacts to have uniform anonymized email address** |  |  | 2% → 35% |  |
| 182 | **Understand topic and determine need to deliberate** | 2019-06-24 A |  | 0% → 75% |  |
| 183 | Determine if answers to legal questions are required | 2019-06-24 A |  | 0% → 75% |  |
| 189 | **Data Accuracy and the WHOIS Accuracy Reporting System** |  |  | 2% → 9% |  |
| 191 | **Understand topic and determine need to deliberate** | 2019-07-16 A |  | 0% → 13% |  |
| 193 | Determine if answers to legal questions are required | 2019-07-16 A |  | 0% → 25% |  |
| 218 | **Key Events** |  |  | 47% → 64% |  |
| 252 | Close F2F | 2019-11-26 A |  | 0% → 75% |  |
| 253 | **EPDP Team F2F Meeting - Montreal (02-07 Nov 2019)** |  |  | 39% → 84% |  |
| 256 | Interact with Meetings Team |  |  | 50% → 90% |  |
| 259 | Plan agenda |  | 2019-10-25 A | 75% → 100% | 91d → none |
| 260 | Confirm 1.0 draft work products (see tasks above) |  | 2019-10-31 A | 20% → 100% | 245d → none |
| 261 | Day 0 preparations | 2019-11-01 A | 2019-11-01 A | 0% → 100% | 87d → none |
| 262 | Day 1 sessions | 2019-11-02 A | 2019-11-02 A | 0% → 100% | 87d → none |
| 263 | Day 2 sessions | 2019-11-03 A | 2019-11-03 A | 0% → 100% | 87d → none |
| 264 | F2F Recon and Sitrep | 2019-11-03 A | 2019-11-03 A | 0% → 100% | 87d → none |
| 265 | Communicate outcomes | 2019-11-04 A | 2019-11-15 A | 0% → 100% | 232d → none |
| 266 | Manage financial invoice, payment confirmation, and tracking (report to PCST) | 2019-09-02 A |  | 0% → 65% |  |
| 268 | **EPDP Team F2F Meeting - Los Angeles (27-30 Jan 2020)** |  |  | 13% → 40% |  |
| 271 | Interact with Meetings Team |  |  | 20% → 25% |  |
| 273 | Engage EPDP team to confirm RSVPs and manage applications for travel support |  | 2019-12-19 A | 75% → 100% | 208d → none |
| 274 | Engage hotel and facilities support teams | 2019-11-08 A |  | 0% → 20% |  |
| 275 | Research and schedule events as necessary | 2019-11-08 A |  | 0% → 20% |  |
| 276 | Engage facilitators | 2019-10-01 A | 2020-01-30 A | 0% → 100% | 178d → none |
| 277 | Plan agenda | 2019-10-01 A |  | 0% → 50% |  |
| 287 | **EPDP Team F2F Meeting - Cancun (07-12 Mar 2020)** | 2019-11-04 A |  | 0% → 17% |  |
| 288 | Determine requirements and scope | 2019-11-04 A | 2019-11-04 A | 0% → 100% | 241d → none |
| 289 | Obtain PCST approval | 2019-11-04 A | 2019-11-08 A | 0% → 100% | 87d → none |
| 290 | Interact with Meetings Team | 2019-11-11 A |  | 0% → 20% |  |
| 291 | Engage EPDP team to confirm RSVPs and manage applications for travel support | 2019-11-11 A |  | 0% → 80% |  |
| 292 | Engage facilitators | 2019-11-08 A | 2019-11-08 A | 0% → 100% | 237d → none |
| 293 | Plan agenda | 2019-11-11 A |  | 0% → 20% |  |
| 302 | **INITIAL REPORT** |  |  | 68% → 75% |  |
| 305 | Discuss/approve findings and interim recommendations | 2019-11-01 A |  | 0% → 30% |  |
| 306 | Consolidate interim recommendations and findings | 2019-11-01 A |  | 0% → 60% |  |
| 307 | Build Draft Report for public comment | 2019-11-01 A |  | 0% → 50% |  |

## Version 6 (saved 2019-12-21, file EPDP-P2_Project_Plan_20191231_baseline.mpp)

Last finish 2020-10-06 → 2020-11-26 (+51d). Complete tasks 137 → 152.

Added:

| ID | Task | Duration | Start | Finish | Constraint |
| --- | --- | --- | --- | --- | --- |
| 123 | **Authorization Provider** | 87.5d | 2019-09-06 A | 2020-01-03 A |  |
| 208 | Develop a cost model on proposed SSAD | 60d | 2019-11-25 A | 2020-02-14 | start no earlier than 2019-11-25 |

Removed: 209 Deliberate policy considerations and determine approach; 210 Deliberate policy issues; 211 Develop draft work product; 212 Conduct First Reading + verbal and email response; 213 Conduct Second Reading + verbal response + adoption or discard

Changed:

| ID | Task | Start | Finish | Duration | Complete | Total float | Other |
| --- | --- | --- | --- | --- | --- | --- | --- |
| 1 | **EPDP - Phase 2 Policy Development** |  | 2020-10-06 → 2020-11-26 (+51d) | 419d → 456d | 50% → 59% |  | baseline start none → 2019-03-04; baseline finish none → 2020-10-06 |
| 2 | **PROJECT MANAGEMENT** |  | 2020-10-06 → 2020-11-26 (+51d) | 419d → 456d | 71% → 72% |  | baseline start none → 2019-03-04; baseline finish none → 2020-10-06 |
| 3 | Project start confirmed |  |  |  |  |  | baseline start none → 2019-03-04; baseline finish none → 2019-03-04 |
| 4 | Adopt/Confirm charter |  |  |  |  |  | baseline start none → 2019-03-05; baseline finish none → 2019-03-05 |
| 5 | Confirmation of EPDP Team |  |  |  |  |  | baseline start none → 2019-03-05; baseline finish none → 2019-04-01 |
| 6 | Appointment of EPDP Team Chair |  |  |  |  |  | baseline start none → 2019-03-05; baseline finish none → 2019-04-15 |
| 7 | Appointment of EPDP Liaison to GNSO Council |  |  |  |  |  | baseline start none → 2019-04-16; baseline finish none → 2019-04-22 |
| 8 | Chair / Staff preparations |  |  |  |  |  | baseline start none → 2019-04-16; baseline finish none → 2019-05-01 |
| 9 | **Project Management** |  | 2020-10-06 → 2020-11-26 (+51d) | 417d → 454d | 69% → 71% |  | baseline start none → 2019-03-06; baseline finish none → 2020-10-06 |
| 10 | Develop and confirm Project Plan |  |  |  |  |  | baseline start none → 2019-04-16; baseline finish none → 2019-08-19 |
| 11 | Adopt iterative work plan(s) |  |  |  |  |  | baseline start none → 2019-04-16; baseline finish none → 2019-08-19 |
| 12 | Develop Project status work products and communications |  |  |  |  |  | baseline start none → 2019-04-16; baseline finish none → 2019-08-19 |
| 13 | Obtain project plan approval from GNSO Council |  |  |  |  |  | baseline start none → 2019-08-22; baseline finish none → 2019-08-22 |
| 14 | **Leadership Sub team** |  | 2020-04-30 → 2020-06-18 (+49d) | 275d → 310d | 60% → 53% | 93d → 95d | baseline start none → 2019-04-16; baseline finish none → 2020-04-30 |
| 15 | On-going preparation and planning of EPDP-P2 activities |  | 2020-04-30 → 2020-06-18 (+49d) | 275d → 310d | 60% → 53% | 93d → 95d | baseline start none → 2019-04-16; baseline finish none → 2020-04-30 |
| 16 | **Project Cost Support Team Sub team** |  |  |  | 60% → 68% | 37d → 74d | baseline start none → 2019-03-06; baseline finish none → 2020-07-17 |
| 17 | Develop EPDP Fact Sheet |  |  |  |  |  | baseline start none → 2019-04-16; baseline finish none → 2019-05-27 |
| 18 | Request and acquire preliminary dedicated funds for additional project resources |  |  |  |  |  | baseline start none → 2019-03-06; baseline finish none → 2019-04-02 |
| 19 | Request and acquire funds for dedicated F2F sessions & facilitation services |  |  |  |  |  | baseline start none → 2019-05-02; baseline finish none → 2019-05-29 |
| 20 | Request and acquire final dedicated funds for additional project resources |  |  |  |  |  | baseline start none → 2019-08-27; baseline finish none → 2019-10-08 |
| 21 | On-going financial and resource approvals of EPDP-P2 activities |  |  |  | 50% → 60% | 37d → 74d | baseline start none → 2019-03-06; baseline finish none → 2020-07-17 |
| 22 | Close project plan, Factsheet, and transition project to IPT | 2020-09-09 → 2020-10-30 (+51d) | 2020-10-06 → 2020-11-26 (+51d) |  |  |  | baseline start none → 2020-09-09; baseline finish none → 2020-10-06 |
| 23 | **EPDP DELIBERATIONS** |  |  |  | 49% → 59% | 87d → 124d | baseline start none → 2019-04-03; baseline finish none → 2020-06-05 |
| 24 | First meeting of EPDP Team |  |  |  |  |  | baseline start none → 2019-05-02; baseline finish none → 2019-05-02 |
| 25 | Understand Charter, organize materials and develop initial approach |  |  |  |  |  | baseline start none → 2019-05-02; baseline finish none → 2019-05-22 |
| 26 | Develop Worksheets for Phase 2 due diligence and organize work by Priority 1 & 2 Topics |  |  |  |  |  | baseline start none → 2019-05-02; baseline finish none → 2019-05-30 |
| 27 | Review prior legal advice memos and formulate potential topics that may require advice |  |  |  |  |  | baseline start none → 2019-05-02; baseline finish none → 2019-05-30 |
| 28 | Develop definitions and terminology |  |  |  |  |  | baseline start none → 2019-05-02; baseline finish none → 2019-05-30 |
| 29 | **Input from other SO/ACs & GNSO SG/Cs** |  |  |  |  | 227d → 264d | baseline start none → 2019-05-23; baseline finish none → 2019-11-22 |
| 30 | Develop template for input |  |  |  |  |  | baseline start none → 2019-05-23; baseline finish none → 2019-05-29 |
| 31 | Announce input opportunity |  |  |  |  |  | baseline start none → 2019-05-30; baseline finish none → 2019-05-30 |
| 32 | Collect and collate input in to Review Tool |  |  |  |  |  | baseline start none → 2019-05-31; baseline finish none → 2019-07-09 |
| 33 | Group to review input and determine relevance to policy deliberations on issues within scope |  |  |  |  | 227d → 264d | baseline start none → 2019-07-10; baseline finish none → 2019-11-22 |
| 34 | **Priority 1 Deliberations** |  | 2019-11-19 → 2020-01-23 (+65d) | 125d → 172d | 87% → 73% | 230d → 3d | baseline start none → 2019-05-31; baseline finish none → 2019-11-19 |
| 35 | **Requirements, incl. defining user groups, use cases and other criteria to determine similarities and differences** |  |  |  |  |  | baseline start none → 2019-05-31; baseline finish none → 2019-09-05 |
| 36 | Deliberate Groups to Use Case approach |  |  |  |  |  | baseline start none → 2019-06-14; baseline finish none → 2019-06-27 |
| 37 | Deliberate Single Use Case to establish Template |  |  |  |  |  | baseline start none → 2019-06-14; baseline finish none → 2019-06-27 |
| 38 | **Generate potential Use Cases (refer to 20+ on wiki)** |  |  |  |  |  | baseline start none → 2019-05-31; baseline finish none → 2019-09-05 |
| 39 | Confirm Use Case order and groups to consolidate |  |  |  |  |  | baseline start none → 2019-06-28; baseline finish none → 2019-09-05 |
| 40 | Understand Purposes and Legitimate Interest for third party disclosure |  |  |  |  |  | baseline start none → 2019-05-31; baseline finish none → 2019-07-02 |
| 41 | First reading + response |  |  |  |  |  | baseline start none → 2019-06-28; baseline finish none → 2019-09-05 |
| 42 | Deliberate other policy topics as necessary to better inform dedicated time to that topic |  |  |  |  |  | baseline start none → 2019-06-28; baseline finish none → 2019-08-08 |
| 43 | Develop subsequent draft + response |  |  |  |  |  | baseline start none → 2019-06-28; baseline finish none → 2019-09-05 |
| 44 | Second reading + adoption or discard |  |  |  |  |  | baseline start none → 2019-06-28; baseline finish none → 2019-09-05 |
| 45 | **SSAD Model & Building Blocks & Preliminary Recommendations** |  | 2019-11-19 → 2020-01-23 (+65d) | 75d → 122d | 84% → 70% | 230d → 3d | was named SSAD Model & Worksheets & Preliminary Recommendations; baseline start none → 2019-08-09; baseline finish none → 2019-11-19 |
| 46 | **Safeguards** |  | 2019-11-19 → 2020-01-23 (+65d) | 74.5d → 122d | 80% → 63% | 230.5d → 3d | baseline start none → 2019-08-09; baseline finish none → 2019-11-19 |
| 47 | Review inputs from Requirements and Use Cases |  |  |  |  |  | baseline start none → 2019-08-09; baseline finish none → 2019-09-12 |
| 48 | **Understand sub-topics and determine need to deliberate** |  | 2019-09-26 → 2020-01-14 (+110d) | 10d → 90d | 78% → 57% |  | baseline start none → 2019-09-12; baseline finish none → 2019-09-26 |
| 49 | Query volume limitations |  | 2019-09-26 A → 2019-12-03 A (+68d) | 10d → 60d |  |  | baseline start none → 2019-09-12; baseline finish none → 2019-09-26 |
| 50 | Code of conduct |  | 2019-09-26 → 2020-01-14 (+110d) | 10d → 90d | 25% → 3% |  | baseline start none → 2019-09-12; baseline finish none → 2019-09-26 |
| 51 | Terms of use / disclosure agreements |  | 2019-09-26 A → 2020-01-14 (+110d) | 10d → 90d | 100% → 11% |  | baseline start none → 2019-09-12; baseline finish none → 2019-09-26 |
| 52 | Privacy policies |  | 2019-09-26 → 2020-01-14 A (+110d) | 10d → 90d | 10% → 100% |  | baseline start none → 2019-09-12; baseline finish none → 2019-09-26 |
| 53 | Retention and destruction of data |  | 2019-09-26 A → 2020-01-14 (+110d) | 10d → 90d | 100% → 50% |  | baseline start none → 2019-09-12; baseline finish none → 2019-09-26 |
| 54 | Service level agreements |  | 2019-09-26 → 2020-01-14 (+110d) | 10d → 90d |  |  | baseline start none → 2019-09-12; baseline finish none → 2019-09-26 |
| 55 | Transfer of the Data |  | 2019-09-26 A → 2020-01-14 (+110d) | 10d → 90d | 100% → 11% |  | baseline start none → 2019-09-12; baseline finish none → 2019-09-26 |
| 56 | Disclosure of the Data |  | 2019-09-26 A → 2019-12-03 A (+68d) | 10d → 60d |  |  | baseline start none → 2019-09-12; baseline finish none → 2019-09-26 |
| 57 | Monitoring |  | 2019-09-26 A → 2019-12-03 A (+68d) | 10d → 60d |  |  | baseline start none → 2019-09-12; baseline finish none → 2019-09-26 |
| 58 | Audit trail |  | 2019-09-26 A → 2019-12-03 A (+68d) | 10d → 60d |  |  | baseline start none → 2019-09-12; baseline finish none → 2019-09-26 |
| 59 | Retention |  | 2019-09-26 A → 2019-12-03 A (+68d) | 10d → 60d |  |  | baseline start none → 2019-09-12; baseline finish none → 2019-09-26 |
| 60 | Destruction of data |  | 2019-09-26 A → 2019-12-03 A (+68d) | 10d → 60d |  |  | baseline start none → 2019-09-12; baseline finish none → 2019-09-26 |
| 61 | Deliberate policy considerations and determine approach |  |  |  |  |  | baseline start none → 2019-09-26; baseline finish none → 2019-10-03 |
| 62 | Deliberate policy issues |  | 2019-10-31 → 2020-01-21 (+82d) | 20d → 80d | 80% → 75% | 245.5d → 5.5d | baseline start none → 2019-10-03; baseline finish none → 2019-10-31 |
| 63 | Develop draft work product |  | 2019-11-12 → 2020-01-21 (+70d) | 30d → 80d | 80% → 75% | 4d → 0d | baseline start none → 2019-10-03; baseline finish none → 2019-11-12 |
| 64 | Conduct First Reading + verbal and email response |  | 2019-10-17 → 2020-01-21 A (+96d) | 10d → 80d | 80% → 100% | 24d → none | baseline start none → 2019-10-03; baseline finish none → 2019-10-17 |
| 65 | Conduct Second Reading + verbal response + adoption or discard |  | 2019-11-19 → 2020-01-23 (+65d) |  | 80% → 50% | 230.5d → 3d | baseline start none → 2019-11-12; baseline finish none → 2019-11-19 |
| 66 | **Accreditation and Authentication (Credentialing)** |  |  |  |  |  | baseline start none → 2019-09-06; baseline finish none → 2019-11-19 |
| 67 | Understand topic and determine need to deliberate |  |  |  |  |  | baseline start none → 2019-09-06; baseline finish none → 2019-09-12 |
| 68 | Deliberate policy considerations and determine approach |  |  |  |  |  | baseline start none → 2019-09-06; baseline finish none → 2019-09-12 |
| 69 | Deliberate policy issues |  |  |  |  |  | baseline start none → 2019-09-13; baseline finish none → 2019-10-31 |
| 70 | Develop draft work product |  |  |  |  |  | baseline start none → 2019-09-13; baseline finish none → 2019-11-12 |

| ID | Task | Start | Finish | Duration | Complete | Total float | Predecessors | Other |
| --- | --- | --- | --- | --- | --- | --- | --- | --- |
| 71 | Conduct First Reading + verbal and email response |  |  |  |  |  |  | baseline start none → 2019-09-13; baseline finish none → 2019-09-26 |
| 72 | Conduct Second Reading + verbal response + adoption or discard |  |  |  |  |  |  | baseline start none → 2019-11-13; baseline finish none → 2019-11-19 |
| 73 | **Lawful Basis & Balancing Test** |  | 2019-11-19 → 2020-01-17 (+59d) | 55d → 97.5d | 89% → 74% | 230d → 7.5d |  | baseline start none → 2019-09-06; baseline finish none → 2019-11-19 |
| 74 | Understand topic and determine need to deliberate |  |  |  |  |  |  | baseline start none → 2019-09-06; baseline finish none → 2019-09-12 |
| 75 | Deliberate policy considerations and determine approach |  |  |  |  |  |  | baseline start none → 2019-09-06; baseline finish none → 2019-09-12 |
| 76 | Deliberate policy issues |  | 2019-10-31 → 2020-01-14 (+75d) | 35d → 90d | 90% → 50% | 245d → 10d |  | baseline start none → 2019-09-13; baseline finish none → 2019-10-31 |
| 77 | Develop draft work product |  | 2019-11-12 → 2020-01-14 (+63d) | 45d → 90d | 90% → 70% | 2.5d → 0d |  | baseline start none → 2019-09-13; baseline finish none → 2019-11-12 |
| 78 | Conduct First Reading + verbal and email response |  | 2019-09-26 → 2020-01-14 A (+110d) | 10d → 90d | 90% → 100% | 37.5d → none |  | baseline start none → 2019-09-13; baseline finish none → 2019-09-26 |
| 79 | Conduct Second Reading + verbal response + adoption or discard |  | 2019-11-19 → 2020-01-17 (+59d) |  |  | 230d → 7.5d |  | baseline start none → 2019-11-13; baseline finish none → 2019-11-19 |
| 80 | **Determine Process publication, format and content request requirements** |  |  |  |  |  |  | baseline start none → 2019-09-06; baseline finish none → 2019-11-19 |
| 81 | Understand topic and determine need to deliberate |  |  |  |  |  |  | baseline start none → 2019-09-06; baseline finish none → 2019-09-12 |
| 82 | Deliberate policy considerations and determine approach |  |  |  |  |  |  | baseline start none → 2019-09-06; baseline finish none → 2019-09-12 |
| 83 | Deliberate policy issues |  |  |  |  |  |  | baseline start none → 2019-09-13; baseline finish none → 2019-10-31 |
| 84 | Develop draft work product |  |  |  |  |  |  | baseline start none → 2019-09-13; baseline finish none → 2019-11-12 |
| 85 | Conduct First Reading + verbal and email response |  |  |  |  |  |  | baseline start none → 2019-09-13; baseline finish none → 2019-09-26 |
| 86 | Conduct Second Reading + verbal response + adoption or discard |  |  |  |  |  |  | baseline start none → 2019-11-13; baseline finish none → 2019-11-19 |
| 87 | **Timeline of process** |  | 2019-11-19 A |  | 77% → 100% | 230d → none |  | baseline start none → 2019-09-06; baseline finish none → 2019-11-19 |
| 88 | Understand topic and determine need to deliberate |  |  |  |  |  |  | baseline start none → 2019-09-06; baseline finish none → 2019-09-12 |
| 89 | Deliberate policy considerations and determine approach |  |  |  |  |  |  | baseline start none → 2019-09-06; baseline finish none → 2019-09-12 |
| 90 | Deliberate policy issues |  | 2019-10-31 A |  | 75% → 100% | 245d → none |  | baseline start none → 2019-09-13; baseline finish none → 2019-10-31 |
| 91 | Develop draft work product |  | 2019-11-12 A |  | 75% → 100% | 3.75d → none |  | baseline start none → 2019-09-13; baseline finish none → 2019-11-12 |
| 92 | Conduct First Reading + verbal and email response |  | 2019-09-26 A |  | 75% → 100% | 38.75d → none |  | baseline start none → 2019-09-13; baseline finish none → 2019-09-26 |
| 93 | Conduct Second Reading + verbal response + adoption or discard |  | 2019-11-19 A |  | 75% → 100% | 230d → none |  | baseline start none → 2019-11-13; baseline finish none → 2019-11-19 |
| 94 | **Automation Analysis + Centralized vs. De-Centralized Models** |  | 2019-11-19 → 2020-01-17 (+59d) | 55d → 97.5d | 85% → 68% | 230d → 7.5d |  | baseline start none → 2019-09-06; baseline finish none → 2019-11-19 |
| 95 | Understand topic and determine need to deliberate |  |  |  |  |  |  | baseline start none → 2019-09-06; baseline finish none → 2019-09-12 |
| 96 | Deliberate policy considerations and determine approach |  |  |  |  |  |  | baseline start none → 2019-09-06; baseline finish none → 2019-09-12 |
| 97 | Deliberate policy issues |  | 2019-10-31 A → 2020-01-14 (+75d) | 35d → 90d | 100% → 70% | none → 10d |  | baseline start none → 2019-09-13; baseline finish none → 2019-10-31 |
| 98 | Determine if automation is consistent with legal requirements/legal basis |  | 2019-11-12 → 2020-01-14 (+63d) | 45d → 90d |  | 235d → 10d |  | baseline start none → 2019-09-13; baseline finish none → 2019-11-12 |
| 99 | Develop draft work product |  | 2019-11-12 A → 2020-01-14 (+63d) | 45d → 90d | 100% → 50% | none → 0d |  | baseline start none → 2019-09-13; baseline finish none → 2019-11-12 |
| 100 | Conduct First Reading + verbal and email response |  | 2019-09-26 A → 2020-01-14 A (+110d) | 10d → 90d |  |  |  | baseline start none → 2019-09-13; baseline finish none → 2019-09-26 |
| 101 | Conduct Second Reading + verbal response + adoption or discard |  | 2019-11-19 A → 2020-01-17 (+59d) |  | 100% → 50% | none → 7.5d |  | baseline start none → 2019-11-13; baseline finish none → 2019-11-19 |
| 102 | **Review possible comprehensive model and options** |  |  |  |  |  |  | baseline start none → 2019-09-06; baseline finish none → 2019-11-19 |
| 103 | Understand topic and determine need to deliberate |  |  |  |  |  |  | baseline start none → 2019-09-06; baseline finish none → 2019-09-12 |
| 104 | Deliberate policy considerations and determine approach |  |  |  |  |  |  | baseline start none → 2019-09-06; baseline finish none → 2019-09-12 |
| 105 | Deliberate policy issues |  |  |  |  |  |  | baseline start none → 2019-09-13; baseline finish none → 2019-10-31 |
| 106 | Develop draft work product |  |  |  |  |  |  | baseline start none → 2019-09-13; baseline finish none → 2019-11-12 |
| 107 | Conduct First Reading + verbal and email response |  |  |  |  |  |  | baseline start none → 2019-09-13; baseline finish none → 2019-09-26 |
| 108 | Conduct Second Reading + verbal response + adoption or discard |  |  |  |  |  |  | baseline start none → 2019-11-13; baseline finish none → 2019-11-19 |
| 109 | **Financial sustainability** |  | 2019-11-19 → 2020-01-20 (+62d) | 55d → 98.75d | 80% → 63% | 230d → 6.25d |  | baseline start none → 2019-09-06; baseline finish none → 2019-11-19 |
| 110 | Understand topic and determine need to deliberate |  |  |  |  |  |  | baseline start none → 2019-09-06; baseline finish none → 2019-09-12 |
| 111 | Deliberate policy considerations and determine approach |  |  |  |  |  |  | baseline start none → 2019-09-06; baseline finish none → 2019-09-12 |
| 112 | Deliberate policy issues |  | 2019-10-31 → 2020-01-14 (+75d) | 35d → 90d | 80% → 50% | 245d → 10d |  | baseline start none → 2019-09-13; baseline finish none → 2019-10-31 |
| 113 | Develop draft work product |  | 2019-11-12 → 2020-01-14 (+63d) | 45d → 90d | 80% → 70% | 230d → 0d |  | baseline start none → 2019-09-13; baseline finish none → 2019-11-12 |
| 114 | Conduct First Reading + verbal and email response |  |  |  |  |  |  | baseline start none → 2019-09-13; baseline finish none → 2019-09-26 |
| 115 | Conduct Second Reading + verbal response + adoption or discard | 2019-11-13 A | 2019-11-19 → 2020-01-20 (+62d) |  | 0% → 25% | 230d → 6.25d |  | baseline start none → 2019-11-13; baseline finish none → 2019-11-19 |
| 116 | **Purpose 2 Rework per Phase 1 and Board Instruction to GNSO Council** |  | 2019-11-19 → 2020-01-21 (+63d) | 55d → 100d | 52% → 27% | 230d → 5d |  | baseline start none → 2019-09-06; baseline finish none → 2019-11-19 |
| 117 | Understand topic and determine need to deliberate |  |  |  |  |  |  | baseline start none → 2019-09-06; baseline finish none → 2019-09-12 |
| 118 | Deliberate policy considerations and determine approach |  |  |  |  |  |  | baseline start none → 2019-09-06; baseline finish none → 2019-09-12 |
| 119 | Deliberate policy issues |  | 2019-10-31 → 2020-01-14 (+75d) | 35d → 90d | 50% → 19% | 245d → 10d |  | baseline start none → 2019-09-13; baseline finish none → 2019-10-31 |
| 120 | Develop draft work product |  | 2019-11-12 → 2020-01-14 (+63d) | 45d → 90d | 50% → 25% | 230d → 5d |  | baseline start none → 2019-09-13; baseline finish none → 2019-11-12 |
| 121 | Conduct First Reading + verbal and email response |  |  |  |  | 265d → 85d |  | baseline start none → 2019-09-13; baseline finish none → 2019-09-26 |
| 122 | Conduct Second Reading + verbal response + adoption or discard | 2019-11-13 → 2020-01-15 (+63d) | 2019-11-19 → 2020-01-21 (+63d) |  |  | 230d → 2d |  | baseline start none → 2019-11-13; baseline finish none → 2019-11-19 |
| 124 | Understand topic and determine need to deliberate | 2019-12-04 → 2019-09-06 A (-89d) | 2019-12-10 → 2019-09-12 A (-89d) |  | 0% → 100% | 140d → none | 306 → 38 | constraint start no earlier than 2019-08-22 → none; baseline start none → 2019-09-06; baseline finish none → 2019-09-12 |
| 125 | Deliberate policy considerations and determine approach | 2019-12-11 → 2019-09-06 A (-96d) | 2019-12-17 → 2019-09-12 A (-96d) |  | 0% → 100% | 140d → none | 124 → 38 | constraint start no earlier than 2019-08-22 → none; baseline start none → 2019-09-06; baseline finish none → 2019-09-12 |
| 126 | Deliberate policy issues | 2019-12-18 → 2019-09-13 A (-96d) | 2020-03-10 → 2019-12-31 A (-70d) | 60d → 80d | 0% → 100% | 150d → none |  | baseline start none → 2019-09-13; baseline finish none → 2019-10-31 |
| 127 | Develop draft work product | 2019-12-18 → 2019-09-13 A (-96d) | 2020-03-10 → 2019-12-31 A (-70d) | 60d → 80d | 0% → 100% | 140d → none |  | baseline start none → 2019-09-13; baseline finish none → 2019-11-12 |
| 128 | Conduct First Reading + verbal and email response | 2020-03-11 → 2019-09-13 A (-180d) | 2020-03-17 → 2019-09-26 A (-173d) | 5d → 10d | 0% → 100% | 140d → none | 127 → 125 | baseline start none → 2019-09-13; baseline finish none → 2019-09-26 |
| 129 | Conduct Second Reading + verbal response + adoption or discard | 2020-03-18 → 2019-11-13 A (-126d) | 2020-03-24 → 2020-01-03 A (-81d) |  | 0% → 100% | 140d → none | 128 → 127, 128 | baseline start none → 2019-11-13; baseline finish none → 2019-11-19 |
| 130 | Priority 1 draft zero documents for LA1 F2F2 |  |  |  |  |  |  | baseline start none → 2019-09-05; baseline finish none → 2019-09-05 |
| 131 | Priority 1 draft 1.0 documents for ICANN66 Montreal |  |  |  |  |  | 62, 69, 76, 83, 90, 97, 105, 112, 119 → 62, 69, 76, 83, 90, 97, 105, 112, 119, 126 | baseline start none → 2019-10-31; baseline finish none → 2019-10-31 |
| 132 | **Priority 2 Deliberations (Issues carried from Phase 1)** |  | 2020-04-23 → 2020-05-14 (+21d) | 237d → 252d | 16% → 31% | 118d → 140d |  | baseline start none → 2019-05-31; baseline finish none → 2020-04-23 |
| 133 | Organize Priority 2 topics |  |  |  |  |  |  | baseline start none → 2019-05-31; baseline finish none → 2019-05-31 |
| 134 | **Display of information of affiliated vs. accredited privacy / proxy providers** |  | 2020-04-15 → 2020-05-06 (+21d) | 230d → 245d | 1% → 20% | 124d → 146d |  | baseline start none → 2019-06-03; baseline finish none → 2020-04-15 |
| 135 | Initial Scoping of topic |  |  |  |  |  |  | baseline start none → 2019-06-03; baseline finish none → 2019-06-07 |
| 136 | **Understand topic and determine need to deliberate** | 2019-06-10 A |  |  | 0% → 27% | 124d → 146d |  | baseline start none → 2019-06-10; baseline finish none → 2019-11-06 |
| 137 | PPSAI IRT briefing to determine how their work compliments or depends on EPDP | 2019-06-10 A |  |  | 0% → 20% | 124d → 146d |  | baseline start none → 2019-06-10; baseline finish none → 2019-11-06 |
| 138 | Determine if briefing regarding a data privacy impact assessment on the PPSAI program is required | 2019-06-10 A |  |  | 0% → 10% | 124d → 146d |  | baseline start none → 2019-06-10; baseline finish none → 2019-11-06 |
| 139 | Determine if answers to legal questions are required | 2019-06-10 A |  |  | 0% → 50% | 124d → 146d |  | baseline start none → 2019-06-10; baseline finish none → 2019-11-06 |
| 140 | Deliberate policy considerations and determine approach |  |  |  |  | 124d → 146d |  | baseline start none → 2019-11-07; baseline finish none → 2019-11-13 |
| 141 | Deliberate policy issues |  | 2020-03-18 → 2020-04-08 (+21d) | 90d → 105d |  | 124d → 153d |  | baseline start none → 2019-11-14; baseline finish none → 2020-03-18 |

| ID | Task | Start | Finish | Duration | Complete | Total float | Predecessors | Other |
| --- | --- | --- | --- | --- | --- | --- | --- | --- |
| 142 | Develop draft work product | 2020-03-19 → 2020-04-09 (+21d) | 2020-04-01 → 2020-04-22 (+21d) |  |  | 124d → 153d |  | baseline start none → 2020-03-19; baseline finish none → 2020-04-01 |
| 143 | Conduct First Reading + verbal and email response | 2020-04-02 → 2020-04-23 (+21d) | 2020-04-08 → 2020-04-29 (+21d) |  |  | 124d → 153d |  | baseline start none → 2020-04-02; baseline finish none → 2020-04-08 |
| 144 | Conduct Second Reading + verbal response + adoption or discard | 2020-04-09 → 2020-04-30 (+21d) | 2020-04-15 → 2020-05-06 (+21d) |  |  | 124d → 153d |  | baseline start none → 2020-04-09; baseline finish none → 2020-04-15 |
| 145 | **Legal vs. Natural** |  | 2020-04-15 → 2020-05-06 (+21d) | 230d → 245d | 40% → 39% | 124d → 146d |  | baseline start none → 2019-06-03; baseline finish none → 2020-04-15 |
| 146 | Initial Scoping of topic |  |  |  |  |  |  | baseline start none → 2019-06-03; baseline finish none → 2019-06-07 |
| 147 | **Understand topic and determine need to deliberate** |  |  |  |  | 124d → 146d |  | baseline start none → 2019-06-10; baseline finish none → 2019-11-06 |
| 148 | Receive briefing from Bird & Bird on legal vs. natural memo |  |  |  |  | 124d → 153d |  | baseline start none → 2019-06-10; baseline finish none → 2019-11-06 |
| 149 | Determine if answers to legal questions are required |  |  |  |  |  |  | baseline start none → 2019-06-10; baseline finish none → 2019-11-06 |
| 150 | EPDP Team to confirm with ICANN Org expected next steps and timing to conduct and publish the study results. |  |  |  |  |  |  | baseline start none → 2019-06-10; baseline finish none → 2019-11-06 |
| 151 | EPDP Team or Sub-team to work with ICANN org on this study, including providing questions and/or relevant background to assist in informing the study by 1 July 2019. |  |  |  |  | 124d → 153d |  | baseline start none → 2019-06-10; baseline finish none → 2019-11-06 |
| 152 | Deliberate policy considerations and determine approach |  |  |  |  | 124d → 153d |  | baseline start none → 2019-11-07; baseline finish none → 2019-11-13 |
| 153 | Deliberate policy issues |  | 2020-03-18 → 2020-04-08 (+21d) | 90d → 105d |  | 124d → 153d |  | baseline start none → 2019-11-14; baseline finish none → 2020-03-18 |
| 154 | Develop draft work product | 2020-03-19 → 2020-04-09 (+21d) | 2020-04-01 → 2020-04-22 (+21d) |  |  | 124d → 153d |  | baseline start none → 2020-03-19; baseline finish none → 2020-04-01 |
| 155 | Conduct First Reading + verbal and email response | 2020-04-02 → 2020-04-23 (+21d) | 2020-04-08 → 2020-04-29 (+21d) |  |  | 124d → 153d |  | baseline start none → 2020-04-02; baseline finish none → 2020-04-08 |
| 156 | Conduct Second Reading + verbal response + adoption or discard | 2020-04-09 → 2020-04-30 (+21d) | 2020-04-15 → 2020-05-06 (+21d) |  |  | 124d → 153d |  | baseline start none → 2020-04-09; baseline finish none → 2020-04-15 |
| 157 | **City Field** |  | 2020-04-23 → 2020-05-14 (+21d) | 230d → 245d | 5% → 30% | 118d → 140d |  | baseline start none → 2019-06-11; baseline finish none → 2020-04-23 |
| 158 | Initial Scoping of topic |  |  |  |  |  |  | baseline start none → 2019-06-11; baseline finish none → 2019-06-17 |
| 159 | **Understand topic and determine need to deliberate** |  |  |  | 6% → 48% | 118d → 140d |  | baseline start none → 2019-06-18; baseline finish none → 2019-11-14 |
| 160 | Receive briefing from Bird & Bird on city field memo |  |  |  |  | 118d → 140d |  | baseline start none → 2019-06-18; baseline finish none → 2019-11-14 |
| 161 | Determine if answers to legal questions are required | 2019-06-18 A | 2019-10-07 A |  | 0% → 100% | 148d → none |  | baseline start none → 2019-06-18; baseline finish none → 2019-10-07 |
| 162 | Deliberate policy considerations and determine approach |  |  |  |  | 118d → 140d |  | baseline start none → 2019-11-15; baseline finish none → 2019-11-21 |
| 163 | Deliberate policy issues |  | 2020-03-26 → 2020-04-16 (+21d) | 90d → 105d |  | 118d → 147d |  | baseline start none → 2019-11-22; baseline finish none → 2020-03-26 |
| 164 | Develop draft work product | 2020-03-27 → 2020-04-17 (+21d) | 2020-04-09 → 2020-04-30 (+21d) |  |  | 118d → 147d |  | baseline start none → 2020-03-27; baseline finish none → 2020-04-09 |
| 165 | Conduct First Reading + verbal and email response | 2020-04-10 → 2020-05-01 (+21d) | 2020-04-16 → 2020-05-07 (+21d) |  |  | 118d → 147d |  | baseline start none → 2020-04-10; baseline finish none → 2020-04-16 |
| 166 | Conduct Second Reading + verbal response + adoption or discard | 2020-04-17 → 2020-05-08 (+21d) | 2020-04-23 → 2020-05-14 (+21d) |  |  | 118d → 147d |  | baseline start none → 2020-04-17; baseline finish none → 2020-04-23 |
| 167 | **Data Retention** |  | 2020-04-23 → 2020-05-14 (+21d) | 230d → 245d | 12% → 36% | 118d → 140d |  | baseline start none → 2019-06-11; baseline finish none → 2020-04-23 |
| 168 | Initial Scoping of topic |  |  |  |  |  |  | baseline start none → 2019-06-11; baseline finish none → 2019-06-17 |
| 169 | **Understand topic and determine need to deliberate** |  |  |  | 20% → 75% | 118d → 140d |  | baseline start none → 2019-06-18; baseline finish none → 2019-11-14 |
| 170 | Confirm with ICANN org when the review of all of ICANN org's processes and procedures to identify and document the instances in which personal data is requested beyond the life of domain name registration is expected to be completed. |  |  |  | 20% → 75% | 118d → 140d |  | baseline start none → 2019-06-18; baseline finish none → 2019-11-14 |
| 171 | Deliberate policy considerations and determine approach |  |  |  |  | 118d → 140d |  | baseline start none → 2019-11-15; baseline finish none → 2019-11-21 |
| 172 | **Deliberate policy issues** |  | 2020-03-26 → 2020-04-16 (+21d) | 90d → 105d |  | 118d → 140d |  | baseline start none → 2019-11-22; baseline finish none → 2020-03-26 |
| 173 | Confirm whether the data retention requirements recommended in phase 1 are to be confirmed or whether updates are needed |  | 2020-03-26 → 2020-04-16 (+21d) | 90d → 105d |  | 118d → 140d |  | baseline start none → 2019-11-22; baseline finish none → 2020-03-26 |
| 174 | Develop draft work product | 2020-03-27 → 2020-04-17 (+21d) | 2020-04-09 → 2020-04-30 (+21d) |  |  | 118d → 140d |  | baseline start none → 2020-03-27; baseline finish none → 2020-04-09 |
| 175 | Conduct First Reading + verbal and email response | 2020-04-10 → 2020-05-01 (+21d) | 2020-04-16 → 2020-05-07 (+21d) |  |  | 118d → 140d |  | baseline start none → 2020-04-10; baseline finish none → 2020-04-16 |
| 176 | Conduct Second Reading + verbal response + adoption or discard | 2020-04-17 → 2020-05-08 (+21d) | 2020-04-23 → 2020-05-14 (+21d) |  |  | 118d → 140d |  | baseline start none → 2020-04-17; baseline finish none → 2020-04-23 |
| 177 | **Additional purpose for ICANN’s OCTO** |  | 2020-04-15 → 2020-05-06 (+21d) | 220d → 235d | 2% → 31% | 124d → 146d |  | baseline start none → 2019-06-17; baseline finish none → 2020-04-15 |
| 178 | Initial Scoping of topic |  |  |  |  |  |  | baseline start none → 2019-06-17; baseline finish none → 2019-06-21 |
| 179 | **Understand topic and determine need to deliberate** | 2019-06-24 A |  |  | 0% → 50% | 124d → 146d |  | baseline start none → 2019-06-24; baseline finish none → 2019-11-06 |
| 180 | Further to EPDP-P1 Rec#2, EPDP Team to draft question to ICANN org, to inform next steps. | 2019-06-24 A | 2019-11-06 A |  | 0% → 100% | 124d → none |  | baseline start none → 2019-06-24; baseline finish none → 2019-11-06 |
| 181 | Determine if answers to legal questions are required |  |  |  |  | 124d → 153d |  | baseline start none → 2019-06-24; baseline finish none → 2019-11-06 |
| 182 | Deliberate policy considerations and determine approach |  |  |  |  | 124d → 146d |  | baseline start none → 2019-11-07; baseline finish none → 2019-11-13 |
| 183 | Deliberate policy issues |  | 2020-03-18 → 2020-04-08 (+21d) | 90d → 105d |  | 124d → 153d |  | baseline start none → 2019-11-14; baseline finish none → 2020-03-18 |
| 184 | Develop draft work product | 2020-03-19 → 2020-04-09 (+21d) | 2020-04-01 → 2020-04-22 (+21d) |  |  | 124d → 153d |  | baseline start none → 2020-03-19; baseline finish none → 2020-04-01 |
| 185 | Conduct First Reading + verbal and email response | 2020-04-02 → 2020-04-23 (+21d) | 2020-04-08 → 2020-04-29 (+21d) |  |  | 124d → 153d |  | baseline start none → 2020-04-02; baseline finish none → 2020-04-08 |
| 186 | Conduct Second Reading + verbal response + adoption or discard | 2020-04-09 → 2020-04-30 (+21d) | 2020-04-15 → 2020-05-06 (+21d) |  |  | 124d → 153d |  | baseline start none → 2020-04-09; baseline finish none → 2020-04-15 |
| 187 | **Feasibility of unique contacts to have uniform anonymized email address** |  | 2020-04-01 → 2020-05-13 (+42d) | 210d → 240d | 35% → 30% | 134d → 141d |  | baseline start none → 2019-06-17; baseline finish none → 2020-04-01 |
| 188 | Initial Scoping of topic |  |  |  |  |  |  | baseline start none → 2019-06-17; baseline finish none → 2019-06-21 |
| 189 | **Understand topic and determine need to deliberate** |  |  |  |  | 134d → 141d |  | baseline start none → 2019-06-24; baseline finish none → 2019-10-25 |
| 190 | Determine if answers to legal questions are required |  |  |  |  | 134d → 141d |  | baseline start none → 2019-06-24; baseline finish none → 2019-10-25 |
| 191 | Deliberate policy considerations and determine approach |  |  |  |  | 134d → 148d |  | baseline start none → 2019-10-28; baseline finish none → 2019-11-01 |
| 192 | Deliberate policy issues |  | 2020-03-04 → 2020-04-15 (+42d) | 90d → 120d |  | 134d → 148d |  | baseline start none → 2019-11-02; baseline finish none → 2020-03-04 |
| 193 | Develop draft work product | 2020-03-05 → 2020-04-16 (+42d) | 2020-03-18 → 2020-04-29 (+42d) |  |  | 134d → 148d |  | baseline start none → 2020-03-05; baseline finish none → 2020-03-18 |
| 194 | Conduct First Reading + verbal and email response | 2020-03-19 → 2020-04-30 (+42d) | 2020-03-25 → 2020-05-06 (+42d) |  |  | 134d → 148d |  | baseline start none → 2020-03-19; baseline finish none → 2020-03-25 |
| 195 | Conduct Second Reading + verbal response + adoption or discard | 2020-03-26 → 2020-05-07 (+42d) | 2020-04-01 → 2020-05-13 (+42d) |  |  | 134d → 148d |  | baseline start none → 2020-03-26; baseline finish none → 2020-04-01 |
| 196 | **Data Accuracy and the WHOIS Accuracy Reporting System** |  | 2020-04-23 → 2020-05-14 (+21d) | 210d → 225d | 9% → 30% | 118d → 140d |  | baseline start none → 2019-07-09; baseline finish none → 2020-04-23 |
| 197 | Initial Scoping of topic |  |  |  |  |  |  | baseline start none → 2019-07-09; baseline finish none → 2019-07-15 |
| 198 | **Understand topic and determine need to deliberate** |  |  |  | 13% → 50% | 118d → 140d |  | baseline start none → 2019-07-16; baseline finish none → 2019-11-14 |
| 199 | Receive briefing from Bird & Bird on city field memo |  |  |  |  | 118d → 147d |  | baseline start none → 2019-07-16; baseline finish none → 2019-11-14 |
| 200 | Determine if answers to legal questions are required |  | 2019-11-14 A |  | 25% → 100% | 118d → none |  | baseline start none → 2019-07-16; baseline finish none → 2019-11-14 |
| 201 | Deliberate policy considerations and determine approach |  |  |  |  | 118d → 140d |  | baseline start none → 2019-11-15; baseline finish none → 2019-11-21 |
| 202 | Deliberate policy issues |  | 2020-03-26 → 2020-04-16 (+21d) | 90d → 105d |  | 118d → 147d |  | baseline start none → 2019-11-22; baseline finish none → 2020-03-26 |
| 203 | Develop draft work product | 2020-03-27 → 2020-04-17 (+21d) | 2020-04-09 → 2020-04-30 (+21d) |  |  | 118d → 147d |  | baseline start none → 2020-03-27; baseline finish none → 2020-04-09 |
| 204 | Conduct First Reading + verbal and email response | 2020-04-10 → 2020-05-01 (+21d) | 2020-04-16 → 2020-05-07 (+21d) |  |  | 118d → 147d |  | baseline start none → 2020-04-10; baseline finish none → 2020-04-16 |
| 205 | Conduct Second Reading + verbal response + adoption or discard | 2020-04-17 → 2020-05-08 (+21d) | 2020-04-23 → 2020-05-14 (+21d) |  |  | 118d → 147d |  | baseline start none → 2020-04-17; baseline finish none → 2020-04-23 |
| 206 | **Unplanned Issues & Tasks** | 2019-12-04 → 2019-11-02 A (-32d) | 2020-03-24 → 2020-03-04 (-20d) | 80d → 90d | 0% → 50% | 140d → 191d |  | baseline start none → 2019-12-04; baseline finish none → 2020-03-24 |
| 207 | **Phase 2 - Financial Costing Estimate - ICANN Org Finance** | 2019-12-04 → 2019-11-25 A (-9d) | 2020-03-24 → 2020-02-14 (-39d) | 80d → 60d | 0% → 50% | 140d → 204d |  | was named Phase 2 - Placeholder; baseline start none → 2019-12-04; baseline finish none → 2020-03-24 |
| 209 | **Phase 2 - Placeholder (Strawberry Paper / EDPB Input)** | 2019-12-04 → 2019-11-02 A (-32d) | 2020-03-24 → 2020-03-04 (-20d) | 80d → 90d | 0% → 50% | 140d → 191d |  | was named Phase 2 - Placeholder (Strawberry Paper / EDPB Input?); baseline start none → 2019-12-04; baseline finish none → 2020-03-24 |
| 210 | Await input on TSG/UAM Model from EDPB | 2019-12-04 → 2019-11-02 A (-32d) | 2019-12-10 → 2020-03-04 (+85d) | 5d → 90d | 0% → 50% | 140d → 191d | 306 → none | was named Understand topic and determine need to deliberate; constraint start no earlier than 2019-08-22 → start no earlier than 2019-11-02; baseline start none → 2019-12-04; baseline finish none → 2019-12-10 |
| 211 | **Legal Sub team** |  | 2019-11-28 → 2020-02-06 (+70d) | 133d → 183d | 85% → 86% | 123d → 150d |  | baseline start none → 2019-05-30; baseline finish none → 2019-11-28 |
| 212 | Establish operating framework for handling legal advice requirements |  |  |  |  |  |  | baseline start none → 2019-05-30; baseline finish none → 2019-07-15 |

| ID | Task | Start | Finish | Duration | Complete | Total float | Other |
| --- | --- | --- | --- | --- | --- | --- | --- |
| 213 | Select members and establish chair |  |  |  |  |  | baseline start none → 2019-05-30; baseline finish none → 2019-07-15 |
| 214 | On-going review of legal questions / advice and interaction with counsel for Initial Report |  | 2019-11-28 → 2020-02-06 (+70d) | 100d → 150d | 75% → 80% | 123d → 150d | baseline start none → 2019-07-16; baseline finish none → 2019-11-28 |
| 215 | **Key Events** |  |  |  | 64% → 72% | 87d → 124d | baseline start none → 2019-04-03; baseline finish none → 2020-06-05 |
| 216 | **EPDP Team F2F Meeting - Marrakech (24-27 Jun 2019)** |  |  |  |  |  | baseline start none → 2019-04-03; baseline finish none → 2019-09-04 |
| 217 | Determine requirements and scope |  |  |  |  |  | baseline start none → 2019-04-03; baseline finish none → 2019-04-03 |
| 218 | Obtain PCST approval |  |  |  |  |  | baseline start none → 2019-04-04; baseline finish none → 2019-04-17 |
| 219 | Interact with Meetings Team |  |  |  |  |  | baseline start none → 2019-04-18; baseline finish none → 2019-07-31 |
| 220 | Engage EPDP team to confirm RSVPs and manage applications for travel support |  |  |  |  |  | baseline start none → 2019-04-18; baseline finish none → 2019-05-29 |
| 221 | Engage facilitators - not required |  |  |  |  |  | baseline start none → 2019-04-17; baseline finish none → 2019-04-17 |
| 222 | Plan agenda |  |  |  |  |  | baseline start none → 2019-04-18; baseline finish none → 2019-06-19 |
| 223 | Confirm Day 0 work products (see tasks above) |  |  |  |  |  | baseline start none → 2019-06-13; baseline finish none → 2019-06-13 |
| 224 | Day 0 preparations |  |  |  |  |  | baseline start none → 2019-06-21; baseline finish none → 2019-06-21 |
| 225 | Day 1 sessions |  |  |  |  |  | baseline start none → 2019-06-25; baseline finish none → 2019-06-25 |
| 226 | Day 2 sessions |  |  |  |  |  | baseline start none → 2019-06-27; baseline finish none → 2019-06-27 |
| 227 | F2F Recon and Sitrep |  |  |  |  |  | baseline start none → 2019-06-27; baseline finish none → 2019-06-27 |
| 228 | Communicate outcomes |  |  |  |  |  | baseline start none → 2019-06-28; baseline finish none → 2019-07-11 |
| 229 | Manage financial invoice, payment confirmation, and tracking (report to PCST) |  |  |  |  |  | baseline start none → 2019-04-18; baseline finish none → 2019-09-04 |
| 230 | Close F2F |  |  |  |  |  | baseline start none → 2019-09-04; baseline finish none → 2019-09-04 |
| 231 | **EPDP Team F2F Meeting - Los Angeles (08-11 Sept 2019)** |  | 2019-11-26 A |  | 89% → 100% | 225d → none | baseline start none → 2019-05-30; baseline finish none → 2019-11-26 |
| 232 | Determine requirements and scope |  |  |  |  |  | baseline start none → 2019-05-30; baseline finish none → 2019-05-30 |
| 233 | Obtain PCST approval |  |  |  |  |  | baseline start none → 2019-05-31; baseline finish none → 2019-06-27 |
| 234 | Interact with Meetings Team |  | 2019-10-24 A |  | 75% → 100% | 250d → none | baseline start none → 2019-06-07; baseline finish none → 2019-10-24 |
| 235 | Evaluate locations and reserve hotel and facilities |  |  |  |  |  | baseline start none → 2019-06-07; baseline finish none → 2019-07-11 |
| 236 | Engage EPDP team to confirm RSVPs and manage applications for travel support |  |  |  |  |  | baseline start none → 2019-07-12; baseline finish none → 2019-08-22 |
| 237 | Engage hotel and facilities support teams |  | 2019-10-17 A |  | 85% → 100% | 255d → none | baseline start none → 2019-07-12; baseline finish none → 2019-10-17 |
| 238 | Research and schedule events as necessary |  |  |  |  |  | baseline start none → 2019-07-12; baseline finish none → 2019-09-12 |
| 239 | Engage facilitators |  |  |  |  |  | baseline start none → 2019-06-07; baseline finish none → 2019-09-19 |
| 240 | Plan agenda |  |  |  |  |  | baseline start none → 2019-06-07; baseline finish none → 2019-09-11 |
| 241 | Confirm draft zero work products (see tasks above) |  |  |  |  |  | baseline start none → 2019-09-05; baseline finish none → 2019-09-05 |
| 242 | Day 0 preparations |  |  |  |  |  | baseline start none → 2019-09-08; baseline finish none → 2019-09-08 |
| 243 | Day 1 sessions |  |  |  |  |  | baseline start none → 2019-09-09; baseline finish none → 2019-09-09 |
| 244 | Day 2 sessions |  |  |  |  |  | baseline start none → 2019-09-10; baseline finish none → 2019-09-10 |
| 245 | Day 3 sessions |  |  |  |  |  | baseline start none → 2019-09-11; baseline finish none → 2019-09-11 |
| 246 | F2F Recon and Sitrep |  |  |  |  |  | baseline start none → 2019-09-11; baseline finish none → 2019-09-11 |
| 247 | Communicate outcomes |  |  |  |  |  | baseline start none → 2019-09-12; baseline finish none → 2019-09-25 |
| 248 | Manage financial invoice, payment confirmation, and tracking (report to PCST) |  | 2019-11-26 A |  | 75% → 100% | 225d → none | baseline start none → 2019-06-28; baseline finish none → 2019-11-26 |
| 249 | Close F2F |  | 2019-11-26 A |  | 75% → 100% | 225d → none | baseline start none → 2019-11-26; baseline finish none → 2019-11-26 |
| 250 | **EPDP Team F2F Meeting - Montreal (02-07 Nov 2019)** |  |  |  | 84% → 95% | 189d → 226d | baseline start none → 2019-08-23; baseline finish none → 2020-01-15 |
| 251 | Determine requirements and scope |  |  |  |  |  | baseline start none → 2019-08-23; baseline finish none → 2019-08-23 |
| 252 | Obtain PCST approval |  |  |  |  |  | baseline start none → 2019-08-26; baseline finish none → 2019-08-30 |
| 253 | Interact with Meetings Team |  |  |  |  | 214d → 251d | baseline start none → 2019-09-02; baseline finish none → 2019-12-11 |
| 254 | Engage EPDP team to confirm RSVPs and manage applications for travel support |  |  |  |  |  | baseline start none → 2019-09-02; baseline finish none → 2019-10-11 |
| 255 | Engage facilitators |  |  |  |  |  | baseline start none → 2019-08-30; baseline finish none → 2019-08-30 |
| 256 | Plan agenda |  |  |  |  |  | baseline start none → 2019-09-02; baseline finish none → 2019-10-25 |
| 257 | Confirm 1.0 draft work products (see tasks above) |  |  |  |  |  | baseline start none → 2019-10-31; baseline finish none → 2019-10-31 |
| 258 | Day 0 preparations |  |  |  |  |  | baseline start none → 2019-11-01; baseline finish none → 2019-11-01 |
| 259 | Day 1 sessions |  |  |  |  |  | baseline start none → 2019-11-02; baseline finish none → 2019-11-02 |
| 260 | Day 2 sessions |  |  |  |  |  | baseline start none → 2019-11-03; baseline finish none → 2019-11-03 |
| 261 | F2F Recon and Sitrep |  |  |  |  |  | baseline start none → 2019-11-03; baseline finish none → 2019-11-03 |
| 262 | Communicate outcomes |  |  |  |  |  | baseline start none → 2019-11-04; baseline finish none → 2019-11-15 |
| 263 | Manage financial invoice, payment confirmation, and tracking (report to PCST) |  |  |  | 65% → 95% | 189d → 226d | baseline start none → 2019-09-02; baseline finish none → 2020-01-15 |
| 264 | Close F2F |  |  |  |  | 189d → 233d | baseline start none → 2020-01-15; baseline finish none → 2020-01-15 |
| 265 | **EPDP Team F2F Meeting - Los Angeles (27-30 Jan 2020)** |  |  |  | 40% → 47% | 138d → 175d | baseline start none → 2019-09-24; baseline finish none → 2020-03-26 |
| 266 | Determine requirements and scope |  |  |  |  |  | baseline start none → 2019-09-24; baseline finish none → 2019-09-24 |
| 267 | Obtain PCST approval |  |  |  |  |  | baseline start none → 2019-09-24; baseline finish none → 2019-09-30 |
| 268 | Interact with Meetings Team |  |  |  | 25% → 45% | 168d → 205d | baseline start none → 2019-10-01; baseline finish none → 2020-02-13 |
| 269 | Evaluate locations and reserve hotel and facilities |  |  |  |  |  | baseline start none → 2019-10-01; baseline finish none → 2019-11-07 |
| 270 | Engage EPDP team to confirm RSVPs and manage applications for travel support |  |  |  |  |  | baseline start none → 2019-11-08; baseline finish none → 2019-12-19 |
| 271 | Engage hotel and facilities support teams |  |  |  | 20% → 35% | 148d → 185d | baseline start none → 2019-11-08; baseline finish none → 2020-03-12 |
| 272 | Research and schedule events as necessary |  |  |  | 20% → 35% | 188d → 225d | baseline start none → 2019-11-08; baseline finish none → 2020-01-16 |
| 273 | Engage facilitators |  |  |  |  |  | baseline start none → 2019-10-01; baseline finish none → 2020-01-30 |
| 274 | Plan agenda |  |  |  |  | 174d → 211d | baseline start none → 2019-10-01; baseline finish none → 2020-01-16 |
| 275 | Confirm Day 0 work products (see tasks above) | 2020-01-21 → 2020-03-23 (+62d) | 2020-01-21 → 2020-03-23 (+62d) |  |  |  | baseline start none → 2020-01-21; baseline finish none → 2020-01-21 |
| 276 | Day 0 preparations |  |  |  |  | 168d → 212d | baseline start none → 2020-01-27; baseline finish none → 2020-01-27 |
| 277 | Day 1 sessions |  |  |  |  | 168d → 212d | baseline start none → 2020-01-28; baseline finish none → 2020-01-28 |
| 278 | Day 2 sessions |  |  |  |  | 168d → 212d | baseline start none → 2020-01-29; baseline finish none → 2020-01-29 |
| 279 | Day 3 sessions |  |  |  |  | 168d → 212d | baseline start none → 2020-01-30; baseline finish none → 2020-01-30 |
| 280 | F2F Recon and Sitrep |  |  |  |  | 168d → 212d | baseline start none → 2020-01-30; baseline finish none → 2020-01-30 |
| 281 | Communicate outcomes |  |  |  |  | 168d → 212d | baseline start none → 2020-01-31; baseline finish none → 2020-02-13 |
| 282 | Manage financial invoice, payment confirmation, and tracking (report to PCST) |  |  |  |  | 138d → 182d | baseline start none → 2019-10-01; baseline finish none → 2020-03-26 |

| ID | Task | Start | Finish | Duration | Complete | Total float | Predecessors | Other |
| --- | --- | --- | --- | --- | --- | --- | --- | --- |
| 283 | Close F2F |  |  |  |  | 138d → 182d |  | baseline start none → 2020-03-26; baseline finish none → 2020-03-26 |
| 284 | **EPDP Team F2F Meeting - Cancun (07-12 Mar 2020)** |  |  |  | 17% → 26% | 87d → 124d |  | baseline start none → 2019-11-04; baseline finish none → 2020-06-05 |
| 285 | Determine requirements and scope |  |  |  |  |  |  | baseline start none → 2019-11-04; baseline finish none → 2019-11-04 |
| 286 | Obtain PCST approval |  |  |  |  |  |  | baseline start none → 2019-11-04; baseline finish none → 2019-11-08 |
| 287 | Interact with Meetings Team |  |  |  | 20% → 50% | 162d → 199d |  | baseline start none → 2019-11-11; baseline finish none → 2020-02-21 |
| 288 | Engage EPDP team to confirm RSVPs and manage applications for travel support |  | 2019-12-20 A |  | 80% → 100% | 207d → none |  | baseline start none → 2019-11-11; baseline finish none → 2019-12-20 |
| 289 | Engage facilitators |  |  |  |  |  |  | baseline start none → 2019-11-08; baseline finish none → 2019-11-08 |
| 290 | Plan agenda |  |  |  |  | 184d → 221d |  | baseline start none → 2019-11-11; baseline finish none → 2020-01-03 |
| 291 | Confirm Day 0 work products (see tasks above) |  |  |  |  | 237d → 274d |  | baseline start none → 2019-11-08; baseline finish none → 2019-11-08 |
| 292 | Day 0 preparations |  |  |  |  | 140d → 177d |  | baseline start none → 2020-03-06; baseline finish none → 2020-03-06 |
| 293 | Day 1 sessions |  |  |  |  | 140d → 177d |  | baseline start none → 2020-03-09; baseline finish none → 2020-03-09 |
| 294 | Day 2 sessions |  |  |  |  | 140d → 177d |  | baseline start none → 2020-03-10; baseline finish none → 2020-03-10 |
| 295 | F2F Recon and Sitrep |  |  |  |  | 140d → 177d |  | baseline start none → 2020-03-10; baseline finish none → 2020-03-10 |
| 296 | Communicate outcomes |  |  |  |  | 140d → 177d |  | baseline start none → 2020-03-11; baseline finish none → 2020-03-24 |
| 297 | Manage financial invoice, payment confirmation, and tracking (report to PCST) |  |  |  |  | 87d → 124d |  | baseline start none → 2019-11-11; baseline finish none → 2020-06-05 |
| 298 | Close F2F |  |  |  |  | 87d → 124d |  | baseline start none → 2020-06-05; baseline finish none → 2020-06-05 |
| 299 | **INITIAL REPORT** |  | 2020-01-21 → 2020-03-23 (+62d) | 150d → 194d | 75% → 82% | 105d → 178d |  | baseline start none → 2019-06-28; baseline finish none → 2020-01-21 |
| 300 | Assemble initial conclusions |  |  |  |  |  |  | baseline start none → 2019-06-28; baseline finish none → 2019-10-31 |
| 301 | Populate discussion papers with findings and potential recommendations |  |  |  |  |  |  | baseline start none → 2019-06-28; baseline finish none → 2019-10-31 |
| 302 | Discuss/approve findings and interim recommendations | 2019-11-01 A → 2020-01-24 A (+84d) | 2019-11-12 → 2020-01-31 (+80d) | 10d → 6d | 30% → 50% | 5d → 0d | 131, 301 → 131, 301, 34 | baseline start none → 2019-11-01; baseline finish none → 2019-11-12 |
| 303 | Consolidate interim recommendations and findings | 2019-11-01 A → 2020-01-24 A (+84d) | 2019-11-19 → 2020-01-31 (+73d) | 15d → 6d | 60% → 80% |  | 131, 301 → 131, 301, 34 | baseline start none → 2019-11-01; baseline finish none → 2019-11-19 |
| 304 | Build Draft Report for public comment | 2019-11-01 A → 2020-01-24 A (+84d) | 2019-11-19 → 2020-01-31 (+73d) | 15d → 6d | 50% → 70% |  | 131, 301 → 131, 301, 34 | baseline start none → 2019-11-01; baseline finish none → 2019-11-19 |
| 305 | Approve Draft Report for public comment | 2019-11-20 → 2020-02-03 (+75d) | 2019-12-03 → 2020-02-07 (+66d) | 10d → 5d |  |  |  | baseline start none → 2019-11-20; baseline finish none → 2019-12-03 |
| 306 | Publish Initial Report | 2019-12-03 → 2020-02-07 (+66d) | 2019-12-03 → 2020-02-07 (+66d) |  |  | 140d → 209d |  | baseline start none → 2019-12-03; baseline finish none → 2019-12-03 |
| 307 | Public comment forum on the Initial Report (45 days) | 2019-12-04 → 2020-02-10 (+68d) | 2020-01-21 → 2020-03-23 (+62d) | 35d → 31d |  |  |  | was named Public comment forum on the Initial Report (49 days); baseline start none → 2019-12-04; baseline finish none → 2020-01-21 |
| 308 | **FINAL REPORT** | 2019-11-29 → 2020-02-07 (+70d) | 2020-04-21 → 2020-06-11 (+51d) | 103d → 90d |  | 38d → 32d |  | baseline start none → 2019-11-29; baseline finish none → 2020-04-21 |
| 309 | Review of public comments | 2020-01-22 → 2020-03-24 (+62d) | 2020-02-25 → 2020-04-27 (+62d) |  |  |  |  | baseline start none → 2020-01-22; baseline finish none → 2020-02-25 |
| 310 | Continue deliberations of Priority 1 topics towards a Final Report | 2020-01-22 → 2020-03-24 (+62d) | 2020-03-17 → 2020-05-04 (+48d) | 40d → 30d |  | 145d → 148d |  | baseline start none → 2020-01-22; baseline finish none → 2020-03-17 |
| 311 | Continue deliberations of Priority 2 topics towards a Final Report | 2020-01-22 → 2020-03-24 (+62d) | 2020-03-17 → 2020-05-04 (+48d) | 40d → 30d |  | 145d → 148d |  | baseline start none → 2020-01-22; baseline finish none → 2020-03-17 |
| 312 | On-going review of legal questions / advice and interaction with counsel for Final Report | 2019-11-29 → 2020-02-07 (+70d) | 2020-04-16 → 2020-04-30 (+14d) | 100d → 60d |  | 123d → 150d |  | baseline start none → 2019-11-29; baseline finish none → 2020-04-16 |
| 313 | Build Final Report | 2020-02-26 → 2020-04-28 (+62d) | 2020-03-31 → 2020-05-25 (+55d) | 25d → 20d |  |  |  | baseline start none → 2020-02-26; baseline finish none → 2020-03-31 |
| 314 | Determine consensus levels on interim recommendations | 2020-04-01 → 2020-05-26 (+55d) | 2020-04-14 → 2020-06-11 (+58d) | 10d → 13d |  | 0d → 120d |  | baseline start none → 2020-04-01; baseline finish none → 2020-04-14 |
| 315 | Adopt final recommendations and report | 2020-04-15 → 2020-05-26 (+41d) | 2020-04-21 → 2020-06-11 (+51d) | 5d → 13d |  |  | 314 → 313 | baseline start none → 2020-04-15; baseline finish none → 2020-04-21 |
| 316 | Submission of Final Report to the GNSO Council | 2020-04-21 → 2020-06-11 (+51d) | 2020-04-21 → 2020-06-11 (+51d) |  |  |  |  | baseline start none → 2020-04-21; baseline finish none → 2020-04-21 |
| 317 | **POST EPDP ACTIVITIES** | 2020-04-22 → 2020-06-12 (+51d) | 2020-09-08 → 2020-10-29 (+51d) |  |  |  |  | baseline start none → 2020-04-22; baseline finish none → 2020-09-08 |
| 318 | Approval of Final Report and Recommendations by the GNSO Council | 2020-04-22 → 2020-06-12 (+51d) | 2020-06-16 → 2020-08-06 (+51d) |  |  |  |  | baseline start none → 2020-04-22; baseline finish none → 2020-06-16 |
| 319 | Report to the Board | 2020-06-17 → 2020-08-07 (+51d) | 2020-07-14 → 2020-09-03 (+51d) |  |  |  |  | baseline start none → 2020-06-17; baseline finish none → 2020-07-14 |
| 320 | Publish Recommendations for Public Comment | 2020-06-17 → 2020-08-07 (+51d) | 2020-08-04 → 2020-09-24 (+51d) |  |  |  |  | baseline start none → 2020-06-17; baseline finish none → 2020-08-04 |
| 321 | Inform GAC if Recommendations affect public policy | 2020-06-17 → 2020-08-07 (+51d) | 2020-08-04 → 2020-09-24 (+51d) |  |  |  |  | baseline start none → 2020-06-17; baseline finish none → 2020-08-04 |
| 322 | Board Paper | 2020-08-05 → 2020-09-25 (+51d) | 2020-09-01 → 2020-10-22 (+51d) |  |  |  |  | baseline start none → 2020-08-05; baseline finish none → 2020-09-01 |
| 323 | Board consideration / approval | 2020-09-02 → 2020-10-23 (+51d) | 2020-09-08 → 2020-10-29 (+51d) |  |  |  |  | baseline start none → 2020-09-02; baseline finish none → 2020-09-08 |

## Version 7 (saved 2020-02-07, file EPDP-P2_Project_Plan_20200207_baseline.mpp)

Last finish stays 2020-11-26. Complete tasks 152 → 197.

Changed:

| ID | Task | Start | Finish | Complete | Total float | Other |
| --- | --- | --- | --- | --- | --- | --- |
| 1 | **EPDP - Phase 2 Policy Development** |  |  | 59% → 73% |  |  |
| 2 | **PROJECT MANAGEMENT** |  |  | 72% → 78% |  |  |
| 9 | **Project Management** |  |  | 71% → 76% |  |  |
| 14 | **Leadership Sub team** |  |  | 53% → 65% |  |  |
| 15 | On-going preparation and planning of EPDP-P2 activities |  |  | 53% → 65% |  |  |
| 16 | **Project Cost Support Team Sub team** |  |  | 68% → 74% |  |  |
| 21 | On-going financial and resource approvals of EPDP-P2 activities |  |  | 60% → 67% |  |  |
| 23 | **EPDP DELIBERATIONS** |  |  | 59% → 75% |  |  |
| 34 | **Priority 1 Deliberations** |  | 2020-01-23 A | 73% → 100% | 3d → none |  |
| 45 | **SSAD Model & Building Blocks & Preliminary Recommendations** |  | 2020-01-23 A | 70% → 100% | 3d → none |  |
| 46 | **Safeguards** |  | 2020-01-23 A | 63% → 100% | 3d → none |  |
| 48 | **Understand sub-topics and determine need to deliberate** |  | 2020-01-14 A | 57% → 100% | 0d → none |  |
| 50 | Code of conduct |  | 2020-01-14 A | 3% → 100% |  |  |
| 51 | Terms of use / disclosure agreements |  | 2020-01-14 A | 11% → 100% |  |  |
| 53 | Retention and destruction of data |  | 2020-01-14 A | 50% → 100% |  |  |
| 54 | Service level agreements | 2019-09-12 A | 2020-01-14 A | 0% → 100% |  |  |
| 55 | Transfer of the Data |  | 2020-01-14 A | 11% → 100% |  |  |
| 62 | Deliberate policy issues |  | 2020-01-21 A | 75% → 100% | 5.5d → none |  |
| 63 | Develop draft work product |  | 2020-01-21 A | 75% → 100% | 0d → none |  |
| 65 | Conduct Second Reading + verbal response + adoption or discard |  | 2020-01-23 A | 50% → 100% | 3d → none |  |
| 73 | **Lawful Basis & Balancing Test** |  | 2020-01-17 A | 74% → 100% | 7.5d → none |  |
| 76 | Deliberate policy issues |  | 2020-01-14 A | 50% → 100% | 10d → none |  |
| 77 | Develop draft work product |  | 2020-01-14 A | 70% → 100% | 0d → none |  |
| 79 | Conduct Second Reading + verbal response + adoption or discard |  | 2020-01-17 A | 50% → 100% | 7.5d → none |  |
| 94 | **Automation Analysis + Centralized vs. De-Centralized Models** |  | 2020-01-17 A | 68% → 100% | 7.5d → none |  |
| 97 | Deliberate policy issues |  | 2020-01-14 A | 70% → 100% | 10d → none |  |
| 98 | Determine if automation is consistent with legal requirements/legal basis |  | 2020-01-14 A | 50% → 100% | 10d → none |  |
| 99 | Develop draft work product |  | 2020-01-14 A | 50% → 100% | 0d → none |  |
| 101 | Conduct Second Reading + verbal response + adoption or discard |  | 2020-01-17 A | 50% → 100% | 7.5d → none |  |
| 109 | **Financial sustainability** |  | 2020-01-20 A | 63% → 100% | 6.25d → none |  |
| 112 | Deliberate policy issues |  | 2020-01-14 A | 50% → 100% | 10d → none |  |
| 113 | Develop draft work product |  | 2020-01-14 A | 70% → 100% | 0d → none |  |
| 115 | Conduct Second Reading + verbal response + adoption or discard |  | 2020-01-20 A | 25% → 100% | 6.25d → none |  |
| 116 | **Purpose 2 Rework per Phase 1 and Board Instruction to GNSO Council** |  | 2020-01-21 A | 27% → 100% | 5d → none |  |
| 119 | Deliberate policy issues |  | 2020-01-14 A | 19% → 100% | 10d → none |  |
| 120 | Develop draft work product |  | 2020-01-14 A | 25% → 100% | 5d → none |  |
| 121 | Conduct First Reading + verbal and email response |  | 2019-09-26 A | 50% → 100% | 85d → none |  |
| 122 | Conduct Second Reading + verbal response + adoption or discard | 2020-01-15 A | 2020-01-21 A | 0% → 100% | 2d → none |  |
| 206 | **Unplanned Issues & Tasks** |  |  | 50% → 75% |  |  |
| 207 | **Phase 2 - Financial Costing Estimate - ICANN Org Finance** |  |  | 50% → 75% |  |  |
| 208 | Develop a cost model on proposed SSAD |  |  | 50% → 75% |  |  |
| 209 | **Phase 2 - Strawberry Paper / EDPB Input** |  |  | 50% → 75% |  | was named Phase 2 - Placeholder (Strawberry Paper / EDPB Input) |
| 210 | Await input on TSG/UAM Model from EDPB |  |  | 50% → 75% |  |  |
| 211 | **Legal Sub team** |  | 2020-02-06 A | 86% → 100% | 150d → none |  |
| 214 | On-going review of legal questions / advice and interaction with counsel for Initial Report |  | 2020-02-06 A | 80% → 100% | 150d → none |  |
| 215 | **Key Events** |  |  | 72% → 90% |  |  |
| 250 | **EPDP Team F2F Meeting - Montreal (02-07 Nov 2019)** |  | 2020-01-15 A | 95% → 100% | 226d → none |  |
| 253 | Interact with Meetings Team |  | 2019-12-11 A | 90% → 100% | 251d → none |  |
| 263 | Manage financial invoice, payment confirmation, and tracking (report to PCST) |  | 2020-01-15 A | 95% → 100% | 226d → none |  |
| 264 | Close F2F | 2020-01-15 A | 2020-01-15 A | 0% → 100% | 233d → none |  |
| 265 | **EPDP Team F2F Meeting - Los Angeles (27-30 Jan 2020)** |  |  | 47% → 93% |  |  |
| 268 | Interact with Meetings Team |  | 2020-02-13 A | 45% → 100% | 205d → none |  |
| 271 | Engage hotel and facilities support teams |  | 2020-03-12 A | 35% → 100% | 185d → none |  |
| 272 | Research and schedule events as necessary |  | 2020-01-16 A | 35% → 100% | 225d → none |  |
| 274 | Plan agenda |  | 2020-01-16 A | 50% → 100% | 211d → none |  |
| 275 | Confirm Day 0 work products (see tasks above) | 2020-03-23 A | 2020-03-23 A | 0% → 100% | 185d → none |  |
| 276 | Day 0 preparations | 2020-01-27 A | 2020-01-27 A | 0% → 100% | 212d → none |  |
| 277 | Day 1 sessions | 2020-01-28 A | 2020-01-28 A | 0% → 100% | 212d → none |  |
| 278 | Day 2 sessions | 2020-01-29 A | 2020-01-29 A | 0% → 100% | 212d → none |  |
| 279 | Day 3 sessions | 2020-01-30 A | 2020-01-30 A | 0% → 100% | 212d → none |  |
| 280 | F2F Recon and Sitrep | 2020-01-30 A | 2020-01-30 A | 0% → 100% | 212d → none |  |
| 281 | Communicate outcomes | 2020-01-31 A | 2020-02-13 A | 0% → 100% | 212d → none |  |
| 282 | Manage financial invoice, payment confirmation, and tracking (report to PCST) | 2019-10-01 A |  | 0% → 65% | 182d → 175d |  |
| 284 | **EPDP Team F2F Meeting - Cancun (07-12 Mar 2020)** |  |  | 26% → 48% |  |  |
| 287 | Interact with Meetings Team |  | 2020-02-21 A | 50% → 100% | 199d → none |  |
| 290 | Plan agenda |  | 2020-01-03 A | 20% → 100% | 221d → none |  |
| 291 | Confirm Day 0 work products (see tasks above) | 2019-11-08 A | 2019-11-08 A | 0% → 100% | 274d → none |  |
| 299 | **INITIAL REPORT** |  |  | 82% → 87% | 178d → 0d |  |
| 302 | Discuss/approve findings and interim recommendations |  | 2020-01-31 A | 50% → 100% | 0d → none |  |
| 303 | Consolidate interim recommendations and findings |  | 2020-01-31 A | 80% → 100% | 0d → none |  |

| ID | Task | Start | Finish | Complete | Total float |
| --- | --- | --- | --- | --- | --- |
| 304 | Build Draft Report for public comment |  | 2020-01-31 A | 70% → 100% | 0d → none |
| 305 | Approve Draft Report for public comment | 2020-02-03 A | 2020-02-07 A | 0% → 100% | 0d → none |
| 306 | Publish Initial Report | 2020-02-07 A | 2020-02-07 A | 0% → 100% | 209d → none |

## Version 8 (saved 2020-03-02, file EPDP-P2_Project_Plan_20200229_baseline.mpp)

Last finish stays 2020-11-26. Complete tasks 197 → 211.

Added:

| ID | Task | Duration | Start | Finish | Predecessors |
| --- | --- | --- | --- | --- | --- |
| 299 | **EPDP Team Leaders F2F Meeting - TBD (May 2020)** | 155d | 2020-02-17 | 2020-09-18 |  |
| 300 | Determine requirements and scope | 1d | 2020-02-17 | 2020-02-17 | 322, 321 |
| 301 | Obtain PCST approval | 5d | 2020-02-17 | 2020-02-21 | 322, 321 |
| 302 | Interact with Meetings Team | 75d | 2020-02-24 | 2020-06-05 | 301 |
| 303 | Engage EPDP team to confirm RSVPs and manage applications for travel support | 30d | 2020-02-24 | 2020-04-03 | 301 |
| 304 | Engage facilitators | 0d | 2020-02-21 | 2020-02-21 | 301 |
| 305 | Plan agenda | 40d | 2020-02-24 | 2020-04-17 | 301 |
| 306 | Confirm Day 0 work products (see tasks above) | 0d | 2020-02-21 | 2020-02-21 | 301, 131 |
| 307 | Day 0 preparations | 1d | 2020-04-20 | 2020-04-20 | 305 |
| 308 | Day 1 sessions | 1d | 2020-04-21 | 2020-04-21 | 307 |
| 309 | Day 2 sessions | 1d | 2020-04-22 | 2020-04-22 | 308 |
| 310 | F2F Recon and Sitrep | 0d | 2020-04-22 | 2020-04-22 | 309 |
| 311 | Communicate outcomes | 10d | 2020-04-23 | 2020-05-06 | 310 |
| 312 | Manage financial invoice, payment confirmation, and tracking (report to PCST) | 150d | 2020-02-24 | 2020-09-18 | 301 |
| 313 | Close F2F | 0d | 2020-09-18 | 2020-09-18 | 312 |
| 322 | Communicate Initial Report | 5d | 2020-02-07 A | 2020-02-14 A | 214, 321 |

Changed:

| ID | Task | Start | Finish | Duration | Complete | Total float | Other |
| --- | --- | --- | --- | --- | --- | --- | --- |
| 1 | **EPDP - Phase 2 Policy Development** |  |  |  | 73% → 81% |  |  |
| 2 | **PROJECT MANAGEMENT** |  |  |  | 78% → 80% |  |  |
| 9 | **Project Management** |  |  |  | 76% → 79% |  |  |
| 14 | **Leadership Sub team** |  |  |  | 65% → 71% |  |  |
| 15 | On-going preparation and planning of EPDP-P2 activities |  |  |  | 65% → 71% |  |  |
| 16 | **Project Cost Support Team Sub team** |  |  |  | 74% → 75% |  |  |
| 21 | On-going financial and resource approvals of EPDP-P2 activities |  |  |  | 67% → 69% |  |  |
| 23 | **EPDP DELIBERATIONS** |  | 2020-06-05 → 2020-09-18 (+105d) | 310d → 385d | 75% → 84% | 124d → 49d |  |
| 29 | **Input from other SO/ACs & GNSO SG/Cs** |  | 2019-11-22 A |  | 44% → 100% | 264d → none |  |
| 33 | Group to review input and determine relevance to policy deliberations on issues within scope |  | 2019-11-22 A |  | 25% → 100% | 264d → none |  |
| 34 | **Priority 1 Deliberations** |  | 2020-01-23 A → 2020-01-23 |  | 100% → 98% | none → 220d |  |
| 45 | **SSAD Model & Building Blocks & Preliminary Recommendations** |  | 2020-01-23 A → 2020-01-23 |  | 100% → 98% | none → 220d |  |
| 109 | **Financial sustainability** |  | 2020-01-20 A → 2020-01-20 |  | 100% → 74% | none → 223.25d |  |
| 113 | Develop draft work product |  | 2020-01-14 A → 2020-01-14 |  | 100% → 50% | none → 1.25d |  |
| 114 | Conduct First Reading + verbal and email response |  | 2019-09-26 A → 2019-09-26 |  | 100% → 50% | none → 81.25d |  |
| 115 | Conduct Second Reading + verbal response + adoption or discard |  | 2020-01-20 A → 2020-01-20 |  | 100% → 50% | none → 223.25d |  |
| 116 | **Purpose 2 Rework per Phase 1 and Board Instruction to GNSO Council** |  | 2020-01-21 A → 2020-01-21 |  | 100% → 98% | none → 222d |  |
| 122 | Conduct Second Reading + verbal response + adoption or discard | 2020-01-15 A → 2020-01-15 | 2020-01-21 A → 2020-01-21 |  | 100% → 0% | none → 222d |  |
| 132 | **Priority 2 Deliberations (Issues carried from Phase 1)** |  |  |  | 31% → 70% |  |  |
| 134 | **Display of information of affiliated vs. accredited privacy / proxy providers** |  |  |  | 20% → 80% |  |  |
| 136 | **Understand topic and determine need to deliberate** |  | 2019-11-06 A |  | 27% → 100% | 146d → none |  |
| 137 | PPSAI IRT briefing to determine how their work compliments or depends on EPDP |  | 2019-11-06 A |  | 20% → 100% | 146d → none |  |
| 138 | Determine if briefing regarding a data privacy impact assessment on the PPSAI program is required |  | 2019-11-06 A |  | 10% → 100% | 146d → none |  |
| 139 | Determine if answers to legal questions are required |  | 2019-11-06 A |  | 50% → 100% | 146d → none |  |
| 140 | Deliberate policy considerations and determine approach | 2019-11-07 A | 2019-11-13 A |  | 0% → 100% | 146d → none |  |
| 141 | Deliberate policy issues | 2019-11-14 A |  |  | 0% → 25% | 146d → 2.5d |  |
| 142 | Develop draft work product | 2020-04-09 A |  |  | 0% → 25% | 146d → 1.25d |  |
| 143 | Conduct First Reading + verbal and email response | 2020-04-23 A |  |  | 0% → 25% |  |  |
| 145 | **Legal vs. Natural** |  |  |  | 39% → 77% |  |  |
| 147 | **Understand topic and determine need to deliberate** |  | 2019-11-06 A |  | 50% → 100% | 146d → none |  |
| 148 | Receive briefing from Bird & Bird on legal vs. natural memo | 2019-06-10 A | 2019-11-06 A |  | 0% → 100% | 146d → none |  |
| 151 | EPDP Team or Sub-team to work with ICANN org on this study, including providing questions and/or relevant background to assist in informing the study by 1 July 2019. | 2019-06-10 A | 2019-11-06 A |  | 0% → 100% | 146d → none |  |
| 157 | **City Field** |  |  |  | 30% → 70% |  |  |
| 159 | **Understand topic and determine need to deliberate** |  | 2019-11-14 A |  | 48% → 100% | 140d → none |  |
| 160 | Receive briefing from Bird & Bird on city field memo |  | 2019-11-14 A |  | 10% → 100% | 140d → none |  |
| 162 | Deliberate policy considerations and determine approach | 2019-11-15 A | 2019-11-21 A |  | 0% → 100% | 140d → none |  |
| 163 | Deliberate policy issues | 2019-11-22 A |  |  | 0% → 25% | 140d → 2.5d |  |
| 164 | Develop draft work product | 2020-04-17 A |  |  | 0% → 25% |  |  |
| 167 | **Data Retention** |  |  |  | 36% → 99% |  |  |
| 169 | **Understand topic and determine need to deliberate** |  | 2019-11-14 A |  | 75% → 100% | 140d → none |  |
| 170 | Confirm with ICANN org when the review of all of ICANN org's processes and procedures to identify and document the instances in which personal data is requested beyond the life of domain name registration is expected to be completed. |  | 2019-11-14 A |  | 75% → 100% | 140d → none |  |
| 171 | Deliberate policy considerations and determine approach | 2019-11-15 A | 2019-11-21 A |  | 0% → 100% | 140d → none |  |
| 172 | **Deliberate policy issues** | 2019-11-22 A | 2020-04-16 A |  | 0% → 100% | 140d → none |  |
| 173 | Confirm whether the data retention requirements recommended in phase 1 are to be confirmed or whether updates are needed | 2019-11-22 A | 2020-04-16 A |  | 0% → 100% | 140d → none |  |
| 174 | Develop draft work product | 2020-04-17 A | 2020-04-30 A |  | 0% → 100% | 140d → none |  |
| 175 | Conduct First Reading + verbal and email response | 2020-05-01 A | 2020-05-07 A |  | 0% → 100% | 140d → none |  |
| 176 | Conduct Second Reading + verbal response + adoption or discard | 2020-05-08 A |  |  | 0% → 75% |  |  |
| 177 | **Additional purpose for ICANN’s OCTO** |  |  |  | 31% → 68% |  |  |
| 179 | **Understand topic and determine need to deliberate** |  | 2019-11-06 A |  | 50% → 100% | 146d → none |  |
| 181 | Determine if answers to legal questions are required | 2019-06-24 A | 2019-11-06 A |  | 0% → 100% | 146d → none |  |
| 183 | Deliberate policy issues | 2019-11-14 A |  |  | 0% → 20% | 146d → 2d |  |
| 184 | Develop draft work product | 2020-04-09 A |  |  | 0% → 20% |  |  |
| 187 | **Feasibility of unique contacts to have uniform anonymized email address** |  |  |  | 30% → 55% |  |  |
| 189 | **Understand topic and determine need to deliberate** |  | 2019-10-25 A |  | 75% → 100% | 141d → none |  |
| 190 | Determine if answers to legal questions are required |  | 2019-10-25 A |  | 75% → 100% | 141d → none |  |
| 191 | Deliberate policy considerations and determine approach | 2019-10-28 A | 2019-11-01 A |  | 0% → 100% | 141d → none |  |
| 192 | Deliberate policy issues | 2019-11-02 A |  |  | 0% → 25% | 141d → 2.5d |  |
| 193 | Develop draft work product | 2020-04-16 A |  |  | 0% → 25% |  |  |
| 199 | Receive briefing from Bird & Bird on city field memo | 2019-07-16 A | 2019-11-14 A |  | 0% → 100% | 140d → none |  |
| 200 | Determine if answers to legal questions are required | 2019-07-16 A → 2019-07-16 | 2019-11-14 A → 2019-11-14 |  | 100% → 0% | none → 140d |  |
| 215 | **Key Events** |  | 2020-06-05 → 2020-09-18 (+105d) | 310d → 385d | 90% → 78% | 124d → 49d |  |
| 284 | **EPDP Team F2F Meeting - Remote (07-12 Mar 2020)** |  |  |  |  |  | was named EPDP Team F2F Meeting - Cancun (07-12 Mar 2020) |
| 314 | **INITIAL REPORT** |  |  |  | 87% → 90% |  |  |
| 323 | Public comment forum on the Initial Report (45 days) | 2020-02-10 A |  |  | 0% → 25% |  |  |

## Version 9 (saved 2020-03-30, file EPDP-P2_Project_Plan_20200331_baseline.mpp)

Last finish stays 2020-11-26. Complete tasks 211 → 246.

Added:

| ID | Task | Duration | Start | Finish | Predecessors |
| --- | --- | --- | --- | --- | --- |
| 314 | **Initial Report Addendum** | 63d | 2020-02-10 A | 2020-05-06 |  |
| 315 | Assemble initial conclusions | 28d | 2020-02-10 A | 2020-03-18 A | 311 |
| 316 | Populate draft addendum with findings and preliminary recommendations | 28d | 2020-02-10 A | 2020-03-18 A | 311 |
| 317 | Discuss/approve findings and interim recommendations | 28d | 2020-02-10 A | 2020-03-18 A | 311 |
| 318 | Publish Initial Report Addendum | 4d | 2020-03-19 A | 2020-03-24 A | 317 |
| 319 | Public comment forum on the Initial Report Addendum (40 days) | 30d | 2020-03-26 | 2020-05-06 | 318 |

Removed: 303 Engage EPDP team to confirm RSVPs and manage applications for travel support; 304 Engage facilitators; 305 Plan agenda; 306 Confirm Day 0 work products (see tasks above); 307 Day 0 preparations; 308 Day 1 sessions; 309 Day 2 sessions; 310 F2F Recon and Sitrep; 311 Communicate outcomes; 312 Manage financial invoice, payment confirmation, and tracking (report to PCST)

Changed:

| ID | Task | Start | Finish | Duration | Complete | Total float | Predecessors | Other |
| --- | --- | --- | --- | --- | --- | --- | --- | --- |
| 1 | **EPDP - Phase 2 Policy Development** |  |  |  | 81% → 92% |  |  |  |
| 2 | **PROJECT MANAGEMENT** |  |  |  | 80% → 84% |  |  |  |
| 9 | **Project Management** |  |  |  | 79% → 83% |  |  |  |
| 14 | **Leadership Sub team** |  |  |  | 71% → 79% |  |  |  |
| 15 | On-going preparation and planning of EPDP-P2 activities |  |  |  | 71% → 79% |  |  |  |
| 16 | **Project Cost Support Team Sub team** |  |  |  | 75% → 80% |  |  |  |
| 21 | On-going financial and resource approvals of EPDP-P2 activities |  |  |  | 69% → 75% |  |  |  |
| 23 | **EPDP DELIBERATIONS** | 2019-04-03 A → 2019-03-04 A (-30d) | 2020-09-18 → 2020-06-05 (-105d) | 385d → 332d | 84% → 98% | 49d → 124d |  |  |
| 34 | **Priority 1 Deliberations** |  | 2020-01-23 A |  | 98% → 100% | 220d → none |  |  |
| 45 | **SSAD Model & Building Blocks & Preliminary Recommendations** |  | 2020-01-23 A |  | 98% → 100% | 220d → none |  |  |
| 109 | **Financial sustainability** |  | 2020-01-20 A |  | 74% → 100% | 223.25d → none |  |  |
| 113 | Develop draft work product |  | 2020-01-14 A |  | 50% → 100% | 1.25d → none |  |  |
| 114 | Conduct First Reading + verbal and email response |  | 2019-09-26 A |  | 50% → 100% | 81.25d → none |  |  |
| 115 | Conduct Second Reading + verbal response + adoption or discard |  | 2020-01-20 A |  | 50% → 100% | 223.25d → none |  |  |
| 116 | **Purpose 2 Rework per Phase 1 and Board Instruction to GNSO Council** |  | 2020-01-21 A |  | 98% → 100% | 222d → none |  |  |
| 122 | Conduct Second Reading + verbal response + adoption or discard | 2020-01-15 A | 2020-01-21 A |  | 0% → 100% | 222d → none |  |  |
| 132 | **Priority 2 Deliberations (Issues carried from Phase 1)** |  |  |  | 70% → 95% |  |  |  |
| 134 | **Display of information of affiliated vs. accredited privacy / proxy providers** |  |  |  | 80% → 98% |  |  |  |
| 141 | Deliberate policy issues |  | 2020-04-08 A |  | 25% → 100% | 2.5d → none |  |  |
| 142 | Develop draft work product |  | 2020-04-22 A |  | 25% → 100% | 1.25d → none |  |  |
| 143 | Conduct First Reading + verbal and email response | 2020-04-23 A → 2020-04-23 |  |  | 25% → 0% |  |  |  |
| 145 | **Legal vs. Natural** |  |  |  | 77% → 87% |  |  |  |
| 152 | Deliberate policy considerations and determine approach | 2019-11-07 A |  |  | 0% → 50% | 146d → 52.5d |  |  |
| 153 | Deliberate policy issues | 2019-11-14 A |  |  | 0% → 50% |  |  |  |
| 157 | **City Field** |  |  |  | 70% → 97% |  |  |  |
| 163 | Deliberate policy issues |  | 2020-04-16 A |  | 25% → 100% | 2.5d → none |  |  |
| 164 | Develop draft work product |  | 2020-04-30 A |  | 25% → 100% | 140d → none |  |  |
| 167 | **Data Retention** |  |  |  | 99% → 96% |  |  |  |
| 175 | Conduct First Reading + verbal and email response | 2020-05-01 A → 2020-05-01 | 2020-05-07 A → 2020-05-07 |  | 100% → 0% | none → 140d |  |  |
| 176 | Conduct Second Reading + verbal response + adoption or discard | 2020-05-08 A → 2020-05-08 |  |  | 75% → 0% |  |  |  |
| 177 | **Additional purpose for ICANN’s OCTO** |  |  |  | 68% → 97% |  |  |  |
| 182 | Deliberate policy considerations and determine approach | 2019-11-07 A | 2019-11-13 A |  | 0% → 100% | 21d → none |  |  |
| 183 | Deliberate policy issues |  | 2020-04-08 A |  | 20% → 100% | 2d → none |  |  |
| 184 | Develop draft work product |  | 2020-04-22 A |  | 20% → 100% | 146d → none |  |  |
| 187 | **Feasibility of unique contacts to have uniform anonymized email address** |  |  |  | 55% → 96% |  |  |  |
| 192 | Deliberate policy issues |  | 2020-04-15 A |  | 25% → 100% | 2.5d → none |  |  |
| 193 | Develop draft work product |  | 2020-04-29 A |  | 25% → 100% | 141d → none |  |  |
| 196 | **Data Accuracy and the WHOIS Accuracy Reporting System [Removed from Phase 2 Scope]** |  | 2020-05-14 A |  | 30% → 100% | 140d → none |  | was named Data Accuracy and the WHOIS Accuracy Reporting System |
| 198 | **Understand topic and determine need to deliberate** |  | 2019-11-14 A |  | 50% → 100% | 140d → none |  |  |
| 200 | Determine if answers to legal questions are required | 2019-07-16 A | 2019-11-14 A |  | 0% → 100% | 140d → none |  |  |
| 201 | Deliberate policy considerations and determine approach | 2019-11-15 A | 2019-11-21 A |  | 0% → 100% | 140d → none |  |  |
| 202 | Deliberate policy issues | 2019-11-22 A | 2020-04-16 A |  | 0% → 100% | 140d → none |  |  |
| 203 | Develop draft work product | 2020-04-17 A | 2020-04-30 A |  | 0% → 100% | 140d → none |  |  |
| 204 | Conduct First Reading + verbal and email response | 2020-05-01 A | 2020-05-07 A |  | 0% → 100% | 140d → none |  |  |
| 205 | Conduct Second Reading + verbal response + adoption or discard | 2020-05-08 A | 2020-05-14 A |  | 0% → 100% | 140d → none |  |  |
| 206 | **Unplanned Issues & Tasks** |  |  |  | 75% → 90% |  |  |  |
| 209 | **Phase 2 - Strawberry Paper / EDPB Input** |  | 2020-03-04 A |  | 75% → 100% | 191d → none |  |  |
| 210 | Await input on TSG/UAM Model from EDPB |  | 2020-03-04 A |  | 75% → 100% | 191d → none |  |  |
| 215 | **Key Events** | 2019-04-03 A → 2019-03-04 A (-30d) | 2020-09-18 → 2020-06-05 (-105d) | 385d → 332d | 78% → 97% | 49d → 124d |  |  |
| 265 | **EPDP Team F2F Meeting - Los Angeles (27-30 Jan 2020)** |  |  |  | 93% → 90% |  |  |  |
| 282 | Manage financial invoice, payment confirmation, and tracking (report to PCST) |  |  |  | 65% → 50% |  |  |  |
| 284 | **EPDP Team F2F Meeting - Remote (07-12 Mar 2020)** |  | 2020-06-05 A |  | 48% → 100% | 124d → none |  |  |
| 292 | Day 0 preparations | 2020-03-06 A | 2020-03-06 A |  | 0% → 100% | 177d → none |  |  |
| 293 | Day 1 sessions | 2020-03-09 A | 2020-03-09 A |  | 0% → 100% | 177d → none |  |  |
| 294 | Day 2 sessions | 2020-03-10 A | 2020-03-10 A |  | 0% → 100% | 177d → none |  |  |
| 295 | F2F Recon and Sitrep | 2020-03-10 A | 2020-03-10 A |  | 0% → 100% | 177d → none |  |  |
| 296 | Communicate outcomes | 2020-03-11 A | 2020-03-24 A |  | 0% → 100% | 177d → none |  |  |
| 297 | Manage financial invoice, payment confirmation, and tracking (report to PCST) | 2019-11-11 A | 2020-06-05 A |  | 0% → 100% | 124d → none |  |  |
| 298 | Close F2F | 2020-06-05 A | 2020-06-05 A |  | 0% → 100% | 124d → none |  |  |
| 299 | **EPDP Team Leaders F2F Meeting [Travel Restricted & no longer planned]** | 2020-02-17 → 2019-03-04 A (-350d) | 2020-09-18 → 2020-06-05 A (-105d) | 155d → 332d | 0% → 100% | 49d → none |  | was named EPDP Team Leaders F2F Meeting - TBD (May 2020) |
| 300 | Determine requirements and scope | 2020-02-17 A | 2020-02-17 A |  | 0% → 100% | 203d → none |  |  |
| 301 | Obtain PCST approval | 2020-02-17 A | 2020-02-21 A |  | 0% → 100% | 49d → none |  |  |
| 302 | Interact with Meetings Team | 2020-02-24 A | 2020-06-05 A |  | 0% → 100% | 124d → none |  |  |
| 303 | Close F2F | 2020-09-18 → 2019-03-04 A (-564d) | 2020-09-18 → 2019-03-04 A (-564d) |  | 0% → 100% | 49d → none | Manage financial invoice, payment confirmation, and tracking (report to PCST) → none |  |
| 304 | **INITIAL REPORT** |  | 2020-03-23 → 2020-05-06 (+44d) | 194d → 226d | 90% → 92% |  |  |  |
| 313 | Public comment forum on the Initial Report (45 days) |  | 2020-03-23 A |  | 25% → 100% | 0d → none |  |  |
| 321 | Review of public comments |  | 2020-04-27 → 2020-05-18 (+21d) | 25d → 40d |  |  |  |  |
| 322 | Continue deliberations of Priority 1 topics towards a Final Report |  | 2020-05-04 → 2020-05-18 (+14d) | 30d → 40d |  | 148d → 138d |  |  |
| 323 | Continue deliberations of Priority 2 topics towards a Final Report |  | 2020-05-04 → 2020-05-18 (+14d) | 30d → 40d |  | 148d → 138d |  |  |
| 324 | On-going review of legal questions / advice and interaction with counsel for Final Report |  | 2020-04-30 → 2020-05-18 (+18d) | 60d → 72d |  | 150d → 138d |  |  |

| ID | Task | Start | Duration | Other |
| --- | --- | --- | --- | --- |
| 325 | Build Final Report & Final Deliberations | 2020-04-28 → 2020-05-19 (+21d) | 20d → 5d | was named Build Final Report |

## Version 10 (saved 2020-05-03, file EPDP-P2_Project_Plan_20200430_baseline.mpp)

Last finish stays 2020-11-26.

Changed:

| ID | Task | Start | Complete | Total float |
| --- | --- | --- | --- | --- |
| 1 | **EPDP - Phase 2 Policy Development** |  | 92% → 94% |  |
| 2 | **PROJECT MANAGEMENT** |  | 84% → 88% |  |
| 9 | **Project Management** |  | 83% → 87% |  |
| 14 | **Leadership Sub team** |  | 79% → 86% |  |
| 15 | On-going preparation and planning of EPDP-P2 activities |  | 79% → 86% |  |
| 16 | **Project Cost Support Team Sub team** |  | 80% → 85% |  |
| 21 | On-going financial and resource approvals of EPDP-P2 activities |  | 75% → 81% |  |
| 215 | **Key Events** |  | 97% → 99% |  |
| 265 | **EPDP Team F2F Meeting - Los Angeles (27-30 Jan 2020)** |  | 90% → 96% |  |
| 282 | Manage financial invoice, payment confirmation, and tracking (report to PCST) |  | 50% → 80% |  |
| 304 | **INITIAL REPORT** |  | 92% → 97% |  |
| 314 | **Initial Report Addendum** |  | 75% → 91% |  |
| 319 | Public comment forum on the Initial Report Addendum (40 days) | 2020-03-26 A | 0% → 65% |  |
| 320 | **FINAL REPORT** | 2020-02-07 A | 0% → 17% | 32d → 120d |
| 321 | Review of public comments | 2020-03-24 A | 0% → 20% | 0d → 0.5d |
| 322 | Continue deliberations of Priority 1 topics towards a Final Report | 2020-03-24 A | 0% → 20% |  |
| 323 | Continue deliberations of Priority 2 topics towards a Final Report | 2020-03-24 A | 0% → 20% |  |
| 324 | On-going review of legal questions / advice and interaction with counsel for Final Report | 2020-02-07 A | 0% → 20% |  |
| 325 | Build Final Report & Final Deliberations | 2020-05-19 A | 0% → 10% |  |

## Version 11 (saved 2020-05-28, file EPDP-P2_Project_Plan_20200531_baseline.mpp)

Last finish stays 2020-11-26. Complete tasks 246 → 252.

Changed:

| ID | Task | Start | Finish | Complete | Total float |
| --- | --- | --- | --- | --- | --- |
| 1 | **EPDP - Phase 2 Policy Development** |  |  | 94% → 96% |  |
| 2 | **PROJECT MANAGEMENT** |  |  | 88% → 92% |  |
| 9 | **Project Management** |  |  | 87% → 92% |  |
| 14 | **Leadership Sub team** |  |  | 86% → 93% |  |
| 15 | On-going preparation and planning of EPDP-P2 activities |  |  | 86% → 93% |  |
| 16 | **Project Cost Support Team Sub team** |  |  | 85% → 90% |  |
| 21 | On-going financial and resource approvals of EPDP-P2 activities |  |  | 81% → 88% |  |
| 23 | **EPDP DELIBERATIONS** |  |  | 98% → 99% |  |
| 132 | **Priority 2 Deliberations (Issues carried from Phase 1)** |  |  | 95% → 99% |  |
| 134 | **Display of information of affiliated vs. accredited privacy / proxy providers** |  |  | 98% → 99% |  |
| 143 | Conduct First Reading + verbal and email response | 2020-04-23 A |  | 0% → 50% | 146d → 2.5d |
| 144 | Conduct Second Reading + verbal response + adoption or discard | 2020-04-30 A |  | 0% → 50% |  |
| 145 | **Legal vs. Natural** |  |  | 87% → 99% |  |
| 152 | Deliberate policy considerations and determine approach |  | 2019-11-13 A | 50% → 100% | 52.5d → none |
| 153 | Deliberate policy issues |  | 2020-04-08 A | 50% → 100% | 146d → none |
| 154 | Develop draft work product | 2020-04-09 A | 2020-04-22 A | 0% → 100% | 146d → none |
| 155 | Conduct First Reading + verbal and email response | 2020-04-23 A |  | 0% → 50% | 146d → 2.5d |
| 156 | Conduct Second Reading + verbal response + adoption or discard | 2020-04-30 A |  | 0% → 50% |  |
| 157 | **City Field** |  |  | 97% → 98% |  |
| 165 | Conduct First Reading + verbal and email response | 2020-05-01 A |  | 0% → 50% | 140d → 2.5d |
| 166 | Conduct Second Reading + verbal response + adoption or discard | 2020-05-08 A |  | 0% → 50% |  |
| 167 | **Data Retention** |  |  | 96% → 98% |  |
| 175 | Conduct First Reading + verbal and email response | 2020-05-01 A |  | 0% → 50% | 140d → 2.5d |
| 176 | Conduct Second Reading + verbal response + adoption or discard | 2020-05-08 A |  | 0% → 50% |  |
| 177 | **Additional purpose for ICANN’s OCTO** |  |  | 97% → 99% |  |
| 185 | Conduct First Reading + verbal and email response | 2020-04-23 A |  | 0% → 50% | 146d → 2.5d |
| 186 | Conduct Second Reading + verbal response + adoption or discard | 2020-04-30 A |  | 0% → 50% |  |
| 187 | **Feasibility of unique contacts to have uniform anonymized email address** |  |  | 96% → 98% |  |
| 194 | Conduct First Reading + verbal and email response | 2020-04-30 A |  | 0% → 50% | 141d → 2.5d |
| 195 | Conduct Second Reading + verbal response + adoption or discard | 2020-05-07 A |  | 0% → 50% |  |
| 206 | **Unplanned Issues & Tasks** |  | 2020-03-04 A | 90% → 100% | 191d → none |
| 207 | **Phase 2 - Financial Costing Estimate - ICANN Org Finance** |  | 2020-02-14 A | 75% → 100% | 204d → none |
| 208 | Develop a cost model on proposed SSAD |  | 2020-02-14 A | 75% → 100% | 204d → none |
| 304 | **INITIAL REPORT** |  | 2020-05-06 A | 97% → 100% | 0d → none |
| 314 | **Initial Report Addendum** |  | 2020-05-06 A | 91% → 100% | 0d → none |
| 319 | Public comment forum on the Initial Report Addendum (40 days) |  | 2020-05-06 A | 65% → 100% |  |
| 320 | **FINAL REPORT** |  |  | 17% → 60% |  |
| 321 | Review of public comments |  |  | 20% → 85% | 0.5d → 1.25d |
| 322 | Continue deliberations of Priority 1 topics towards a Final Report |  |  | 20% → 45% |  |
| 324 | On-going review of legal questions / advice and interaction with counsel for Final Report |  | 2020-05-18 A | 20% → 100% | 138d → none |
| 325 | Build Final Report & Final Deliberations |  |  | 10% → 25% |  |

## Version 12 (saved 2020-06-29, file EPDP-P2_Project_Plan_20200630_baseline2.mpp)

Last finish 2020-11-26 → 2021-01-13 (+48d). Complete tasks 252 → 259.

Changed:

| ID | Task | Start | Finish | Duration | Complete | Total float | Other |
| --- | --- | --- | --- | --- | --- | --- | --- |
| 1 | **EPDP - Phase 2 Policy Development** |  | 2020-11-26 → 2021-01-13 (+48d) | 456d → 489.75d | 96% → 95% |  |  |
| 2 | **PROJECT MANAGEMENT** |  | 2020-11-26 → 2021-01-13 (+48d) | 456d → 489.75d |  |  |  |
| 9 | **Project Management** |  | 2020-11-26 → 2021-01-13 (+48d) | 454d → 487.75d |  |  |  |
| 14 | **Leadership Sub team** |  | 2020-06-18 → 2020-07-29 (+41d) | 310d → 339d | 93% → 90% | 95d → 99.75d |  |
| 15 | On-going preparation and planning of EPDP-P2 activities |  | 2020-06-18 → 2020-07-29 (+41d) | 310d → 339d | 93% → 90% | 95d → 99.75d |  |
| 16 | **Project Cost Support Team Sub team** |  | 2020-07-17 → 2020-08-14 (+28d) | 360d → 380d | 90% → 92% | 74d → 87.75d |  |
| 21 | On-going financial and resource approvals of EPDP-P2 activities |  | 2020-07-17 → 2020-08-14 (+28d) | 360d → 380d | 88% → 90% | 74d → 87.75d |  |
| 22 | Close project plan, Factsheet, and transition project to IPT | 2020-10-30 → 2020-12-16 (+47d) | 2020-11-26 → 2021-01-13 (+48d) |  |  |  |  |
| 23 | **EPDP DELIBERATIONS** |  | 2020-06-05 → 2020-07-29 (+54d) | 332d → 370d | 99% → 97% | 124d → 119.75d |  |
| 132 | **Priority 2 Deliberations (Issues carried from Phase 1)** |  | 2020-05-14 → 2020-07-29 (+76d) | 252d → 305.5d | 99% → 95% | 140d → 120.25d |  |
| 134 | **Display of information of affiliated vs. accredited privacy / proxy providers** |  | 2020-05-06 → 2020-07-29 (+84d) | 245d → 304.5d | 99% → 94% | 146d → 120.25d |  |
| 143 | Conduct First Reading + verbal and email response |  | 2020-04-29 → 2020-06-17 A (+49d) | 5d → 40d | 50% → 100% | 2.5d → none |  |
| 144 | Conduct Second Reading + verbal response + adoption or discard |  | 2020-05-06 → 2020-07-29 (+84d) | 5d → 32d | 50% → 8% | 146d → 120.25d |  |
| 145 | **Legal vs. Natural [Deferred from Phase 2 SSAD Scope]** |  | 2020-05-06 → 2020-06-08 A (+33d) | 245d → 267.5d | 99% → 100% | 146d → none | was named Legal vs. Natural |
| 155 | Conduct First Reading + verbal and email response |  | 2020-04-29 → 2020-06-03 A (+35d) | 5d → 30d | 50% → 100% | 2.5d → none |  |
| 156 | Conduct Second Reading + verbal response + adoption or discard |  | 2020-05-06 → 2020-06-08 A (+33d) |  | 50% → 100% | 146d → none |  |
| 157 | **City Field** |  | 2020-05-14 → 2020-07-29 (+76d) | 245d → 298.5d | 98% → 94% | 140d → 120.25d |  |
| 165 | Conduct First Reading + verbal and email response |  | 2020-05-07 → 2020-06-25 A (+49d) | 5d → 40d | 50% → 100% | 2.5d → none |  |
| 166 | Conduct Second Reading + verbal response + adoption or discard |  | 2020-05-14 → 2020-07-29 (+76d) | 5d → 26d | 50% → 10% | 140d → 120.25d |  |
| 167 | **Data Retention** |  | 2020-05-14 → 2020-07-29 (+76d) | 245d → 298.5d | 98% → 92% | 140d → 120.25d |  |
| 175 | Conduct First Reading + verbal and email response |  | 2020-05-07 → 2020-06-25 A (+49d) | 5d → 40d | 50% → 100% | 2.5d → none |  |
| 176 | Conduct Second Reading + verbal response + adoption or discard |  | 2020-05-14 → 2020-07-29 (+76d) | 5d → 26d | 50% → 10% | 140d → 120.25d |  |
| 177 | **Additional purpose for ICANN’s OCTO** |  | 2020-05-06 → 2020-07-29 (+84d) | 235d → 294.5d | 99% → 93% | 146d → 120.25d |  |
| 185 | Conduct First Reading + verbal and email response |  | 2020-04-29 → 2020-06-17 A (+49d) | 5d → 40d | 50% → 100% | 2.5d → none |  |
| 186 | Conduct Second Reading + verbal response + adoption or discard |  | 2020-05-06 → 2020-07-29 (+84d) | 5d → 32d | 50% → 8% | 146d → 120.25d |  |
| 187 | **Feasibility of unique contacts to have uniform anonymized email address** |  | 2020-05-13 → 2020-07-29 (+77d) | 240d → 294.5d | 98% → 92% | 141d → 120.25d |  |
| 194 | Conduct First Reading + verbal and email response |  | 2020-05-06 → 2020-06-24 A (+49d) | 5d → 40d | 50% → 100% | 2.5d → none |  |
| 195 | Conduct Second Reading + verbal response + adoption or discard |  | 2020-05-13 → 2020-07-29 (+77d) | 5d → 27d | 50% → 9% | 141d → 120.25d |  |
| 196 | **Data Accuracy and the WHOIS Accuracy Reporting System [Deferred from Phase 2 SSAD Scope]** |  |  |  |  |  | was named Data Accuracy and the WHOIS Accuracy Reporting System [Removed from Phase 2 Scope] |
| 215 | **Key Events** |  | 2020-06-05 → 2020-07-29 (+54d) | 332d → 370d | 99% → 95% | 124d → 119.75d |  |
| 265 | **EPDP Team F2F Meeting - Los Angeles (27-30 Jan 2020)** |  | 2020-03-26 → 2020-07-29 (+125d) | 135d → 224d | 96% → 85% | 175d → 119.75d |  |
| 282 | Manage financial invoice, payment confirmation, and tracking (report to PCST) |  | 2020-03-26 → 2020-07-29 (+125d) | 130d → 219d | 80% → 50% | 175d → 119.75d |  |
| 283 | Close F2F | 2020-03-26 → 2020-07-29 (+125d) | 2020-03-26 → 2020-07-29 (+125d) |  |  | 175d → 119.75d |  |
| 320 | **FINAL REPORT** |  | 2020-06-11 → 2020-07-29 (+48d) | 90d → 123.75d | 60% → 74% |  |  |
| 321 | Review of public comments |  | 2020-05-18 → 2020-07-06 (+49d) | 40d → 75d | 85% → 75% |  |  |
| 322 | Continue deliberations of Priority 1 topics towards a Final Report |  | 2020-05-18 → 2020-07-06 (+49d) | 40d → 75d | 45% → 75% | 138d → 136.75d |  |
| 323 | Continue deliberations of Priority 2 topics towards a Final Report |  | 2020-05-18 → 2020-07-06 (+49d) | 40d → 75d | 20% → 75% | 138d → 136.75d |  |
| 325 | Build Final Report & Final Deliberations |  | 2020-05-25 → 2020-07-10 (+46d) |  | 25% → 50% |  |  |
| 326 | Determine consensus levels on interim recommendations | 2020-05-26 → 2020-07-10 (+45d) | 2020-06-11 → 2020-07-29 (+48d) |  |  |  |  |
| 327 | Adopt final recommendations and report | 2020-05-26 → 2020-07-10 (+45d) | 2020-06-11 → 2020-07-29 (+48d) |  |  |  |  |
| 328 | Submission of Final Report to the GNSO Council | 2020-06-11 → 2020-07-29 (+48d) | 2020-06-11 → 2020-07-29 (+48d) |  |  |  |  |
| 329 | **POST EPDP ACTIVITIES** | 2020-06-12 → 2020-07-29 (+47d) | 2020-10-29 → 2020-12-16 (+48d) |  |  |  |  |
| 330 | Approval of Final Report and Recommendations by the GNSO Council | 2020-06-12 → 2020-07-29 (+47d) | 2020-08-06 → 2020-09-23 (+48d) |  |  |  |  |
| 331 | Report to the Board | 2020-08-07 → 2020-09-23 (+47d) | 2020-09-03 → 2020-10-21 (+48d) |  |  |  |  |
| 332 | Publish Recommendations for Public Comment | 2020-08-07 → 2020-09-23 (+47d) | 2020-09-24 → 2020-11-11 (+48d) |  |  |  |  |
| 333 | Inform GAC if Recommendations affect public policy | 2020-08-07 → 2020-09-23 (+47d) | 2020-09-24 → 2020-11-11 (+48d) |  |  |  |  |
| 334 | Board Paper | 2020-09-25 → 2020-11-11 (+47d) | 2020-10-22 → 2020-12-09 (+48d) |  |  |  |  |
| 335 | Board consideration / approval | 2020-10-23 → 2020-12-09 (+47d) | 2020-10-29 → 2020-12-16 (+48d) |  |  |  |  |

## Version 13 (saved 2020-07-31, file EPDP-P2_Project_Plan_20200731_baseline2.mpp)

Last finish stays 2021-01-13. Complete tasks 259 → 269.

Added:

| ID | Task | Duration | Start | Finish |
| --- | --- | --- | --- | --- |
| 338 | Purple highlights denote Council consideration of next steps on how to address these remaining topics | 1d? | 2020-07-29 | 2020-07-30 |

Changed:

| ID | Task | Start | Finish | Duration | Complete | Total float |
| --- | --- | --- | --- | --- | --- | --- |
| 1 | **EPDP - Phase 2 Policy Development** |  |  |  | 95% → 97% |  |
| 2 | **PROJECT MANAGEMENT** |  |  |  | 92% → 98% |  |
| 9 | **Project Management** |  |  |  | 92% → 98% |  |
| 14 | **Leadership Sub team** |  | 2020-07-29 A |  | 90% → 100% | 99.75d → none |
| 15 | On-going preparation and planning of EPDP-P2 activities |  | 2020-07-29 A |  | 90% → 100% | 99.75d → none |
| 16 | **Project Cost Support Team Sub team** |  | 2020-08-14 → 2020-07-31 A (-14d) | 380d → 370d | 92% → 100% | 87.75d → none |
| 21 | On-going financial and resource approvals of EPDP-P2 activities |  | 2020-08-14 → 2020-07-31 A (-14d) | 380d → 370d | 90% → 100% | 87.75d → none |
| 23 | **EPDP DELIBERATIONS** |  | 2020-07-29 → 2020-07-31 (+2d) | 370d → 372d | 97% → 99% | 119.75d → 117.75d |
| 132 | **Priority 2 Deliberations (Issues carried from Phase 1)** |  | 2020-07-29 → 2020-07-31 (+2d) | 305.5d → 308d | 95% → 96% | 120.25d → 117.75d |
| 134 | **Display of information of affiliated vs. accredited privacy / proxy providers** |  | 2020-07-29 A |  | 94% → 100% | 120.25d → none |
| 144 | Conduct Second Reading + verbal response + adoption or discard |  | 2020-07-29 A |  | 8% → 100% | 120.25d → none |
| 145 | **Legal vs. Natural [Deferred from Phase 2 SSAD Scope]** |  | 2020-06-08 A → 2020-07-31 (+53d) | 267.5d → 306.5d | 100% → 97% | none → 118.25d |
| 156 | Conduct Second Reading + verbal response + adoption or discard | 2020-04-30 A → 2020-06-04 (+35d) | 2020-06-08 A → 2020-07-31 (+53d) | 5d → 19d | 100% → 0% | none → 118.25d |
| 157 | **City Field** |  | 2020-07-29 A |  | 94% → 100% | 120.25d → none |
| 166 | Conduct Second Reading + verbal response + adoption or discard |  | 2020-07-29 A |  | 10% → 100% | 120.25d → none |
| 167 | **Data Retention** |  | 2020-07-29 A |  | 92% → 100% | 120.25d → none |
| 176 | Conduct Second Reading + verbal response + adoption or discard |  | 2020-07-29 A |  | 10% → 100% | 120.25d → none |
| 177 | **Additional purpose for ICANN’s OCTO** |  | 2020-07-29 A |  | 93% → 100% | 120.25d → none |
| 186 | Conduct Second Reading + verbal response + adoption or discard |  | 2020-07-29 A |  | 8% → 100% | 120.25d → none |
| 187 | **Feasibility of unique contacts to have uniform anonymized email address** |  | 2020-07-29 → 2020-07-31 (+2d) | 294.5d → 297d | 92% → 91% | 120.25d → 117.75d |
| 195 | Conduct Second Reading + verbal response + adoption or discard | 2020-05-07 A → 2020-06-25 (+49d) | 2020-07-29 → 2020-07-31 (+2d) |  | 9% → 0% | 120.25d → 117.75d |
| 196 | **Data Accuracy and the WHOIS Accuracy Reporting System [Deferred from Phase 2 SSAD Scope]** |  | 2020-05-14 A → 2020-07-31 (+78d) | 225d → 280.5d | 100% → 80% | none → 118.25d |
| 202 | Deliberate policy issues |  | 2020-04-16 A → 2020-06-04 (+49d) | 105d → 140d | 100% → 75% | none → 0d |
| 203 | Develop draft work product |  | 2020-04-30 A → 2020-06-05 (+36d) |  | 100% → 90% | none → 0d |
| 204 | Conduct First Reading + verbal and email response |  | 2020-05-07 A → 2020-06-08 (+32d) |  | 100% → 90% | none → 118.25d |
| 205 | Conduct Second Reading + verbal response + adoption or discard | 2020-05-08 A → 2020-06-08 (+31d) | 2020-05-14 A → 2020-07-31 (+78d) | 5d → 39d | 100% → 0% | none → 118.25d |
| 215 | **Key Events** |  | 2020-07-29 A |  | 95% → 100% | 119.75d → none |
| 265 | **EPDP Team F2F Meeting - Los Angeles (27-30 Jan 2020)** |  | 2020-07-29 A |  | 85% → 100% | 119.75d → none |
| 282 | Manage financial invoice, payment confirmation, and tracking (report to PCST) |  | 2020-07-29 A |  | 50% → 100% | 119.75d → none |
| 283 | Close F2F | 2020-07-29 A | 2020-07-29 A |  | 0% → 100% | 119.75d → none |
| 320 | **FINAL REPORT** |  | 2020-07-29 A |  | 74% → 100% | 120d → none |
| 321 | Review of public comments |  | 2020-07-06 A |  | 75% → 100% | 1.25d → none |
| 322 | Continue deliberations of Priority 1 topics towards a Final Report |  | 2020-07-06 A |  | 75% → 100% | 136.75d → none |
| 323 | Continue deliberations of Priority 2 topics towards a Final Report |  | 2020-07-06 A |  | 75% → 100% | 136.75d → none |
| 325 | Build Final Report & Final Deliberations |  | 2020-07-10 A |  | 50% → 100% | 0d → none |
| 326 | Determine consensus levels on interim recommendations | 2020-07-10 A | 2020-07-29 A |  | 0% → 100% | 120d → none |
| 327 | Adopt final recommendations and report | 2020-07-10 A | 2020-07-29 A |  | 0% → 100% | 0d → none |
| 328 | Submission of Final Report to the GNSO Council | 2020-07-29 A | 2020-07-29 A |  | 0% → 100% | 0d → none |
